Schedule from MS Project, 2015-03-03 to 2016-08-31, status date 2016-08-20.

## Calendars

- Standard: Mon-Sun 08:00-12:00, 13:00-17:00.

## Schedule

| ID | WBS | Task | Type | Duration | Start | Finish | Predecessors | Baseline start | Baseline finish | Baseline duration | Total slack | Free slack | Constraint | Work | Text4 | Text5 | Text1 | Text20 | Text22 |
| --- | --- | --- | --- | --- | --- | --- | --- | --- | --- | --- | --- | --- | --- | --- | --- | --- | --- | --- | --- |
| 1 | 1 | **احداث ساختمان های پادگان ارتش** |  | 548d | 2015-03-03 | 2016-08-31 |  |  |  |  | 0d |  |  | 40339h |  |  |  |  |  |
| 2 | 1.1 | **اقدامات اولیه** |  | 475d | 2015-03-03 | 2016-06-19 |  | 2015-03-03 | 2017-08-24 | 0d? | 73d |  |  |  | 765 روز | 765 روز |  |  |  |
| 3 | 1.1.1 | تحویل زمین | milestone | 0d | 2015-03-03 | 2015-03-03 |  | 2015-03-03 | 2015-03-03 | 0d? | 548d |  |  |  | 0 روز | 0 روز |  |  |  |
| 4 | 1.1.2 | **تجهیز کارگاه** |  | 475d | 2015-03-03 | 2016-06-19 |  | 2015-03-03 | 2017-08-24 | 0d? | 73d |  |  |  | 765 روز | 765 روز |  |  |  |
| 5 | 1.1.2.1 | اولیه ( احداث ساختمانها و تجهیز امکانات اولیه ) |  | 10d | 2015-03-03 | 2015-03-12 |  | 2015-03-03 | 2015-03-15 | 0d? | 500d | 0d |  |  | 10 روز | 10 روز |  |  |  |
| 6 | 1.1.2.2 | مستمر |  | 475d | 2015-03-03 | 2016-06-19 |  | 2015-03-03 | 2017-08-24 | 0d | 73d |  | start no earlier than 2015-03-03 |  | 765 روز | 765 روز | 0% |  |  |
| 7 | 1.1.3 | **تهیه و تامین مصالح مورد نیاز اولیه پروژه** |  | 46d | 2015-03-05 | 2015-04-19 |  | 2015-03-05 | 2015-04-28 | 0d? | 500d |  |  |  | 46 روز | 46 روز |  |  |  |
| 8 | 1.1.3.1 | فاز اول |  | 30d | 2015-03-05 | 2015-04-03 | 5SS+2d | 2015-03-05 | 2015-04-09 | 0d? | 500d | 0d |  |  | 30 روز | 30 روز |  |  |  |
| 9 | 1.1.3.2 | فاز دوم |  | 16d | 2015-04-04 | 2015-04-19 | 8 | 2015-04-09 | 2015-04-28 | 0d? | 500d |  |  |  | 16 روز | 16 روز |  |  |  |
| 10 | 1.1.4 | ابلاغ نقشه های اجرایی به پیمانکار | milestone | 0d | 2015-07-01 | 2015-07-01 |  | 2015-07-01 | 2015-07-01 | 0d | 0d |  | start no earlier than 2015-07-01 |  | 0 روز | 0 روز | 0% | 1.07 | 1.07 |
| 11 | 1.2 | **مجموع فعالیتهای اجرایی ساختمانها** |  | 463d | 2015-05-22 | 2016-08-26 |  |  |  |  | 5d |  |  | 40339h |  |  |  |  |  |
| 12 | 1.2.1 | **ساختمان آسایشگاه توپخانه** |  | 412d | 2015-05-22 | 2016-07-06 |  | 2015-05-20 | 2016-10-01 | 0d | 56d |  |  | 2756.5h | 349 روز | 417 روز | 37% | 296 | 296 |
| 13 | 1.2.1.1 | **عملیات تخریب** |  | 85d | 2015-05-22 | 2015-08-14 |  |  |  |  | 383d |  |  |  |  |  |  |  |  |
| 14 | 1.2.1.1.1 | تخریب دیوارهای پیرامونی و داخلی همکف |  | 10d | 2015-05-22 | 2015-05-31 |  |  |  |  | 383d | 0d | start no earlier than 2015-05-22 |  |  |  |  |  |  |
| 15 | 1.2.1.1.2 | تخریب و جابجایی نعل درگاههای درب و پنجره در همکف |  | 10d | 2015-06-01 | 2015-06-10 | 14 |  |  |  | 383d | 0d |  |  |  |  |  |  |  |
| 16 | 1.2.1.1.3 | وایر برس و اصلاح ضد زنگ همکف |  | 10d | 2015-06-11 | 2015-06-20 | 15 |  |  |  | 383d | 0d |  |  |  |  |  |  |  |
| 17 | 1.2.1.1.4 | تخریب دیوارهای پیرامونی و داخلی طبقه اول |  | 10d | 2015-06-21 | 2015-06-30 | 16 |  |  |  | 383d | 0d |  |  |  |  |  |  |  |
| 18 | 1.2.1.1.5 | جمع آموری و اصلاح لوله های فاضلاب همکف |  | 10d | 2015-07-01 | 2015-07-10 | 17 |  |  |  | 383d | 0d |  |  |  |  |  |  |  |
| 19 | 1.2.1.1.6 | تخریب و جابجایی نعل درگاههای درب و پنجره در طبقه اول |  | 10d | 2015-07-11 | 2015-07-20 | 18 |  |  |  | 383d | 0d |  |  |  |  |  |  |  |
| 20 | 1.2.1.1.7 | جمع آوری و اصلاح لوله های سرد و گرم همکف |  | 5d | 2015-07-21 | 2015-07-25 | 19 |  |  |  | 383d | 0d |  |  |  |  |  |  |  |
| 21 | 1.2.1.1.8 | وایر برس و اصلاح ضد زنگ طبقه اول |  | 5d | 2015-07-26 | 2015-07-30 | 20 |  |  |  | 383d | 0d |  |  |  |  |  |  |  |
| 22 | 1.2.1.1.9 | جمع آوری و اصلاح لوله های فاضلاب طبقه اول |  | 8d | 2015-07-31 | 2015-08-07 | 21 |  |  |  | 383d | 0d |  |  |  |  |  |  |  |
| 23 | 1.2.1.1.10 | جمع آوری و اصلاح لوله های سرد و گرم طبقه اول |  | 7d | 2015-08-08 | 2015-08-14 | 22 |  |  |  | 383d |  |  |  |  |  |  |  |  |
| 24 | 1.2.1.2 | ابلاغ نقشه های فصل مشترک |  | 1d | 2015-07-01 | 2015-07-01 | 10SS |  |  |  | 56d | 0d |  |  |  |  |  |  |  |
| 25 | 1.2.1.3 | ( آماده سازی زمین ) پی کنی فونداسیون اضافه شده طبق نقشه جدید |  | 8d | 2015-07-02 | 2015-07-09 | 24 | 2015-09-20 | 2015-09-28 | 0d | 56d | 0d | start no earlier than 2015-07-02 | 64h | 8 روز | 8 روز | 100% |  |  |

| ID | WBS | Task | Type | Duration | Start | Finish | Predecessors | Baseline start | Baseline finish | Baseline duration | Total slack | Free slack | Work | Text1 | Text4 | Text5 | Text22 |
| --- | --- | --- | --- | --- | --- | --- | --- | --- | --- | --- | --- | --- | --- | --- | --- | --- | --- |
| 26 | 1.2.1.4 | **اجرای سازه** |  | 161d | 2015-07-02 | 2015-12-09 |  | 2015-05-20 | 2016-04-07 | 0d | 56d |  | 2260.5h | 96% | 161 روز | 266 روز | 120 |
| 27 | 1.2.1.4.1 | ساخت و مونتاژ ستون های اضافه شده ضلع شمالی |  | 12d | 2015-07-02 | 2015-07-13 | 25SS | 2015-09-20 | 2015-10-03 | 0d | 56d | 0d | 96h | 100% | 12 روز | 12 روز | 10 |
| 28 | 1.2.1.4.2 | ساخت تیر ورق و تیر های حمال و تودلی بام و خرپشته |  | 45d | 2015-07-02 | 2015-08-15 | 27SS | 2015-09-20 | 2016-01-02 | 0d | 382d |  | 760h | 100% | 90 روز | 90 روز | 120 |
| 29 | 1.2.1.4.3 | ساخت و مونتاژ تیر های پله و قوسی پاگرد ها |  | 19d | 2015-07-02 | 2015-07-20 | 27SS | 2015-09-20 | 2015-10-11 | 0d | 408d |  | 152h | 100% | 19 روز | 19 روز | 15 |
| 30 | 1.2.1.4.4 | پیاده سازی ، رگلاژ و تسطیح | milestone | 5d | 2015-07-14 | 2015-07-18 | 27 | 2015-10-04 | 2015-10-08 | 0d | 56d | 0d | 40h | 100% | 5 روز | 5 روز |  |
| 31 | 1.2.1.4.5 | بتن مگر |  | 6d | 2015-07-19 | 2015-07-24 | 30 | 2015-10-10 | 2015-10-15 | 0d | 56d | 0d | 48h | 100% | 6 روز | 6 روز |  |
| 32 | 1.2.1.4.6 | کاشت میلگرد جهت اتصال پی جدید به قدیم |  | 7d | 2015-07-25 | 2015-07-31 | 31 | 2015-10-17 | 2015-10-24 | 0d | 56d | 0d | 56h | 100% | 7 روز | 7 روز |  |
| 33 | 1.2.1.4.7 | آرماتور بندی |  | 7d | 2015-08-01 | 2015-08-07 | 32 | 2015-10-25 | 2015-11-01 | 0d | 56d | 0d | 56h | 100% | 7 روز | 7 روز |  |
| 34 | 1.2.1.4.8 | قالب بندی |  | 7d | 2015-08-08 | 2015-08-14 | 33 | 2015-11-02 | 2015-11-09 | 0d | 56d | 0d | 56h | 100% | 7 روز | 7 روز |  |
| 35 | 1.2.1.4.9 | نصب بیس پلیت ها و کاشت بولت |  | 9d | 2015-08-15 | 2015-08-23 | 34 | 2015-11-10 | 2015-11-19 | 0d | 56d | 0d | 72h | 100% | 9 روز | 9 روز |  |
| 36 | 1.2.1.4.10 | بتن ریزی فنداسیون |  | 7d | 2015-08-24 | 2015-08-30 | 35 | 2015-11-21 | 2015-11-28 | 0d | 56d | 0d | 56h | 100% | 7 روز | 7 روز |  |
| 37 | 1.2.1.4.11 | نصب ستون های اضافه شده ضلع شمالی |  | 10d | 2015-08-31 | 2015-09-09 | 36 | 2015-11-29 | 2015-12-09 | 0d | 56d | 0d | 64h | 100% | 10 روز | 10 روز |  |
| 38 | 1.2.1.4.12 | توقف بدلیل عدم حضور آزمایشگاه جهت تست جوش |  | 14d | 2015-09-10 | 2015-09-23 | 37 | 2015-12-10 | 2015-12-26 | 0d | 56d | 0d | 112h | 100% | 14 روز | 14 روز |  |
| 39 | 1.2.1.4.13 | نصب تیر های حمال و تودلی بام و خرپشته |  | 45d | 2015-09-24 | 2015-11-07 | 38 | 2015-12-27 | 2016-02-16 | 0d | 266d | 0d | 360h | 100% | 45 روز | 45 روز | 35 |
| 40 | 1.2.1.4.14 | اجرای شمشیری ها و تیر های قوسی راه پله |  | 10d | 2015-09-24 | 2015-10-03 | 38 | 2015-12-27 | 2016-01-06 | 0d | 301d | 35d | 80h | 100% | 10 روز | 10 روز |  |
| 41 | 1.2.1.4.15 | برش کاری و نصب و پانچ ورقهای متال راه پله و بام و خرپشته |  | 11d | 2015-11-08 | 2015-11-18 | 39, 40 | 2016-02-17 | 2016-02-29 | 0d | 266d | 0d | 88h | 100% | 11 روز | 11 روز |  |
| 42 | 1.2.1.4.16 | جوشکاری گل میخ ها |  | 6d | 2015-11-19 | 2015-11-24 | 41 | 2016-03-01 | 2016-03-07 | 0d | 266d | 0d | 48h | 100% | 6 روز | 6 روز |  |
| 43 | 1.2.1.4.17 | آرماتور بندی راه پله، بام و خرپشته |  | 7d | 2015-11-25 | 2015-12-01 | 42 | 2016-03-08 | 2016-03-15 | 0d | 266d | 0d | 52.5h | 50% | 7 روز | 7 روز |  |
| 44 | 1.2.1.4.18 | بتن ریزی راه پله ، بام و خرپشته |  | 8d | 2015-12-02 | 2015-12-09 | 43 | 2016-03-16 | 2016-04-07 | 0d | 266d |  | 64h | 0% | 8 روز | 8 روز |  |
| 45 | 1.2.1.5 | **سفت کاری** |  | 54d | 2015-09-24 | 2015-11-16 |  | 2015-12-27 | 2016-06-22 | 0d | 56d |  |  | 48% | 142 روز | 142 روز |  |
| 46 | 1.2.1.5.1 | **طبقه همکف** |  | 32d | 2015-09-24 | 2015-10-25 |  | 2015-12-27 | 2016-01-25 | 0d | 56d |  |  | 60% | 26 روز | 26 روز |  |
| 47 | 1.2.1.5.1.1 | اجرای بلوکاژ |  | 5d | 2015-09-24 | 2015-09-28 | 38 |  |  |  | 56d | 0d |  |  |  |  |  |
| 48 | 1.2.1.5.1.2 | اجرای دیوارهای پیرامونی |  | 12d | 2015-09-29 | 2015-10-10 | 47 |  |  |  | 56d | 0d |  |  |  |  |  |
| 49 | 1.2.1.5.1.3 | ساخت و نصب نعل درگاه های پیرامونی |  | 12d | 2015-09-29 | 2015-10-10 | 48SS |  |  |  | 321d | 0d |  |  |  |  |  |
| 50 | 1.2.1.5.1.4 | ساخت فریم و چارچوب در و پنجره ها |  | 5d | 2015-09-29 | 2015-10-03 | 49SS |  |  |  | 321d | 0d |  |  |  |  |  |
| 51 | 1.2.1.5.1.5 | ساخت درهای فولادی |  | 12d | 2015-10-04 | 2015-10-15 | 50 |  |  |  | 321d | 0d |  |  |  |  |  |
| 52 | 1.2.1.5.1.6 | اجرای دیوار جداکننده داخلی |  | 5d | 2015-10-11 | 2015-10-15 | 48 |  |  |  | 311d | 0d |  |  |  |  |  |
| 53 | 1.2.1.5.1.7 | ساخت و نصب نعل درگاه های داخلی |  | 10d | 2015-10-04 | 2015-10-13 | 51SS |  |  |  | 323d |  |  |  |  |  |  |
| 54 | 1.2.1.5.1.8 | اجرای گچ و خاک دیوارها |  | 10d | 2015-10-16 | 2015-10-25 | 52 |  |  |  | 311d |  |  |  |  |  |  |

| ID | WBS | Task | Duration | Start | Finish | Predecessors | Total slack | Free slack |
| --- | --- | --- | --- | --- | --- | --- | --- | --- |
| 55 | 1.2.1.5.2 | **طبقه اول** | 25d | 2015-10-11 | 2015-11-04 |  | 56d |  |
| 56 | 1.2.1.5.2.1 | اجرای دیوارهای پیرامونی | 12d | 2015-10-11 | 2015-10-22 | 48 | 56d | 0d |
| 57 | 1.2.1.5.2.2 | ساخت و نصب نعل درگاه های پیرامونی | 5d | 2015-10-11 | 2015-10-15 | 56SS | 276d | 0d |
| 58 | 1.2.1.5.2.3 | اجرای دیوار جداکننده داخلی | 5d | 2015-10-16 | 2015-10-20 | 57 | 276d | 0d |
| 59 | 1.2.1.5.2.4 | ساخت و نصب نعل درگاه های داخلی | 5d | 2015-10-16 | 2015-10-20 | 58SS | 316d |  |
| 60 | 1.2.1.5.2.5 | اجرای گچ و خاک دیوارها | 15d | 2015-10-21 | 2015-11-04 | 58 | 276d | 0d |
| 61 | 1.2.1.5.3 | **طبقه دوم** | 25d | 2015-10-23 | 2015-11-16 |  | 56d |  |
| 62 | 1.2.1.5.3.1 | اجرای دیوارهای پیرامونی | 12d | 2015-10-23 | 2015-11-03 | 56 | 56d | 0d |
| 63 | 1.2.1.5.3.2 | ساخت و نصب نعل درگاه های پیرامونی | 5d | 2015-10-23 | 2015-10-27 | 62SS | 289d | 0d |
| 64 | 1.2.1.5.3.3 | اجرای دیوار جداکننده داخلی | 5d | 2015-10-28 | 2015-11-01 | 63 | 289d | 0d |
| 65 | 1.2.1.5.3.4 | ساخت و نصب نعل درگاه های داخلی | 5d | 2015-10-23 | 2015-10-27 | 63SS | 309d |  |
| 66 | 1.2.1.5.3.5 | اجرای گچ و خاک دیوارها | 15d | 2015-11-02 | 2015-11-16 | 64 | 289d |  |
| 67 | 1.2.1.6 | **بام ( مرحله اول )** | 19d | 2015-11-04 | 2015-11-22 |  | 56d |  |
| 68 | 1.2.1.6.1 | اجرای دیوار جان پناه پشت بام و خرپشته | 6d | 2015-11-04 | 2015-11-09 | 62 | 56d | 0d |
| 69 | 1.2.1.6.2 | سیمانکاری دیوار جانپناه | 3d | 2015-11-10 | 2015-11-12 | 68 | 127d | 0d |
| 70 | 1.2.1.6.3 | رابیتس بندی | 10d | 2015-11-13 | 2015-11-22 | 69 | 127d | 0d |
| 71 | 1.2.1.7 | **اجرای نمای بیرونی** | 95d | 2016-01-23 | 2016-04-26 |  | 127d |  |
| 72 | 1.2.1.7.1 | اجرای سنگ پلاک نما به همراه فتیله | 15d | 2016-01-23 | 2016-02-06 | 70FS+61d | 127d | 0d |
| 73 | 1.2.1.7.2 | اجرای سنگ باکس تیر ها و ستون ها | 45d | 2016-02-07 | 2016-03-22 | 72 | 127d | 0d |
| 74 | 1.2.1.7.3 | اجرای سنگ پیش آمدگی ها | 35d | 2016-03-23 | 2016-04-26 | 73 | 127d |  |
| 75 | 1.2.1.7.4 | اجرای آستر سیمان سیاه دیوار جهت زیر سازی نمای شسته | 45d | 2016-01-23 | 2016-03-07 | 72SS | 142d | 0d |
| 76 | 1.2.1.7.5 | اجرای نمای شسته | 60d | 2016-02-02 | 2016-04-01 | 75SS+10d | 142d | 0d |
| 77 | 1.2.1.7.6 | اجرای درپوش بتنی جانپناه و کف پنجره ها | 10d | 2016-04-02 | 2016-04-11 | 76 | 142d |  |
| 78 | 1.2.1.8 | **تاسیسات مکانیکی ( مرحله اول )** | 50d | 2015-11-10 | 2015-12-29 |  | 56d |  |
| 79 | 1.2.1.8.1 | سوراخکاری و شیارزنی و کنده کاری داکت | 4d | 2015-11-10 | 2015-11-13 | 68 | 56d | 0d |
| 80 | 1.2.1.8.2 | کانال کنی تاسیسات | 5d | 2015-11-10 | 2015-11-14 | 79SS | 56d | 0d |
| 81 | 1.2.1.8.3 | لوله کشی پلی اتیلن فاضلاب و آب باران | 10d | 2015-11-15 | 2015-11-24 | 80 | 56d | 0d |
| 82 | 1.2.1.8.4 | ساپورتهای لوله کشی تاسیسات | 5d | 2015-11-15 | 2015-11-19 | 81SS | 276d | 0d |
| 83 | 1.2.1.8.5 | لوله کشی گالوانیزه آب سرد و گرم | 10d | 2015-11-20 | 2015-11-29 | 82 | 276d |  |
| 84 | 1.2.1.8.6 | لوله کشی لوله های گرمایشی و پنج لایه | 20d | 2015-11-25 | 2015-12-14 | 81 | 56d | 0d |
| 85 | 1.2.1.8.7 | اجرای ساپورتهای کانال کولر | 5d | 2015-11-25 | 2015-11-29 | 81 | 246d | 0d |
| 86 | 1.2.1.8.8 | اجرای کانال کولر | 30d | 2015-11-30 | 2015-12-29 | 85 | 246d | 0d |
| 87 | 1.2.1.8.9 | اجرای کانال اگزاست | 20d | 2015-11-30 | 2015-12-19 | 86SS | 256d | 0d |
| 88 | 1.2.1.8.10 | عایق پشم شیشه و تست | 5d | 2015-12-15 | 2015-12-19 | 84 | 256d |  |
| 89 | 1.2.1.8.11 | اجرای لوله هایPVC | 2d | 2015-11-15 | 2015-11-16 | 81SS | 289d |  |

| ID | WBS | Task | Duration | Start | Finish | Predecessors | Total slack | Free slack |
| --- | --- | --- | --- | --- | --- | --- | --- | --- |
| 90 | 1.2.1.9 | **تاسیسات الکتریکی ( مرحله اول )** | 30d | 2015-11-05 | 2015-12-04 |  | 271d |  |
| 91 | 1.2.1.9.1 | شیارزنی | 10d | 2015-11-05 | 2015-11-14 | 60 | 276d | 0d |
| 92 | 1.2.1.9.2 | اجرای لوله های PVC . PG13/5 | 15d | 2015-11-15 | 2015-11-29 | 91 | 276d | 0d |
| 93 | 1.2.1.9.3 | اجرای لوله های PVC . PG16-42 | 15d | 2015-11-15 | 2015-11-29 | 92SS | 276d | 0d |
| 94 | 1.2.1.9.4 | تهیه ساخت و سفارش تابلو برق | 10d | 2015-11-05 | 2015-11-14 | 91SS | 290d | 0d |
| 95 | 1.2.1.9.5 | غلاف گزاری | 3d | 2015-11-15 | 2015-11-17 | 93SS | 288d |  |
| 96 | 1.2.1.9.6 | سینی کابل | 5d | 2015-11-30 | 2015-12-04 | 87SS | 271d |  |
| 97 | 1.2.1.9.7 | نصب تابلو | 1d | 2015-11-15 | 2015-11-15 | 94 | 290d |  |
| 98 | 1.2.1.10 | **بام ( مرحله دوم )** | 42d | 2015-11-25 | 2016-01-05 |  | 239d |  |
| 99 | 1.2.1.10.1 | شیب بندی و اجرای بتن سبک بام | 5d | 2015-11-25 | 2015-11-29 | 81 | 239d | 0d |
| 100 | 1.2.1.10.2 | اجرای سیمانکاری لیسه ای زیر عایق | 2d | 2015-11-30 | 2015-12-01 | 99 | 239d | 0d |
| 101 | 1.2.1.10.3 | اجرای عایق پشت بام | 2d | 2015-12-02 | 2015-12-03 | 100 | 239d | 0d |
| 102 | 1.2.1.10.4 | نصب تور مرغی قبل از سنگ اندود | 1d | 2015-12-04 | 2015-12-04 | 101 | 239d | 0d |
| 103 | 1.2.1.10.5 | اجرای سنگ قرنیز لاشتر | 4d | 2015-12-05 | 2015-12-08 | 102 | 239d | 0d |
| 104 | 1.2.1.10.6 | اجرای آستر سیمان سیاه و سفید بام | 10d | 2015-12-09 | 2015-12-18 | 103 | 239d | 0d |
| 105 | 1.2.1.10.7 | شیب بندی و اجرای موزاییک بام | 15d | 2015-12-19 | 2016-01-02 | 104 | 239d | 0d |
| 106 | 1.2.1.10.8 | نصب قرنیز گالوانیزه بام | 3d | 2016-01-03 | 2016-01-05 | 105 | 239d |  |
| 107 | 1.2.1.11 | **نازک کاری** | 127d | 2016-02-13 | 2016-06-18 |  | 56d |  |
| 108 | 1.2.1.11.1 | **طبقه همکف** | 49d | 2016-02-13 | 2016-04-01 |  | 56d |  |
| 109 | 1.2.1.11.1.1 | اجرای کرم بندی و شیب بندی سرویسها و سالن غذاخوری | 5d | 2016-02-13 | 2016-02-17 | 84FS+60d | 56d | 0d |
| 110 | 1.2.1.11.1.2 | اجرای عایق رطوبتی سالن غذاخوری و سرویسها | 4d | 2016-02-18 | 2016-02-21 | 109 | 56d | 0d |
| 111 | 1.2.1.11.1.3 | اجرای سیمان محافظ روی عایق | 2d | 2016-02-22 | 2016-02-23 | 110 | 190d |  |
| 112 | 1.2.1.11.1.4 | چیدن دیوارهای داکت | 6d | 2016-02-13 | 2016-02-18 | 109SS | 195d |  |
| 113 | 1.2.1.11.1.5 | نصب چارچوبهای در و پنجره | 5d | 2016-02-13 | 2016-02-17 | 109SS | 196d |  |
| 114 | 1.2.1.11.1.6 | اجرای قرنیز و سنگ و پلاک فضای داخلی دیوارها | 15d | 2016-02-22 | 2016-03-07 | 110 | 56d | 0d |
| 115 | 1.2.1.11.1.7 | اجرای گچ سفید دیوارها | 15d | 2016-03-08 | 2016-03-22 | 114 | 152d | 0d |
| 116 | 1.2.1.11.1.8 | اجرای کاشی دیوار سرویسها | 25d | 2016-02-22 | 2016-03-17 | 110 | 157d | 0d |
| 117 | 1.2.1.11.1.9 | اجرای سرامیک کف | 10d | 2016-03-18 | 2016-03-27 | 116 | 157d |  |
| 118 | 1.2.1.11.1.10 | اجرای سنگ گرانیت و چینی و موزائیک کف | 10d | 2016-03-08 | 2016-03-17 | 114 | 167d |  |
| 119 | 1.2.1.11.1.11 | اجرای سقف کاذب ( کناف فضای داخلی ) | 10d | 2016-03-23 | 2016-04-01 | 115 | 152d |  |
| 120 | 1.2.1.11.1.12 | اجرای سقف کاذب ( سرویس بهداشتی ) | 4d | 2016-03-18 | 2016-03-21 | 116 | 163d |  |

| ID | WBS | Task | Duration | Start | Finish | Predecessors | Total slack | Free slack |
| --- | --- | --- | --- | --- | --- | --- | --- | --- |
| 121 | 1.2.1.11.2 | **طبقه اول** | 36d | 2016-02-18 | 2016-03-24 |  | 157d |  |
| 122 | 1.2.1.11.2.1 | کرم بندی و شیب بندی | 3d | 2016-02-18 | 2016-02-20 | 109 | 157d | 0d |
| 123 | 1.2.1.11.2.2 | نصب چارچوبهای در و پنجره | 3d | 2016-02-21 | 2016-02-23 | 122 | 160d | 0d |
| 124 | 1.2.1.11.2.3 | اجرای قرنیز و سنگ و پلاک فضای داخلی دیوارها | 10d | 2016-02-24 | 2016-03-04 | 123 | 160d | 0d |
| 125 | 1.2.1.11.2.4 | اجرای سنگ گرانیت کف | 5d | 2016-03-05 | 2016-03-09 | 124 | 160d | 0d |
| 126 | 1.2.1.11.2.5 | اجرای گچ سفید | 5d | 2016-03-10 | 2016-03-14 | 125 | 170d |  |
| 127 | 1.2.1.11.2.6 | اجرای سقف کاذب ( کناف فضای داخلی ) | 15d | 2016-03-10 | 2016-03-24 | 125 | 160d |  |
| 128 | 1.2.1.11.3 | **طبقه دوم** | 36d | 2016-02-21 | 2016-03-27 |  | 157d |  |
| 129 | 1.2.1.11.3.1 | کرم بندی و شیب بندی | 3d | 2016-02-21 | 2016-02-23 | 122 | 157d | 0d |
| 130 | 1.2.1.11.3.2 | نصب چارچوبهای در و پنجره | 3d | 2016-02-24 | 2016-02-26 | 129 | 157d | 0d |
| 131 | 1.2.1.11.3.3 | اجرای قرنیز و سنگ و پلاک فضای داخلی دیوارها | 10d | 2016-02-27 | 2016-03-07 | 130 | 157d | 0d |
| 132 | 1.2.1.11.3.4 | اجرای سنگ گرانیت کف | 5d | 2016-03-08 | 2016-03-12 | 131 | 157d | 0d |
| 133 | 1.2.1.11.3.5 | اجرای گچ سفید | 5d | 2016-03-13 | 2016-03-17 | 132 | 157d | 0d |
| 134 | 1.2.1.11.3.6 | اجرای سقف کاذب ( کناف فضای داخلی ) | 10d | 2016-03-18 | 2016-03-27 | 133 | 157d |  |
| 135 | 1.2.1.11.4 | **راه پله** | 73d | 2016-03-08 | 2016-05-19 |  | 56d |  |
| 136 | 1.2.1.11.4.1 | اجرای سنگ بدنه | 15d | 2016-03-08 | 2016-03-22 | 114 | 56d | 0d |
| 137 | 1.2.1.11.4.2 | اجرای سنگ پله ها | 20d | 2016-03-23 | 2016-04-11 | 136 | 56d | 0d |
| 138 | 1.2.1.11.4.3 | اجرای رابتس زیر پله | 5d | 2016-04-12 | 2016-04-16 | 137 | 56d | 0d |
| 139 | 1.2.1.11.4.4 | اجرای گچ و خاک پله ها | 12d | 2016-04-17 | 2016-04-28 | 138 | 56d | 0d |
| 140 | 1.2.1.11.4.5 | اجرای گچ سفید | 15d | 2016-04-29 | 2016-05-13 | 139 | 56d | 0d |
| 141 | 1.2.1.11.4.6 | اجرای لگه گیری گچ سفید زیر و بغل پله | 6d | 2016-05-14 | 2016-05-19 | 140 | 104d |  |
| 142 | 1.2.1.11.5 | **نصبیات و تکمیلی نازک کاری** | 36d | 2016-05-14 | 2016-06-18 |  | 74d |  |
| 143 | 1.2.1.11.5.1 | نصب در و پنجره های جوبی ، فولادی و UPVC | 8d | 2016-05-14 | 2016-05-21 | 140 | 74d | 0d |
| 144 | 1.2.1.11.5.2 | نصب شیشه ها | 8d | 2016-05-22 | 2016-05-29 | 143 | 74d | 0d |
| 145 | 1.2.1.11.5.3 | رنگ آمیزی سقف و دیوار | 20d | 2016-05-30 | 2016-06-18 | 144 | 74d |  |

| ID | WBS | Task | Duration | Start | Finish | Predecessors | Baseline start | Baseline finish | Baseline duration | Total slack | Free slack | Constraint | Work | Text1 | Text4 | Text5 | Text22 | Text20 |
| --- | --- | --- | --- | --- | --- | --- | --- | --- | --- | --- | --- | --- | --- | --- | --- | --- | --- | --- |
| 146 | 1.2.1.12 | **تاسیسات الکتریکی ( مرحله دوم )** | 47d | 2016-05-14 | 2016-06-29 |  | 2016-01-05 | 2016-08-04 | 0d | 56d |  |  | 72h | 7% | 170 | 170 | 73 |  |
| 147 | 1.2.1.12.1 | اجرای سیم کشی و کابل کشی ساختمان | 20d | 2016-05-14 | 2016-06-02 | 140 |  |  |  | 56d | 0d |  |  |  |  |  |  |  |
| 148 | 1.2.1.12.2 | کابل کشی مخابرات و تجهیزات مربوطه | 7d | 2016-06-03 | 2016-06-09 | 147 |  |  |  | 76d | 0d |  |  |  |  |  |  |  |
| 149 | 1.2.1.12.3 | اجرا و نصب تابلو برق و جریان ضعیف | 7d | 2016-06-10 | 2016-06-16 | 148 |  |  |  | 76d |  |  |  |  |  |  |  |  |
| 150 | 1.2.1.12.4 | کلید و پریز | 7d | 2016-06-03 | 2016-06-09 | 147 |  |  |  | 56d | 0d |  |  |  |  |  |  |  |
| 151 | 1.2.1.12.5 | چراغ های ایندور | 7d | 2016-06-10 | 2016-06-16 | 150 |  |  |  | 56d | 0d |  |  |  |  |  |  |  |
| 152 | 1.2.1.12.6 | سیستم اعلام حریق | 7d | 2016-06-17 | 2016-06-23 | 151 |  |  |  | 56d | 0d |  |  |  |  |  |  |  |
| 153 | 1.2.1.12.7 | سیستم آنتن مرکزی | 3d | 2016-06-24 | 2016-06-26 | 152 |  |  |  | 56d | 0d |  |  |  |  |  |  |  |
| 154 | 1.2.1.12.8 | ارت سازی | 3d | 2016-06-27 | 2016-06-29 | 153 | 2016-01-05 | 2016-01-14 | 0d | 56d | 0d |  | 72h | 60% | 9 روز | 9 روز | 10 |  |
| 155 | 1.2.1.13 | **تاسیسات مکانیکی ( مرحله دوم )** | 7d | 2016-06-30 | 2016-07-06 |  |  |  |  | 56d |  |  | 360h |  |  |  |  |  |
| 156 | 1.2.1.13.1 | شیر آلات بهداشتی | 4d | 2016-06-30 | 2016-07-03 | 154 | 2016-01-28 | 2016-02-11 | 0d | 56d | 0d |  | 104h | 100% | 13 روز | 13 روز | 10 |  |
| 157 | 1.2.1.13.2 | تجهیزات آتش نشانی | 4d | 2016-06-30 | 2016-07-03 | 156SS |  |  |  | 59d |  |  |  |  |  |  |  |  |
| 158 | 1.2.1.13.3 | نصب رادیاتور | 4d | 2016-06-30 | 2016-07-03 | 156SS | 2016-02-13 | 2016-02-23 | 0d | 56d | 0d |  | 80h | 0% | 10 روز | 10 روز |  |  |
| 159 | 1.2.1.13.4 | نصب دریچه های هوا و کولر | 3d | 2016-07-04 | 2016-07-06 | 158 | 2016-02-24 | 2016-04-03 | 0d | 56d |  |  | 176h | 0% | 22 روز | 22 روز | 12 |  |
| 160 | 1.2.2 | **ساختمان آسایشگاه پیاده** | 406d | 2015-05-22 | 2016-06-30 |  | 2015-05-20 | 2016-10-01 | 0d | 62d |  |  | 2756.5h | 37% | 349 روز | 417 روز | 296 | 296 |
| 161 | 1.2.2.1 | **عملیات تخریب** | 85d | 2015-05-22 | 2015-08-14 |  |  |  |  | 383d |  |  |  |  |  |  |  |  |
| 162 | 1.2.2.1.1 | تخریب دیوارهای پیرامونی و داخلی همکف | 10d | 2015-05-22 | 2015-05-31 |  |  |  |  | 383d | 0d | start no earlier than 2015-05-22 |  |  |  |  |  |  |
| 163 | 1.2.2.1.2 | تخریب و جابجایی نعل درگاههای درب و پنجره در همکف | 10d | 2015-06-01 | 2015-06-10 | 162 |  |  |  | 383d | 0d |  |  |  |  |  |  |  |
| 164 | 1.2.2.1.3 | وایر برس و اصلاح ضد زنگ همکف | 10d | 2015-06-11 | 2015-06-20 | 163 |  |  |  | 383d | 0d |  |  |  |  |  |  |  |
| 165 | 1.2.2.1.4 | تخریب دیوارهای پیرامونی و داخلی طبقه اول | 10d | 2015-06-21 | 2015-06-30 | 164 |  |  |  | 383d | 0d |  |  |  |  |  |  |  |
| 166 | 1.2.2.1.5 | جمع آموری و اصلاح لوله های فاضلاب همکف | 10d | 2015-07-01 | 2015-07-10 | 165 |  |  |  | 383d | 0d |  |  |  |  |  |  |  |
| 167 | 1.2.2.1.6 | تخریب و جابجایی نعل درگاههای درب و پنجره در طبقه اول | 10d | 2015-07-11 | 2015-07-20 | 166 |  |  |  | 383d | 0d |  |  |  |  |  |  |  |
| 168 | 1.2.2.1.7 | جمع آوری و اصلاح لوله های سرد و گرم همکف | 5d | 2015-07-21 | 2015-07-25 | 167 |  |  |  | 383d | 0d |  |  |  |  |  |  |  |
| 169 | 1.2.2.1.8 | وایر برس و اصلاح ضد زنگ طبقه اول | 5d | 2015-07-26 | 2015-07-30 | 168 |  |  |  | 383d | 0d |  |  |  |  |  |  |  |
| 170 | 1.2.2.1.9 | جمع آوری و اصلاح لوله های فاضلاب طبقه اول | 8d | 2015-07-31 | 2015-08-07 | 169 |  |  |  | 383d | 0d |  |  |  |  |  |  |  |
| 171 | 1.2.2.1.10 | جمع آوری و اصلاح لوله های سرد و گرم طبقه اول | 7d | 2015-08-08 | 2015-08-14 | 170 |  |  |  | 383d |  |  |  |  |  |  |  |  |
| 172 | 1.2.2.2 | ابلاغ نقشه های فصل مشترک | 1d | 2015-07-02 | 2015-07-02 | 10 |  |  |  | 62d | 0d | start no earlier than 2015-07-02 |  |  |  |  |  |  |
| 173 | 1.2.2.3 | ( آماده سازی زمین ) پی کنی فونداسیون اضافه شده طبق نقشه جدید | 10d | 2015-07-03 | 2015-07-12 | 172 | 2015-09-20 | 2015-09-28 | 0d | 62d | 0d | start no earlier than 2015-07-02 | 64h | 100% | 8 روز | 8 روز |  |  |

| ID | WBS | Task | Type | Duration | Start | Finish | Predecessors | Baseline start | Baseline finish | Baseline duration | Total slack | Free slack | Work | Text1 | Text4 | Text5 | Text22 |
| --- | --- | --- | --- | --- | --- | --- | --- | --- | --- | --- | --- | --- | --- | --- | --- | --- | --- |
| 174 | 1.2.2.4 | **اجرای سازه** |  | 161d | 2015-07-03 | 2015-12-10 |  | 2015-05-20 | 2016-04-07 | 0d | 62d |  | 2260.5h | 96% | 161 روز | 266 روز | 120 |
| 175 | 1.2.2.4.1 | ساخت و مونتاژ ستون های اضافه شده ضلع شمالی |  | 12d | 2015-07-03 | 2015-07-14 | 173SS | 2015-09-20 | 2015-10-03 | 0d | 62d | 0d | 96h | 100% | 12 روز | 12 روز | 10 |
| 176 | 1.2.2.4.2 | ساخت تیر ورق و تیر های حمال و تودلی بام و خرپشته |  | 45d | 2015-07-03 | 2015-08-16 | 175SS | 2015-09-20 | 2016-01-02 | 0d | 381d |  | 760h | 100% | 90 روز | 90 روز | 120 |
| 177 | 1.2.2.4.3 | ساخت و مونتاژ تیر های پله و قوسی پاگرد ها |  | 19d | 2015-07-03 | 2015-07-21 | 175SS | 2015-09-20 | 2015-10-11 | 0d | 407d |  | 152h | 100% | 19 روز | 19 روز | 15 |
| 178 | 1.2.2.4.4 | پیاده سازی ، رگلاژ و تسطیح | milestone | 5d | 2015-07-15 | 2015-07-19 | 175 | 2015-10-04 | 2015-10-08 | 0d | 62d | 0d | 40h | 100% | 5 روز | 5 روز |  |
| 179 | 1.2.2.4.5 | بتن مگر |  | 6d | 2015-07-20 | 2015-07-25 | 178 | 2015-10-10 | 2015-10-15 | 0d | 62d | 0d | 48h | 100% | 6 روز | 6 روز |  |
| 180 | 1.2.2.4.6 | کاشت میلگرد جهت اتصال پی جدید به قدیم |  | 7d | 2015-07-26 | 2015-08-01 | 179 | 2015-10-17 | 2015-10-24 | 0d | 62d | 0d | 56h | 100% | 7 روز | 7 روز |  |
| 181 | 1.2.2.4.7 | آرماتور بندی |  | 7d | 2015-08-02 | 2015-08-08 | 180 | 2015-10-25 | 2015-11-01 | 0d | 62d | 0d | 56h | 100% | 7 روز | 7 روز |  |
| 182 | 1.2.2.4.8 | قالب بندی |  | 7d | 2015-08-09 | 2015-08-15 | 181 | 2015-11-02 | 2015-11-09 | 0d | 62d | 0d | 56h | 100% | 7 روز | 7 روز |  |
| 183 | 1.2.2.4.9 | نصب بیس پلیت ها و کاشت بولت |  | 9d | 2015-08-16 | 2015-08-24 | 182 | 2015-11-10 | 2015-11-19 | 0d | 62d | 0d | 72h | 100% | 9 روز | 9 روز |  |
| 184 | 1.2.2.4.10 | بتن ریزی فنداسیون |  | 7d | 2015-08-25 | 2015-08-31 | 183 | 2015-11-21 | 2015-11-28 | 0d | 62d | 0d | 56h | 100% | 7 روز | 7 روز |  |
| 185 | 1.2.2.4.11 | نصب ستون های اضافه شده ضلع شمالی |  | 10d | 2015-09-01 | 2015-09-10 | 184 | 2015-11-29 | 2015-12-09 | 0d | 62d | 0d | 64h | 100% | 10 روز | 10 روز |  |
| 186 | 1.2.2.4.12 | توقف بدلیل عدم حضور آزمایشگاه جهت تست جوش |  | 14d | 2015-09-11 | 2015-09-24 | 185 | 2015-12-10 | 2015-12-26 | 0d | 62d | 0d | 112h | 100% | 14 روز | 14 روز |  |
| 187 | 1.2.2.4.13 | نصب تیر های حمال و تودلی بام و خرپشته |  | 45d | 2015-09-25 | 2015-11-08 | 186 | 2015-12-27 | 2016-02-16 | 0d | 265d | 0d | 360h | 100% | 45 روز | 45 روز | 35 |
| 188 | 1.2.2.4.14 | اجرای شمشیری ها و تیر های قوسی راه پله |  | 10d | 2015-09-25 | 2015-10-04 | 186 | 2015-12-27 | 2016-01-06 | 0d | 300d | 35d | 80h | 100% | 10 روز | 10 روز |  |
| 189 | 1.2.2.4.15 | برش کاری و نصب و پانچ ورقهای متال راه پله و بام و خرپشته |  | 11d | 2015-11-09 | 2015-11-19 | 187, 188 | 2016-02-17 | 2016-02-29 | 0d | 265d | 0d | 88h | 100% | 11 روز | 11 روز |  |
| 190 | 1.2.2.4.16 | جوشکاری گل میخ ها |  | 6d | 2015-11-20 | 2015-11-25 | 189 | 2016-03-01 | 2016-03-07 | 0d | 265d | 0d | 48h | 100% | 6 روز | 6 روز |  |
| 191 | 1.2.2.4.17 | آرماتور بندی راه پله، بام و خرپشته |  | 7d | 2015-11-26 | 2015-12-02 | 190 | 2016-03-08 | 2016-03-15 | 0d | 265d | 0d | 52.5h | 50% | 7 روز | 7 روز |  |
| 192 | 1.2.2.4.18 | بتن ریزی راه پله ، بام و خرپشته |  | 8d | 2015-12-03 | 2015-12-10 | 191 | 2016-03-16 | 2016-04-07 | 0d | 265d |  | 64h | 0% | 8 روز | 8 روز |  |
| 193 | 1.2.2.5 | **سفت کاری** |  | 75d | 2015-09-25 | 2015-12-08 |  | 2015-12-27 | 2016-06-22 | 0d | 62d |  |  | 48% | 142 روز | 142 روز |  |
| 194 | 1.2.2.5.1 | **طبقه همکف** |  | 45d | 2015-09-25 | 2015-11-08 |  | 2015-12-27 | 2016-01-25 | 0d | 62d |  |  | 60% | 26 روز | 26 روز |  |
| 195 | 1.2.2.5.1.1 | اجرای بلوکاژ |  | 5d | 2015-09-25 | 2015-09-29 | 186 |  |  |  | 62d | 0d |  |  |  |  |  |
| 196 | 1.2.2.5.1.2 | اجرای دیوارهای پیرامونی |  | 15d | 2015-09-30 | 2015-10-14 | 195 |  |  |  | 62d | 0d |  |  |  |  |  |
| 197 | 1.2.2.5.1.3 | ساخت و نصب نعل درگاه های پیرامونی |  | 15d | 2015-09-30 | 2015-10-14 | 196SS |  |  |  | 320d | 0d |  |  |  |  |  |
| 198 | 1.2.2.5.1.4 | ساخت فریم و چارچوب در و پنجره ها |  | 7d | 2015-09-30 | 2015-10-06 | 197SS |  |  |  | 320d | 0d |  |  |  |  |  |
| 199 | 1.2.2.5.1.5 | ساخت درهای فولادی |  | 10d | 2015-10-07 | 2015-10-16 | 198 |  |  |  | 320d | 0d |  |  |  |  |  |
| 200 | 1.2.2.5.1.6 | اجرای دیوار جداکننده داخلی |  | 15d | 2015-10-15 | 2015-10-29 | 196 |  |  |  | 297d | 0d |  |  |  |  |  |
| 201 | 1.2.2.5.1.7 | ساخت و نصب نعل درگاه های داخلی |  | 10d | 2015-10-07 | 2015-10-16 | 199SS |  |  |  | 320d |  |  |  |  |  |  |
| 202 | 1.2.2.5.1.8 | اجرای گچ و خاک دیوارها |  | 10d | 2015-10-30 | 2015-11-08 | 200 |  |  |  | 297d |  |  |  |  |  |  |

| ID | WBS | Task | Duration | Start | Finish | Predecessors | Total slack | Free slack |
| --- | --- | --- | --- | --- | --- | --- | --- | --- |
| 203 | 1.2.2.5.2 | **طبقه اول** | 40d | 2015-10-15 | 2015-11-23 |  | 62d |  |
| 204 | 1.2.2.5.2.1 | اجرای دیوارهای پیرامونی | 15d | 2015-10-15 | 2015-10-29 | 196 | 62d | 0d |
| 205 | 1.2.2.5.2.2 | ساخت و نصب نعل درگاه های پیرامونی | 15d | 2015-10-15 | 2015-10-29 | 204SS | 257d | 0d |
| 206 | 1.2.2.5.2.3 | اجرای دیوار جداکننده داخلی | 15d | 2015-10-30 | 2015-11-13 | 205 | 257d | 0d |
| 207 | 1.2.2.5.2.4 | ساخت و نصب نعل درگاه های داخلی | 10d | 2015-10-30 | 2015-11-08 | 206SS | 297d |  |
| 208 | 1.2.2.5.2.5 | اجرای گچ و خاک دیوارها | 10d | 2015-11-14 | 2015-11-23 | 206 | 257d | 0d |
| 209 | 1.2.2.5.3 | **طبقه دوم** | 40d | 2015-10-30 | 2015-12-08 |  | 62d |  |
| 210 | 1.2.2.5.3.1 | اجرای دیوارهای پیرامونی | 15d | 2015-10-30 | 2015-11-13 | 204 | 62d | 0d |
| 211 | 1.2.2.5.3.2 | ساخت و نصب نعل درگاه های پیرامونی | 15d | 2015-10-30 | 2015-11-13 | 210SS | 267d | 0d |
| 212 | 1.2.2.5.3.3 | اجرای دیوار جداکننده داخلی | 15d | 2015-11-14 | 2015-11-28 | 211 | 267d | 0d |
| 213 | 1.2.2.5.3.4 | ساخت و نصب نعل درگاه های داخلی | 10d | 2015-10-30 | 2015-11-08 | 211SS | 297d |  |
| 214 | 1.2.2.5.3.5 | اجرای گچ و خاک دیوارها | 10d | 2015-11-29 | 2015-12-08 | 212 | 267d |  |
| 215 | 1.2.2.6 | **بام ( مرحله اول )** | 19d | 2015-11-14 | 2015-12-02 |  | 62d |  |
| 216 | 1.2.2.6.1 | اجرای دیوار جان پناه پشت بام و خرپشته | 6d | 2015-11-14 | 2015-11-19 | 210 | 62d | 0d |
| 217 | 1.2.2.6.2 | سیمانکاری دیوار جانپناه | 3d | 2015-11-20 | 2015-11-22 | 216 | 130d | 0d |
| 218 | 1.2.2.6.3 | رابیتس بندی | 10d | 2015-11-23 | 2015-12-02 | 217 | 130d | 0d |
| 219 | 1.2.2.7 | **اجرای نمای بیرونی** | 82d | 2016-02-02 | 2016-04-23 |  | 130d |  |
| 220 | 1.2.2.7.1 | اجرای سنگ پلاک نما به همراه فتیله | 7d | 2016-02-02 | 2016-02-08 | 218FS+61d | 130d | 0d |
| 221 | 1.2.2.7.2 | اجرای سنگ باکس تیر ها و ستون ها | 45d | 2016-02-09 | 2016-03-24 | 220 | 130d | 0d |
| 222 | 1.2.2.7.3 | اجرای سنگ پیش آمدگی ها | 30d | 2016-03-25 | 2016-04-23 | 221 | 130d |  |
| 223 | 1.2.2.7.4 | اجرای آستر سیمان سیاه دیوار جهت زیر سازی نمای شسته | 40d | 2016-02-02 | 2016-03-12 | 220SS | 132d | 0d |
| 224 | 1.2.2.7.5 | اجرای نمای شسته | 60d | 2016-02-12 | 2016-04-11 | 223SS+10d | 132d | 0d |
| 225 | 1.2.2.7.6 | اجرای درپوش بتنی جانپناه و کف پنجره ها | 10d | 2016-04-12 | 2016-04-21 | 224 | 132d |  |
| 226 | 1.2.2.8 | **تاسیسات مکانیکی ( مرحله اول )** | 50d | 2015-11-20 | 2016-01-08 |  | 62d |  |
| 227 | 1.2.2.8.1 | سوراخکاری و شیارزنی و کنده کاری داکت | 4d | 2015-11-20 | 2015-11-23 | 216 | 62d | 0d |
| 228 | 1.2.2.8.2 | کانال کنی تاسیسات | 5d | 2015-11-20 | 2015-11-24 | 227SS | 62d | 0d |
| 229 | 1.2.2.8.3 | لوله کشی پلی اتیلن فاضلاب و آب باران | 10d | 2015-11-25 | 2015-12-04 | 228 | 62d | 0d |
| 230 | 1.2.2.8.4 | ساپورتهای لوله کشی تاسیسات | 5d | 2015-11-25 | 2015-11-29 | 229SS | 266d | 0d |
| 231 | 1.2.2.8.5 | لوله کشی گالوانیزه آب سرد و گرم | 10d | 2015-11-30 | 2015-12-09 | 230 | 266d |  |
| 232 | 1.2.2.8.6 | لوله کشی لوله های گرمایشی و پنج لایه | 20d | 2015-12-05 | 2015-12-24 | 229 | 62d | 0d |
| 233 | 1.2.2.8.7 | اجرای ساپورتهای کانال کولر | 5d | 2015-12-05 | 2015-12-09 | 229 | 236d | 0d |
| 234 | 1.2.2.8.8 | اجرای کانال کولر | 30d | 2015-12-10 | 2016-01-08 | 233 | 236d | 0d |
| 235 | 1.2.2.8.9 | اجرای کانال اگزاست | 20d | 2015-12-10 | 2015-12-29 | 234SS | 246d | 0d |
| 236 | 1.2.2.8.10 | عایق پشم شیشه و تست | 5d | 2015-12-25 | 2015-12-29 | 232 | 246d |  |
| 237 | 1.2.2.8.11 | اجرای لوله هایPVC | 2d | 2015-11-25 | 2015-11-26 | 229SS | 279d |  |

| ID | WBS | Task | Duration | Start | Finish | Predecessors | Total slack | Free slack |
| --- | --- | --- | --- | --- | --- | --- | --- | --- |
| 238 | 1.2.2.9 | **تاسیسات الکتریکی ( مرحله اول )** | 25d | 2015-11-24 | 2015-12-18 |  | 257d |  |
| 239 | 1.2.2.9.1 | شیارزنی | 10d | 2015-11-24 | 2015-12-03 | 208 | 257d | 0d |
| 240 | 1.2.2.9.2 | اجرای لوله های PVC . PG13/5 | 15d | 2015-12-04 | 2015-12-18 | 239 | 257d | 0d |
| 241 | 1.2.2.9.3 | اجرای لوله های PVC . PG16-42 | 15d | 2015-12-04 | 2015-12-18 | 240SS | 257d | 0d |
| 242 | 1.2.2.9.4 | تهیه ساخت و سفارش تابلو برق | 10d | 2015-11-24 | 2015-12-03 | 239SS | 271d | 0d |
| 243 | 1.2.2.9.5 | غلاف گزاری | 3d | 2015-12-04 | 2015-12-06 | 241SS | 269d |  |
| 244 | 1.2.2.9.6 | سینی کابل | 5d | 2015-12-10 | 2015-12-14 | 235SS | 261d |  |
| 245 | 1.2.2.9.7 | نصب تابلو | 1d | 2015-12-04 | 2015-12-04 | 242 | 271d |  |
| 246 | 1.2.2.10 | **بام ( مرحله دوم )** | 42d | 2015-12-05 | 2016-01-15 |  | 229d |  |
| 247 | 1.2.2.10.1 | شیب بندی و اجرای بتن سبک بام | 5d | 2015-12-05 | 2015-12-09 | 229 | 229d | 0d |
| 248 | 1.2.2.10.2 | اجرای سیمانکاری لیسه ای زیر عایق | 2d | 2015-12-10 | 2015-12-11 | 247 | 229d | 0d |
| 249 | 1.2.2.10.3 | اجرای عایق پشت بام | 2d | 2015-12-12 | 2015-12-13 | 248 | 229d | 0d |
| 250 | 1.2.2.10.4 | نصب تور مرغی قبل از سنگ اندود | 1d | 2015-12-14 | 2015-12-14 | 249 | 229d | 0d |
| 251 | 1.2.2.10.5 | اجرای سنگ قرنیز لاشتر | 4d | 2015-12-15 | 2015-12-18 | 250 | 229d | 0d |
| 252 | 1.2.2.10.6 | اجرای آستر سیمان سیاه و سفید بام | 10d | 2015-12-19 | 2015-12-28 | 251 | 229d | 0d |
| 253 | 1.2.2.10.7 | شیب بندی و اجرای موزاییک بام | 15d | 2015-12-29 | 2016-01-12 | 252 | 229d | 0d |
| 254 | 1.2.2.10.8 | نصب قرنیز گالوانیزه بام | 3d | 2016-01-13 | 2016-01-15 | 253 | 229d |  |
| 255 | 1.2.2.11 | **نازک کاری** | 104d | 2016-02-23 | 2016-06-05 |  | 62d |  |
| 256 | 1.2.2.11.1 | **طبقه همکف** | 36d | 2016-02-23 | 2016-03-29 |  | 62d |  |
| 257 | 1.2.2.11.1.1 | اجرای کرم بندی و شیب بندی سرویسها و سالن غذاخوری | 4d | 2016-02-23 | 2016-02-26 | 232FS+60d | 62d | 0d |
| 258 | 1.2.2.11.1.2 | اجرای عایق رطوبتی سالن غذاخوری و سرویسها | 2d | 2016-02-27 | 2016-02-28 | 257 | 62d | 0d |
| 259 | 1.2.2.11.1.3 | اجرای سیمان محافظ روی عایق | 2d | 2016-02-29 | 2016-03-01 | 258 | 183d |  |
| 260 | 1.2.2.11.1.4 | چیدن دیوارهای داکت | 2d | 2016-02-23 | 2016-02-24 | 257SS | 189d |  |
| 261 | 1.2.2.11.1.5 | نصب چارچوبهای در و پنجره | 5d | 2016-02-23 | 2016-02-27 | 257SS | 186d |  |
| 262 | 1.2.2.11.1.6 | اجرای قرنیز و سنگ و پلاک فضای داخلی دیوارها | 10d | 2016-02-29 | 2016-03-09 | 258 | 62d | 0d |
| 263 | 1.2.2.11.1.7 | اجرای گچ سفید دیوارها | 15d | 2016-03-10 | 2016-03-24 | 262 | 160d |  |
| 264 | 1.2.2.11.1.8 | اجرای کاشی دیوار سرویسها | 20d | 2016-02-29 | 2016-03-19 | 258 | 160d | 0d |
| 265 | 1.2.2.11.1.9 | اجرای سرامیک کف | 5d | 2016-03-20 | 2016-03-24 | 264 | 160d |  |
| 266 | 1.2.2.11.1.10 | اجرای سنگ گرانیت و چینی و موزائیک کف | 10d | 2016-03-10 | 2016-03-19 | 262 | 155d | 0d |
| 267 | 1.2.2.11.1.11 | اجرای سقف کاذب ( کناف فضای داخلی ) | 10d | 2016-03-20 | 2016-03-29 | 266 | 155d |  |
| 268 | 1.2.2.11.1.12 | اجرای سقف کاذب ( سرویس بهداشتی ) | 4d | 2016-03-20 | 2016-03-23 | 264 | 161d |  |

| ID | WBS | Task | Duration | Start | Finish | Predecessors | Total slack | Free slack |
| --- | --- | --- | --- | --- | --- | --- | --- | --- |
| 269 | 1.2.2.11.2 | **طبقه اول** | 36d | 2016-02-27 | 2016-04-02 |  | 150d |  |
| 270 | 1.2.2.11.2.1 | کرم بندی و شیب بندی | 3d | 2016-02-27 | 2016-02-29 | 257 | 150d | 0d |
| 271 | 1.2.2.11.2.2 | نصب چارچوبهای در و پنجره | 3d | 2016-03-01 | 2016-03-03 | 270 | 151d | 0d |
| 272 | 1.2.2.11.2.3 | اجرای قرنیز و سنگ و پلاک فضای داخلی دیوارها | 10d | 2016-03-04 | 2016-03-13 | 271 | 151d | 0d |
| 273 | 1.2.2.11.2.4 | اجرای سنگ گرانیت کف | 5d | 2016-03-14 | 2016-03-18 | 272 | 151d | 0d |
| 274 | 1.2.2.11.2.5 | اجرای گچ سفید | 3d | 2016-03-14 | 2016-03-16 | 272 | 168d |  |
| 275 | 1.2.2.11.2.6 | اجرای سقف کاذب ( کناف فضای داخلی ) | 15d | 2016-03-19 | 2016-04-02 | 273 | 151d |  |
| 276 | 1.2.2.11.3 | **طبقه دوم** | 34d | 2016-03-01 | 2016-04-03 |  | 150d |  |
| 277 | 1.2.2.11.3.1 | کرم بندی و شیب بندی | 3d | 2016-03-01 | 2016-03-03 | 270 | 150d | 0d |
| 278 | 1.2.2.11.3.2 | نصب چارچوبهای در و پنجره | 3d | 2016-03-04 | 2016-03-06 | 277 | 150d | 0d |
| 279 | 1.2.2.11.3.3 | اجرای قرنیز و سنگ و پلاک فضای داخلی دیوارها | 10d | 2016-03-07 | 2016-03-16 | 278 | 150d | 0d |
| 280 | 1.2.2.11.3.4 | اجرای سنگ گرانیت کف | 5d | 2016-03-17 | 2016-03-21 | 279 | 150d | 0d |
| 281 | 1.2.2.11.3.5 | اجرای گچ سفید | 3d | 2016-03-22 | 2016-03-24 | 280 | 150d | 0d |
| 282 | 1.2.2.11.3.6 | اجرای سقف کاذب ( کناف فضای داخلی ) | 10d | 2016-03-25 | 2016-04-03 | 281 | 150d |  |
| 283 | 1.2.2.11.4 | **راه پله** | 68d | 2016-03-10 | 2016-05-16 |  | 62d |  |
| 284 | 1.2.2.11.4.1 | اجرای سنگ بدنه | 15d | 2016-03-10 | 2016-03-24 | 262 | 62d | 0d |
| 285 | 1.2.2.11.4.2 | اجرای سنگ پله ها | 20d | 2016-03-25 | 2016-04-13 | 284 | 62d | 0d |
| 286 | 1.2.2.11.4.3 | اجرای رابتس زیر پله | 5d | 2016-04-14 | 2016-04-18 | 285 | 62d | 0d |
| 287 | 1.2.2.11.4.4 | اجرای گچ و خاک پله ها | 12d | 2016-04-19 | 2016-04-30 | 286 | 62d | 0d |
| 288 | 1.2.2.11.4.5 | اجرای گچ سفید | 10d | 2016-05-01 | 2016-05-10 | 287 | 62d | 0d |
| 289 | 1.2.2.11.4.6 | اجرای لگه گیری گچ سفید زیر و بغل پله | 6d | 2016-05-11 | 2016-05-16 | 288 | 107d |  |
| 290 | 1.2.2.11.5 | **نصبیات و تکمیلی نازک کاری** | 36d | 2016-05-01 | 2016-06-05 |  | 87d |  |
| 291 | 1.2.2.11.5.1 | نصب در و پنجره های جوبی ، فولادی و UPVC | 8d | 2016-05-01 | 2016-05-08 | 287 | 87d | 0d |
| 292 | 1.2.2.11.5.2 | نصب شیشه ها | 8d | 2016-05-09 | 2016-05-16 | 291 | 87d | 0d |
| 293 | 1.2.2.11.5.3 | رنگ آمیزی سقف و دیوار | 20d | 2016-05-17 | 2016-06-05 | 292 | 87d |  |

| ID | WBS | Task | Type | Duration | Start | Finish | Predecessors | Baseline start | Baseline finish | Baseline duration | Total slack | Free slack | Constraint | Work | Text1 | Text4 | Text5 | Text22 | Text20 |
| --- | --- | --- | --- | --- | --- | --- | --- | --- | --- | --- | --- | --- | --- | --- | --- | --- | --- | --- | --- |
| 294 | 1.2.2.12 | **تاسیسات الکتریکی ( مرحله دوم )** |  | 41d | 2016-05-11 | 2016-06-20 |  | 2016-01-05 | 2016-08-04 | 0d | 62d |  |  | 72h | 7% | 170 | 170 | 73 |  |
| 295 | 1.2.2.12.1 | اجرای سیم کشی و کابل کشی ساختمان |  | 20d | 2016-05-11 | 2016-05-30 | 288 |  |  |  | 62d | 0d |  |  |  |  |  |  |  |
| 296 | 1.2.2.12.2 | کابل کشی مخابرات و تجهیزات مربوطه |  | 5d | 2016-05-31 | 2016-06-04 | 295 |  |  |  | 83d | 0d |  |  |  |  |  |  |  |
| 297 | 1.2.2.12.3 | اجرا و نصب تابلو برق و جریان ضعیف |  | 5d | 2016-06-05 | 2016-06-09 | 296 |  |  |  | 83d |  |  |  |  |  |  |  |  |
| 298 | 1.2.2.12.4 | کلید و پریز |  | 5d | 2016-05-31 | 2016-06-04 | 295 |  |  |  | 62d | 0d |  |  |  |  |  |  |  |
| 299 | 1.2.2.12.5 | چراغ های ایندور |  | 5d | 2016-06-05 | 2016-06-09 | 298 |  |  |  | 62d | 0d |  |  |  |  |  |  |  |
| 300 | 1.2.2.12.6 | سیستم اعلام حریق |  | 5d | 2016-06-10 | 2016-06-14 | 299 |  |  |  | 62d | 0d |  |  |  |  |  |  |  |
| 301 | 1.2.2.12.7 | سیستم آنتن مرکزی |  | 3d | 2016-06-15 | 2016-06-17 | 300 |  |  |  | 62d | 0d |  |  |  |  |  |  |  |
| 302 | 1.2.2.12.8 | ارت سازی |  | 3d | 2016-06-18 | 2016-06-20 | 301 | 2016-01-05 | 2016-01-14 | 0d | 62d | 0d |  | 72h | 60% | 9 روز | 9 روز | 10 |  |
| 303 | 1.2.2.13 | **تاسیسات مکانیکی ( مرحله دوم )** |  | 10d | 2016-06-21 | 2016-06-30 |  |  |  |  | 62d |  |  | 360h |  |  |  |  |  |
| 304 | 1.2.2.13.1 | شیر آلات بهداشتی |  | 5d | 2016-06-21 | 2016-06-25 | 302 | 2016-01-28 | 2016-02-11 | 0d | 62d | 0d |  | 104h | 100% | 13 روز | 13 روز | 10 |  |
| 305 | 1.2.2.13.2 | تجهیزات آتش نشانی |  | 4d | 2016-06-21 | 2016-06-24 | 304SS |  |  |  | 68d |  |  |  |  |  |  |  |  |
| 306 | 1.2.2.13.3 | نصب رادیاتور |  | 7d | 2016-06-21 | 2016-06-27 | 304SS | 2016-02-13 | 2016-02-23 | 0d | 62d | 0d |  | 80h | 0% | 10 روز | 10 روز |  |  |
| 307 | 1.2.2.13.4 | نصب دریچه های هوا و کولر |  | 3d | 2016-06-28 | 2016-06-30 | 306 | 2016-02-24 | 2016-04-03 | 0d | 62d |  |  | 176h | 0% | 22 روز | 22 روز | 12 |  |
| 308 | 1.2.3 | **ساختمان آموزشی** |  | 395d | 2015-07-01 | 2016-07-29 |  | 2015-05-20 | 2016-10-01 | 0d | 33d |  |  | 2708h | 37% | 349 روز | 417 روز | 296 | 296 |
| 309 | 1.2.3.1 | ابلاغ نقشه های فصل مشترک |  | 1d | 2015-07-01 | 2015-07-01 |  | 2015-09-19 | 2015-09-19 | 0d | 33d | 0d | start no earlier than 2015-07-01 | 7.5h | 100% | 1 روز | 1 روز |  |  |
| 310 | 1.2.3.2 | **اجرای اسکلت فلزی** |  | 122d | 2015-09-10 | 2016-01-09 |  | 2015-05-20 | 2016-04-07 | 0d | 33d |  |  | 1152h | 96% | 161 روز | 266 روز | 120 |  |
| 311 | 1.2.3.2.1 | ساخت و مونتاژ ستون ها |  | 65d | 2015-09-10 | 2015-11-13 | 309FS+70d | 2015-09-20 | 2015-10-03 | 0d | 33d | 0d |  | 96h | 100% | 12 روز | 12 روز | 10 |  |
| 312 | 1.2.3.2.2 | ساخت و مونتاژ تیرهای حمال و تودلی |  | 30d | 2015-11-14 | 2015-12-13 | 311 | 2015-09-20 | 2016-01-02 | 0d | 33d | 0d |  | 760h | 100% | 90 روز | 90 روز | 120 |  |
| 313 | 1.2.3.2.3 | ساخت و مونتاژ تیرهای پله |  | 10d | 2015-12-14 | 2015-12-23 | 312 | 2015-09-20 | 2015-10-11 | 0d | 33d | 0d |  | 152h | 100% | 19 روز | 19 روز | 15 |  |
| 314 | 1.2.3.2.4 | نصب ستون ها | milestone | 10d | 2015-12-24 | 2016-01-02 | 313 | 2015-10-04 | 2015-10-08 | 0d | 33d | 0d |  | 40h | 100% | 5 روز | 5 روز |  |  |
| 315 | 1.2.3.2.5 | نصب تیر های حمال و تودلی سقف همکف |  | 4d | 2016-01-03 | 2016-01-06 | 314 | 2015-10-10 | 2015-10-15 | 0d | 33d | 0d |  | 48h | 100% | 6 روز | 6 روز |  |  |
| 316 | 1.2.3.2.6 | نصب تیر های پله |  | 3d | 2016-01-07 | 2016-01-09 | 315 | 2015-10-17 | 2015-10-24 | 0d | 33d | 0d |  | 56h | 100% | 7 روز | 7 روز |  |  |
| 317 | 1.2.3.3 | **اجرای سقف** |  | 24d | 2016-01-18 | 2016-02-10 | 316 | 2015-10-25 | 2015-11-01 | 0d | 33d |  |  | 572.5h | 100% | 7 روز | 7 روز |  |  |
| 318 | 1.2.3.3.1 | **همکف** |  | 6d | 2016-01-18 | 2016-01-23 |  | 2015-11-02 | 2015-11-09 | 0d | 33d |  |  | 304h | 100% | 7 روز | 7 روز |  |  |
| 319 | 1.2.3.3.1.1 | برش کاری و نصب و پانچ ورقهای متال |  | 3d | 2016-01-18 | 2016-01-20 | 316FS+8d | 2015-11-10 | 2015-11-19 | 0d | 33d | 0d |  | 72h | 100% | 9 روز | 9 روز |  |  |
| 320 | 1.2.3.3.1.2 | جوشکاری گل میخ ها |  | 1d | 2016-01-21 | 2016-01-21 | 319 | 2015-11-21 | 2015-11-28 | 0d | 33d | 0d |  | 56h | 100% | 7 روز | 7 روز |  |  |
| 321 | 1.2.3.3.1.3 | آرماتور بندی |  | 1d | 2016-01-22 | 2016-01-22 | 320 | 2015-11-29 | 2015-12-09 | 0d | 33d | 0d |  | 64h | 100% | 10 روز | 10 روز |  |  |
| 322 | 1.2.3.3.1.4 | بتن ریزی |  | 1d | 2016-01-23 | 2016-01-23 | 321 | 2015-12-10 | 2015-12-26 | 0d | 33d | 0d |  | 112h | 100% | 14 روز | 14 روز |  |  |

| ID | WBS | Task | Duration | Start | Finish | Predecessors | Baseline start | Baseline finish | Baseline duration | Total slack | Free slack | Work | Text1 | Text4 | Text5 | Text22 |
| --- | --- | --- | --- | --- | --- | --- | --- | --- | --- | --- | --- | --- | --- | --- | --- | --- |
| 323 | 1.2.3.3.2 | **طبقه اول** | 6d | 2016-02-05 | 2016-02-10 | 322 | 2015-12-27 | 2016-02-16 | 0d | 88d |  | 268.5h | 100% | 45 روز | 45 روز | 35 |
| 324 | 1.2.3.3.2.1 | برش کاری و نصب و پانچ ورقهای متال | 3d | 2016-02-05 | 2016-02-07 | 319FS+15d | 2015-12-27 | 2016-01-06 | 0d | 88d | 0d | 80h | 100% | 10 روز | 10 روز |  |
| 325 | 1.2.3.3.2.2 | جوشکاری گل میخ ها | 1d | 2016-02-08 | 2016-02-08 | 324 | 2016-02-17 | 2016-02-29 | 0d | 88d | 0d | 88h | 100% | 11 روز | 11 روز |  |
| 326 | 1.2.3.3.2.3 | آرماتور بندی | 1d | 2016-02-09 | 2016-02-09 | 325 | 2016-03-01 | 2016-03-07 | 0d | 88d | 0d | 48h | 100% | 6 روز | 6 روز |  |
| 327 | 1.2.3.3.2.4 | بتن ریزی | 1d | 2016-02-10 | 2016-02-10 | 326 | 2016-03-08 | 2016-03-15 | 0d | 88d | 0d | 52.5h | 50% | 7 روز | 7 روز |  |
| 328 | 1.2.3.4 | **سفت کاری** | 50d | 2016-01-24 | 2016-03-13 |  | 2015-12-27 | 2016-06-22 | 0d | 33d |  | 544h | 48% | 142 روز | 142 روز |  |
| 329 | 1.2.3.4.1 | **همکف** | 50d | 2016-01-24 | 2016-03-13 |  | 2015-12-27 | 2016-01-25 | 0d | 33d |  | 360h | 60% | 26 روز | 26 روز |  |
| 330 | 1.2.3.4.1.1 | اجرای کرسی چینی و عایق | 5d | 2016-01-24 | 2016-01-28 | 322 |  |  |  | 33d | 0d |  |  |  |  |  |
| 331 | 1.2.3.4.1.2 | اجرای دیوارهای پیرامونی | 15d | 2016-01-29 | 2016-02-12 | 330 |  |  |  | 33d | 0d |  |  |  |  |  |
| 332 | 1.2.3.4.1.3 | ساخت و نصب نعل درگاه های پیرامونی | 5d | 2016-02-13 | 2016-02-17 | 331 |  |  |  | 171d | 0d |  |  |  |  |  |
| 333 | 1.2.3.4.1.4 | ساخت فریم و چارچوب در و پنجره ها | 5d | 2016-02-18 | 2016-02-22 | 332 | 2015-12-27 | 2016-01-05 | 0d | 171d | 0d | 72h | 100% | 9 روز | 9 روز |  |
| 334 | 1.2.3.4.1.5 | ساخت درهای فولادی | 10d | 2016-02-18 | 2016-02-27 | 333SS | 2015-12-27 | 2016-01-05 | 0d | 171d | 0d | 104h | 69% | 9 روز | 9 روز |  |
| 335 | 1.2.3.4.1.6 | اجرای بلوکاژ | 7d | 2016-02-28 | 2016-03-05 | 334 |  |  |  | 179d |  |  |  |  |  |  |
| 336 | 1.2.3.4.1.7 | اجرای دیوار جداکننده داخلی | 10d | 2016-02-18 | 2016-02-27 | 334SS |  |  |  | 171d | 0d |  |  |  |  |  |
| 337 | 1.2.3.4.1.8 | ساخت و نصب نعل درگاه های داخلی | 5d | 2016-02-18 | 2016-02-22 | 334SS |  |  |  | 191d |  |  |  |  |  |  |
| 338 | 1.2.3.4.1.9 | اجرای گچ و خاک دیوارها | 15d | 2016-02-28 | 2016-03-13 | 336 |  |  |  | 171d |  |  |  |  |  |  |
| 339 | 1.2.3.4.1.10 | رابیتس بندی مرحله اول | 10d | 2016-02-28 | 2016-03-08 | 336 | 2016-01-05 | 2016-01-25 | 0d | 176d |  | 184h | 0% | 18 روز | 18 روز |  |
| 340 | 1.2.3.4.2 | **طبقه اول** | 30d | 2016-02-13 | 2016-03-13 |  | 2016-01-06 | 2016-06-19 | 0d | 33d |  | 184h | 58% | 130 روز | 130 روز | 95 |
| 341 | 1.2.3.4.2.1 | اجرای دیوارهای پیرامونی | 10d | 2016-02-13 | 2016-02-22 | 331 | 2016-01-06 | 2016-01-18 | 0d | 33d | 0d | 128h | 100% | 11 روز | 11 روز | 12 |
| 342 | 1.2.3.4.2.2 | ساخت و نصب نعل درگاه های پیرامونی | 5d | 2016-02-13 | 2016-02-17 | 341SS | 2016-01-06 | 2016-01-18 | 0d | 33d | 0d | 56h | 14% | 11 روز | 11 روز |  |
| 343 | 1.2.3.4.2.3 | اجرای دیوار جداکننده داخلی | 10d | 2016-02-18 | 2016-02-27 | 342 |  |  |  | 33d | 0d |  |  |  |  |  |
| 344 | 1.2.3.4.2.4 | ساخت و نصب نعل درگاه های داخلی | 5d | 2016-02-13 | 2016-02-17 | 342SS |  |  |  | 196d |  |  |  |  |  |  |
| 345 | 1.2.3.4.2.5 | اجرای گچ و خاک دیوارها | 15d | 2016-02-28 | 2016-03-13 | 343 |  |  |  | 33d | 0d |  |  |  |  |  |
| 346 | 1.2.3.5 | **بام ( مرحله اول )** | 27d | 2016-02-11 | 2016-03-08 |  |  |  |  | 88d |  |  |  |  |  |  |
| 347 | 1.2.3.5.1 | اجرای دیوار جان پناه پشت بام و خرپشته | 10d | 2016-02-11 | 2016-02-20 | 327 |  |  |  | 88d | 0d |  |  |  |  |  |
| 348 | 1.2.3.5.2 | سیمانکاری دیوار جانپناه | 7d | 2016-02-21 | 2016-02-27 | 347 |  |  |  | 176d | 0d |  |  |  |  |  |
| 349 | 1.2.3.5.3 | رابیتس بندی | 10d | 2016-02-28 | 2016-03-08 | 348 |  |  |  | 176d |  |  |  |  |  |  |

| ID | WBS | Task | Duration | Start | Finish | Predecessors | Total slack | Free slack |
| --- | --- | --- | --- | --- | --- | --- | --- | --- |
| 350 | 1.2.3.6 | **اجرای نمای بیرونی** | 105d | 2016-02-21 | 2016-06-04 |  | 88d |  |
| 351 | 1.2.3.6.1 | اجرای سنگ پلاک نما به همراه فتیله | 20d | 2016-02-21 | 2016-03-11 | 347 | 88d | 0d |
| 352 | 1.2.3.6.2 | اجرای سنگ باکس تیر ها و ستون ها | 45d | 2016-03-12 | 2016-04-25 | 351 | 88d | 0d |
| 353 | 1.2.3.6.3 | اجرای سنگ پیش آمدگی ها | 40d | 2016-04-26 | 2016-06-04 | 352 | 88d |  |
| 354 | 1.2.3.6.4 | اجرای آستر سیمان سیاه دیوار جهت زیر سازی نمای شسته | 45d | 2016-02-21 | 2016-04-05 | 351SS | 108d | 0d |
| 355 | 1.2.3.6.5 | اجرای نمای شسته | 60d | 2016-03-02 | 2016-04-30 | 354SS+10d | 108d | 0d |
| 356 | 1.2.3.6.6 | اجرای درپوش بتنی جانپناه و کف پنجره ها | 15d | 2016-05-01 | 2016-05-15 | 355 | 108d |  |
| 357 | 1.2.3.7 | **تاسیسات مکانیکی ( مرحله اول )** | 77d | 2016-03-14 | 2016-05-29 |  | 33d |  |
| 358 | 1.2.3.7.1 | سوراخکاری و شیارزنی و کنده کاری داکت | 5d | 2016-03-14 | 2016-03-18 | 345 | 33d | 0d |
| 359 | 1.2.3.7.2 | کانال کنی تاسیسات | 5d | 2016-03-19 | 2016-03-23 | 358 | 33d | 0d |
| 360 | 1.2.3.7.3 | لوله کشی پلی اتیلن فاضلاب و آب باران | 10d | 2016-03-24 | 2016-04-02 | 359 | 33d | 0d |
| 361 | 1.2.3.7.4 | ساپورتهای لوله کشی تاسیسات | 7d | 2016-04-03 | 2016-04-09 | 360 | 134d | 0d |
| 362 | 1.2.3.7.5 | لوله کشی گالوانیزه آب سرد و گرم | 10d | 2016-04-10 | 2016-04-19 | 361 | 134d |  |
| 363 | 1.2.3.7.6 | لوله کشی لوله های گرمایشی و پنج لایه | 20d | 2016-04-03 | 2016-04-22 | 360 | 126d | 0d |
| 364 | 1.2.3.7.7 | اجرای ساپورتهای کانال کولر | 7d | 2016-04-03 | 2016-04-09 | 360 | 94d | 0d |
| 365 | 1.2.3.7.8 | اجرای کانال کولر | 30d | 2016-04-10 | 2016-05-09 | 364 | 94d | 0d |
| 366 | 1.2.3.7.9 | اجرای کانال اگزاست | 20d | 2016-05-10 | 2016-05-29 | 365 | 94d |  |
| 367 | 1.2.3.7.10 | عایق پشم شیشه و تست | 5d | 2016-04-23 | 2016-04-27 | 363 | 126d |  |
| 368 | 1.2.3.7.11 | اجرای لوله هایPVC | 2d | 2016-04-03 | 2016-04-04 | 360 | 33d | 0d |
| 369 | 1.2.3.8 | **تاسیسات الکتریکی ( مرحله اول )** | 48d | 2016-03-19 | 2016-05-05 |  | 118d |  |
| 370 | 1.2.3.8.1 | شیارزنی | 10d | 2016-03-19 | 2016-03-28 | 358 | 118d | 0d |
| 371 | 1.2.3.8.2 | اجرای لوله های PVC . PG13/5 | 15d | 2016-03-29 | 2016-04-12 | 370 | 118d | 0d |
| 372 | 1.2.3.8.3 | اجرای لوله های PVC . PG16-42 | 15d | 2016-04-13 | 2016-04-27 | 371 | 118d | 0d |
| 373 | 1.2.3.8.4 | تهیه ساخت و سفارش تابلو برق | 10d | 2016-03-29 | 2016-04-07 | 370 | 145d | 0d |
| 374 | 1.2.3.8.5 | غلاف گزاری | 3d | 2016-04-28 | 2016-04-30 | 372 | 118d | 0d |
| 375 | 1.2.3.8.6 | سینی کابل | 5d | 2016-05-01 | 2016-05-05 | 374 | 118d |  |
| 376 | 1.2.3.8.7 | نصب تابلو | 1d | 2016-04-08 | 2016-04-08 | 373 | 145d |  |

| ID | WBS | Task | Duration | Start | Finish | Predecessors | Total slack | Free slack |
| --- | --- | --- | --- | --- | --- | --- | --- | --- |
| 377 | 1.2.3.9 | **بام ( مرحله دوم )** | 42d | 2016-04-05 | 2016-05-16 |  | 33d |  |
| 378 | 1.2.3.9.1 | شیب بندی و اجرای بتن سبک بام | 5d | 2016-04-05 | 2016-04-09 | 368 | 33d | 0d |
| 379 | 1.2.3.9.2 | اجرای سیمانکاری لیسه ای زیر عایق | 2d | 2016-04-10 | 2016-04-11 | 378 | 107d | 0d |
| 380 | 1.2.3.9.3 | اجرای عایق پشت بام | 2d | 2016-04-12 | 2016-04-13 | 379 | 107d | 0d |
| 381 | 1.2.3.9.4 | نصب تور مرغی قبل از سنگ اندود | 1d | 2016-04-14 | 2016-04-14 | 380 | 107d | 0d |
| 382 | 1.2.3.9.5 | اجرای سنگ قرنیز لاشتر | 4d | 2016-04-15 | 2016-04-18 | 381 | 107d | 0d |
| 383 | 1.2.3.9.6 | اجرای آستر سیمان سیاه و سفید بام | 10d | 2016-04-19 | 2016-04-28 | 382 | 107d | 0d |
| 384 | 1.2.3.9.7 | شیب بندی و اجرای موزاییک بام | 15d | 2016-04-29 | 2016-05-13 | 383 | 107d | 0d |
| 385 | 1.2.3.9.8 | نصب قرنیز گالوانیزه بام | 3d | 2016-05-14 | 2016-05-16 | 384 | 107d |  |
| 386 | 1.2.3.10 | **نازک کاری** | 111d | 2016-04-10 | 2016-07-29 |  | 33d |  |
| 387 | 1.2.3.10.1 | **طبقه همکف** | 36d | 2016-04-10 | 2016-05-15 |  | 33d |  |
| 388 | 1.2.3.10.1.1 | اجرای کرم بندی و شیب بندی سرویسها و سالن غذاخوری | 4d | 2016-04-10 | 2016-04-13 | 378 | 33d | 0d |
| 389 | 1.2.3.10.1.2 | اجرای عایق رطوبتی سالن غذاخوری و سرویسها | 2d | 2016-04-14 | 2016-04-15 | 388 | 33d | 0d |
| 390 | 1.2.3.10.1.3 | اجرای سیمان محافظ روی عایق | 2d | 2016-04-16 | 2016-04-17 | 389 | 136d |  |
| 391 | 1.2.3.10.1.4 | چیدن دیوارهای داکت | 2d | 2016-04-10 | 2016-04-11 | 388SS | 142d |  |
| 392 | 1.2.3.10.1.5 | نصب چارچوبهای در و پنجره | 5d | 2016-04-10 | 2016-04-14 | 388SS | 139d |  |
| 393 | 1.2.3.10.1.6 | اجرای قرنیز و سنگ و پلاک فضای داخلی دیوارها | 10d | 2016-04-16 | 2016-04-25 | 389 | 33d | 0d |
| 394 | 1.2.3.10.1.7 | اجرای گچ سفید دیوارها | 15d | 2016-04-26 | 2016-05-10 | 393 | 113d |  |
| 395 | 1.2.3.10.1.8 | اجرای کاشی دیوار سرویسها | 20d | 2016-04-16 | 2016-05-05 | 389 | 113d | 0d |
| 396 | 1.2.3.10.1.9 | اجرای سرامیک کف | 5d | 2016-05-06 | 2016-05-10 | 395 | 113d |  |
| 397 | 1.2.3.10.1.10 | اجرای سنگ گرانیت و چینی و موزائیک کف | 10d | 2016-04-26 | 2016-05-05 | 393 | 108d | 0d |
| 398 | 1.2.3.10.1.11 | اجرای سقف کاذب ( کناف فضای داخلی ) | 10d | 2016-05-06 | 2016-05-15 | 397 | 108d |  |
| 399 | 1.2.3.10.1.12 | اجرای سقف کاذب ( سرویس بهداشتی ) | 4d | 2016-05-06 | 2016-05-09 | 395 | 114d |  |
| 400 | 1.2.3.10.2 | **طبقه اول** | 36d | 2016-04-14 | 2016-05-19 |  | 49d |  |
| 401 | 1.2.3.10.2.1 | کرم بندی و شیب بندی | 3d | 2016-04-14 | 2016-04-16 | 388 | 49d | 0d |
| 402 | 1.2.3.10.2.2 | نصب چارچوبهای در و پنجره | 3d | 2016-04-17 | 2016-04-19 | 401 | 49d | 0d |
| 403 | 1.2.3.10.2.3 | اجرای قرنیز و سنگ و پلاک فضای داخلی دیوارها | 10d | 2016-04-20 | 2016-04-29 | 402 | 49d | 0d |
| 404 | 1.2.3.10.2.4 | اجرای سنگ گرانیت کف | 5d | 2016-04-30 | 2016-05-04 | 403 | 49d | 0d |
| 405 | 1.2.3.10.2.5 | اجرای گچ سفید | 3d | 2016-04-30 | 2016-05-02 | 403 | 121d |  |
| 406 | 1.2.3.10.2.6 | اجرای سقف کاذب ( کناف فضای داخلی ) | 15d | 2016-05-05 | 2016-05-19 | 404 | 49d | 0d |

| ID | WBS | Task | Duration | Start | Finish | Predecessors | Baseline start | Baseline finish | Baseline duration | Total slack | Free slack | Work | Text1 | Text4 | Text5 | Text22 |
| --- | --- | --- | --- | --- | --- | --- | --- | --- | --- | --- | --- | --- | --- | --- | --- | --- |
| 407 | 1.2.3.10.3 | **راه پله** | 61d | 2016-04-26 | 2016-06-25 |  |  |  |  | 33d |  |  |  |  |  |  |
| 408 | 1.2.3.10.3.1 | اجرای سنگ بدنه | 10d | 2016-04-26 | 2016-05-05 | 393 |  |  |  | 33d | 0d |  |  |  |  |  |
| 409 | 1.2.3.10.3.2 | اجرای سنگ پله ها | 20d | 2016-05-06 | 2016-05-25 | 408 |  |  |  | 33d | 0d |  |  |  |  |  |
| 410 | 1.2.3.10.3.3 | اجرای رابتس زیر پله | 5d | 2016-05-26 | 2016-05-30 | 409 |  |  |  | 33d | 0d |  |  |  |  |  |
| 411 | 1.2.3.10.3.4 | اجرای گچ و خاک پله ها | 10d | 2016-05-31 | 2016-06-09 | 410 |  |  |  | 33d | 0d |  |  |  |  |  |
| 412 | 1.2.3.10.3.5 | اجرای گچ سفید | 10d | 2016-06-10 | 2016-06-19 | 411 |  |  |  | 67d | 0d |  |  |  |  |  |
| 413 | 1.2.3.10.3.6 | اجرای لگه گیری گچ سفید زیر و بغل پله | 6d | 2016-06-20 | 2016-06-25 | 412 |  |  |  | 67d |  |  |  |  |  |  |
| 414 | 1.2.3.10.4 | **نصبیات و تکمیلی نازک کاری** | 50d | 2016-06-10 | 2016-07-29 |  |  |  |  | 33d |  |  |  |  |  |  |
| 415 | 1.2.3.10.4.1 | نصب در و پنجره های جوبی ، فولادی و UPVC | 10d | 2016-06-10 | 2016-06-19 | 411 |  |  |  | 33d | 0d |  |  |  |  |  |
| 416 | 1.2.3.10.4.2 | نصب شیشه ها | 8d | 2016-06-20 | 2016-06-27 | 415 |  |  |  | 33d | 0d |  |  |  |  |  |
| 417 | 1.2.3.10.4.3 | رنگ آمیزی سقف و دیوار | 32d | 2016-06-28 | 2016-07-29 | 416 |  |  |  | 33d |  |  |  |  |  |  |
| 418 | 1.2.3.11 | **تاسیسات الکتریکی ( مرحله دوم )** | 41d | 2016-05-20 | 2016-06-29 |  | 2016-01-05 | 2016-08-04 | 0d | 49d |  | 72h | 7% | 170 | 170 | 73 |
| 419 | 1.2.3.11.1 | اجرای سیم کشی و کابل کشی ساختمان | 20d | 2016-05-20 | 2016-06-08 | 406 |  |  |  | 49d | 0d |  |  |  |  |  |
| 420 | 1.2.3.11.2 | کابل کشی مخابرات و تجهیزات مربوطه | 5d | 2016-06-09 | 2016-06-13 | 419 |  |  |  | 74d | 0d |  |  |  |  |  |
| 421 | 1.2.3.11.3 | اجرا و نصب تابلو برق و جریان ضعیف | 5d | 2016-06-14 | 2016-06-18 | 420 |  |  |  | 74d |  |  |  |  |  |  |
| 422 | 1.2.3.11.4 | کلید و پریز | 5d | 2016-06-09 | 2016-06-13 | 419 |  |  |  | 49d | 0d |  |  |  |  |  |
| 423 | 1.2.3.11.5 | چراغ های ایندور | 5d | 2016-06-14 | 2016-06-18 | 422 |  |  |  | 49d | 0d |  |  |  |  |  |
| 424 | 1.2.3.11.6 | سیستم اعلام حریق | 5d | 2016-06-19 | 2016-06-23 | 423 |  |  |  | 49d | 0d |  |  |  |  |  |
| 425 | 1.2.3.11.7 | سیستم آنتن مرکزی | 3d | 2016-06-24 | 2016-06-26 | 424 |  |  |  | 49d | 0d |  |  |  |  |  |
| 426 | 1.2.3.11.8 | ارت سازی | 3d | 2016-06-27 | 2016-06-29 | 425 | 2016-01-05 | 2016-01-14 | 0d | 49d | 0d | 72h | 60% | 9 روز | 9 روز | 10 |
| 427 | 1.2.3.12 | **تاسیسات مکانیکی ( مرحله دوم )** | 14d | 2016-06-30 | 2016-07-13 |  |  |  |  | 49d |  | 360h |  |  |  |  |
| 428 | 1.2.3.12.1 | شیر آلات بهداشتی | 5d | 2016-06-30 | 2016-07-04 | 426 | 2016-01-28 | 2016-02-11 | 0d | 49d | 0d | 104h | 100% | 13 روز | 13 روز | 10 |
| 429 | 1.2.3.12.2 | تجهیزات آتش نشانی | 4d | 2016-06-30 | 2016-07-03 | 428SS |  |  |  | 49d | 0d |  |  |  |  |  |
| 430 | 1.2.3.12.3 | نصب رادیاتور | 7d | 2016-07-04 | 2016-07-10 | 429 | 2016-02-13 | 2016-02-23 | 0d | 49d | 0d | 80h | 0% | 10 روز | 10 روز |  |
| 431 | 1.2.3.12.4 | نصب دریچه های هوا و کولر | 3d | 2016-07-11 | 2016-07-13 | 430 | 2016-02-24 | 2016-04-03 | 0d | 49d |  | 176h | 0% | 22 روز | 22 روز | 12 |

| ID | WBS | Task | Duration | Start | Finish | Predecessors | Baseline start | Baseline finish | Baseline duration | Total slack | Free slack | Constraint | Work | Text1 | Text4 | Text5 | Text20 | Text22 |
| --- | --- | --- | --- | --- | --- | --- | --- | --- | --- | --- | --- | --- | --- | --- | --- | --- | --- | --- |
| 432 | 1.2.4 | **ساختمان ادوات** | 313d | 2015-07-01 | 2016-05-08 |  | 2015-05-20 | 2016-10-01 | 0d | 115d |  |  | 983.5h | 37% | 349 روز | 417 روز | 296 | 296 |
| 433 | 1.2.4.1 | ابلاغ نقشه های فصل مشترک | 1d | 2015-07-01 | 2015-07-01 |  | 2015-09-19 | 2015-09-19 | 0d | 130d | 0d | start no earlier than 2015-07-01 | 7.5h | 100% | 1 روز | 1 روز |  |  |
| 434 | 1.2.4.2 | **سفت کاری** | 40d | 2015-07-02 | 2015-08-10 |  | 2015-12-27 | 2016-06-22 | 0d | 337d |  |  | 544h | 48% | 142 روز | 142 روز |  |  |
| 435 | 1.2.4.2.1 | **همکف** | 33d | 2015-07-02 | 2015-08-03 |  | 2015-12-27 | 2016-01-25 | 0d | 337d |  |  | 360h | 60% | 26 روز | 26 روز |  |  |
| 436 | 1.2.4.2.1.1 | اجرای دیوارهای پیرامونی | 15d | 2015-07-02 | 2015-07-16 | 433 |  |  |  | 337d | 0d |  |  |  |  |  |  |  |
| 437 | 1.2.4.2.1.2 | ساخت و نصب نعل درگاه های پیرامونی | 3d | 2015-07-17 | 2015-07-19 | 436 |  |  |  | 394d | 0d |  |  |  |  |  |  |  |
| 438 | 1.2.4.2.1.3 | ساخت فریم و چارچوب در و پنجره ها | 5d | 2015-07-20 | 2015-07-24 | 437 | 2015-12-27 | 2016-01-05 | 0d | 394d | 0d |  | 72h | 100% | 9 روز | 9 روز |  |  |
| 439 | 1.2.4.2.1.4 | ساخت درهای فولادی | 10d | 2015-07-20 | 2015-07-29 | 438SS | 2015-12-27 | 2016-01-05 | 0d | 394d | 0d |  | 104h | 69% | 9 روز | 9 روز |  |  |
| 440 | 1.2.4.2.1.5 | اجرای بلوکاژ | 5d | 2015-07-30 | 2015-08-03 | 439 |  |  |  | 394d |  |  |  |  |  |  |  |  |
| 441 | 1.2.4.2.1.6 | اجرای دیوار جداکننده داخلی | 5d | 2015-07-20 | 2015-07-24 | 439SS |  |  |  | 394d | 0d |  |  |  |  |  |  |  |
| 442 | 1.2.4.2.1.7 | ساخت و نصب نعل درگاه های داخلی | 5d | 2015-07-20 | 2015-07-24 | 439SS |  |  |  | 404d |  |  |  |  |  |  |  |  |
| 443 | 1.2.4.2.1.8 | اجرای گچ و خاک دیوارها | 10d | 2015-07-25 | 2015-08-03 | 441 |  |  |  | 394d |  |  |  |  |  |  |  |  |
| 444 | 1.2.4.2.1.9 | رابیتس بندی مرحله اول | 10d | 2015-07-25 | 2015-08-03 | 441 | 2016-01-05 | 2016-01-25 | 0d | 394d |  |  | 184h | 0% | 18 روز | 18 روز |  |  |
| 445 | 1.2.4.2.2 | **طبقه اول** | 25d | 2015-07-17 | 2015-08-10 |  | 2016-01-06 | 2016-06-19 | 0d | 337d |  |  | 184h | 58% | 130 روز | 130 روز |  | 95 |
| 446 | 1.2.4.2.2.1 | اجرای دیوارهای پیرامونی | 5d | 2015-07-17 | 2015-07-21 | 436 | 2016-01-06 | 2016-01-18 | 0d | 337d | 0d |  | 128h | 100% | 11 روز | 11 روز |  | 12 |
| 447 | 1.2.4.2.2.2 | ساخت و نصب نعل درگاه های پیرامونی | 5d | 2015-07-17 | 2015-07-21 | 446SS | 2016-01-06 | 2016-01-18 | 0d | 337d | 0d |  | 56h | 14% | 11 روز | 11 روز |  |  |
| 448 | 1.2.4.2.2.3 | اجرای دیوار جداکننده داخلی | 5d | 2015-07-22 | 2015-07-26 | 447 |  |  |  | 337d | 0d |  |  |  |  |  |  |  |
| 449 | 1.2.4.2.2.4 | ساخت و نصب نعل درگاه های داخلی | 5d | 2015-07-17 | 2015-07-21 | 447SS |  |  |  | 407d |  |  |  |  |  |  |  |  |
| 450 | 1.2.4.2.2.5 | اجرای گچ و خاک دیوارها | 15d | 2015-07-27 | 2015-08-10 | 448 |  |  |  | 337d | 0d |  |  |  |  |  |  |  |
| 451 | 1.2.4.3 | **اجرای نمای بیرونی** | 65d | 2016-01-25 | 2016-03-29 |  |  |  |  | 115d |  |  |  |  |  |  |  |  |
| 452 | 1.2.4.3.1 | اجرای سنگ پلاک نما به همراه فتیله | 10d | 2016-01-25 | 2016-02-03 |  |  |  |  | 115d | 0d | start no earlier than 2016-01-25 |  |  |  |  |  |  |
| 453 | 1.2.4.3.2 | اجرای سنگ باکس تیر ها و ستون ها | 30d | 2016-02-04 | 2016-03-04 | 452 |  |  |  | 155d | 0d |  |  |  |  |  |  |  |
| 454 | 1.2.4.3.3 | اجرای سنگ پیش آمدگی ها | 25d | 2016-03-05 | 2016-03-29 | 453 |  |  |  | 155d |  |  |  |  |  |  |  |  |
| 455 | 1.2.4.3.4 | اجرای آستر سیمان سیاه دیوار جهت زیر سازی نمای شسته | 40d | 2016-01-25 | 2016-03-04 | 452SS |  |  |  | 155d | 0d |  |  |  |  |  |  |  |
| 456 | 1.2.4.3.5 | اجرای نمای شسته | 45d | 2016-02-04 | 2016-03-19 | 455SS+10d |  |  |  | 155d | 0d |  |  |  |  |  |  |  |
| 457 | 1.2.4.3.6 | اجرای درپوش بتنی جانپناه و کف پنجره ها | 10d | 2016-03-20 | 2016-03-29 | 456 |  |  |  | 155d |  |  |  |  |  |  |  |  |

| ID | WBS | Task | Duration | Start | Finish | Predecessors | Total slack | Free slack |
| --- | --- | --- | --- | --- | --- | --- | --- | --- |
| 458 | 1.2.4.4 | **تاسیسات مکانیکی ( مرحله اول )** | 50d | 2015-08-11 | 2015-09-29 |  | 337d |  |
| 459 | 1.2.4.4.1 | سوراخکاری و شیارزنی و کنده کاری داکت | 4d | 2015-08-11 | 2015-08-14 | 450 | 337d | 0d |
| 460 | 1.2.4.4.2 | کانال کنی تاسیسات | 5d | 2015-08-11 | 2015-08-15 | 459SS | 337d | 0d |
| 461 | 1.2.4.4.3 | لوله کشی پلی اتیلن فاضلاب و آب باران | 10d | 2015-08-16 | 2015-08-25 | 460 | 337d | 0d |
| 462 | 1.2.4.4.4 | ساپورتهای لوله کشی تاسیسات | 5d | 2015-08-16 | 2015-08-20 | 461SS | 367d | 0d |
| 463 | 1.2.4.4.5 | لوله کشی گالوانیزه آب سرد و گرم | 10d | 2015-08-21 | 2015-08-30 | 462 | 367d |  |
| 464 | 1.2.4.4.6 | لوله کشی لوله های گرمایشی و پنج لایه | 20d | 2015-08-26 | 2015-09-14 | 461 | 347d | 0d |
| 465 | 1.2.4.4.7 | اجرای ساپورتهای کانال کولر | 5d | 2015-08-26 | 2015-08-30 | 461 | 337d | 0d |
| 466 | 1.2.4.4.8 | اجرای کانال کولر | 30d | 2015-08-31 | 2015-09-29 | 465 | 337d | 0d |
| 467 | 1.2.4.4.9 | اجرای کانال اگزاست | 20d | 2015-08-31 | 2015-09-19 | 466SS | 347d |  |
| 468 | 1.2.4.4.10 | عایق پشم شیشه و تست | 5d | 2015-09-15 | 2015-09-19 | 464 | 347d |  |
| 469 | 1.2.4.4.11 | اجرای لوله هایPVC | 2d | 2015-08-16 | 2015-08-17 | 461SS | 380d |  |
| 470 | 1.2.4.5 | **تاسیسات الکتریکی ( مرحله اول )** | 25d | 2015-08-11 | 2015-09-04 |  | 362d |  |
| 471 | 1.2.4.5.1 | شیارزنی | 10d | 2015-08-11 | 2015-08-20 | 459SS | 362d | 0d |
| 472 | 1.2.4.5.2 | اجرای لوله های PVC . PG13/5 | 15d | 2015-08-21 | 2015-09-04 | 471 | 362d | 0d |
| 473 | 1.2.4.5.3 | اجرای لوله های PVC . PG16-42 | 15d | 2015-08-21 | 2015-09-04 | 472SS | 362d | 0d |
| 474 | 1.2.4.5.4 | تهیه ساخت و سفارش تابلو برق | 10d | 2015-08-11 | 2015-08-20 | 471SS | 376d | 0d |
| 475 | 1.2.4.5.5 | غلاف گزاری | 3d | 2015-08-21 | 2015-08-23 | 473SS | 369d | 0d |
| 476 | 1.2.4.5.6 | سینی کابل | 5d | 2015-08-24 | 2015-08-28 | 475 | 369d |  |
| 477 | 1.2.4.5.7 | نصب تابلو | 1d | 2015-08-21 | 2015-08-21 | 474 | 376d |  |
| 478 | 1.2.4.6 | **بام ( مرحله دوم )** | 42d | 2016-02-04 | 2016-03-16 |  | 115d |  |
| 479 | 1.2.4.6.1 | شیب بندی و اجرای بتن سبک بام | 5d | 2016-02-04 | 2016-02-08 | 452 | 115d | 0d |
| 480 | 1.2.4.6.2 | اجرای سیمانکاری لیسه ای زیر عایق | 2d | 2016-02-09 | 2016-02-10 | 479 | 168d | 0d |
| 481 | 1.2.4.6.3 | اجرای عایق پشت بام | 2d | 2016-02-11 | 2016-02-12 | 480 | 168d | 0d |
| 482 | 1.2.4.6.4 | نصب تور مرغی قبل از سنگ اندود | 1d | 2016-02-13 | 2016-02-13 | 481 | 168d | 0d |
| 483 | 1.2.4.6.5 | اجرای سنگ قرنیز لاشتر | 4d | 2016-02-14 | 2016-02-17 | 482 | 168d | 0d |
| 484 | 1.2.4.6.6 | اجرای آستر سیمان سیاه و سفید بام | 10d | 2016-02-18 | 2016-02-27 | 483 | 168d | 0d |
| 485 | 1.2.4.6.7 | شیب بندی و اجرای موزاییک بام | 15d | 2016-02-28 | 2016-03-13 | 484 | 168d | 0d |
| 486 | 1.2.4.6.8 | نصب قرنیز گالوانیزه بام | 3d | 2016-03-14 | 2016-03-16 | 485 | 168d |  |

| ID | WBS | Task | Duration | Start | Finish | Predecessors | Total slack | Free slack |
| --- | --- | --- | --- | --- | --- | --- | --- | --- |
| 487 | 1.2.4.7 | **نازک کاری** | 82d | 2016-02-09 | 2016-04-30 |  | 115d |  |
| 488 | 1.2.4.7.1 | **طبقه همکف** | 46d | 2016-02-09 | 2016-03-25 |  | 115d |  |
| 489 | 1.2.4.7.1.1 | اجرای کرم بندی و شیب بندی سرویسها و سالن غذاخوری | 4d | 2016-02-09 | 2016-02-12 | 479 | 115d | 0d |
| 490 | 1.2.4.7.1.2 | اجرای عایق رطوبتی سالن غذاخوری و سرویسها | 2d | 2016-02-13 | 2016-02-14 | 489 | 115d | 0d |
| 491 | 1.2.4.7.1.3 | اجرای سیمان محافظ روی عایق | 2d | 2016-02-15 | 2016-02-16 | 490 | 197d |  |
| 492 | 1.2.4.7.1.4 | چیدن دیوارهای داکت | 2d | 2016-02-09 | 2016-02-10 | 489SS | 203d |  |
| 493 | 1.2.4.7.1.5 | نصب چارچوبهای در و پنجره | 5d | 2016-02-09 | 2016-02-13 | 489SS | 200d |  |
| 494 | 1.2.4.7.1.6 | اجرای قرنیز و سنگ و پلاک فضای داخلی دیوارها | 10d | 2016-02-15 | 2016-02-24 | 490 | 115d | 0d |
| 495 | 1.2.4.7.1.7 | اجرای گچ سفید دیوارها | 15d | 2016-02-25 | 2016-03-10 | 494 | 174d |  |
| 496 | 1.2.4.7.1.8 | اجرای کاشی دیوار سرویسها | 20d | 2016-02-15 | 2016-03-05 | 490 | 174d | 0d |
| 497 | 1.2.4.7.1.9 | اجرای سرامیک کف | 5d | 2016-03-06 | 2016-03-10 | 496 | 174d |  |
| 498 | 1.2.4.7.1.10 | اجرای سنگ گرانیت و چینی و موزائیک کف | 15d | 2016-02-25 | 2016-03-10 | 494 | 115d | 0d |
| 499 | 1.2.4.7.1.11 | اجرای سقف کاذب ( کناف فضای داخلی ) | 15d | 2016-03-11 | 2016-03-25 | 498 | 159d |  |
| 500 | 1.2.4.7.1.12 | اجرای سقف کاذب ( سرویس بهداشتی ) | 4d | 2016-03-06 | 2016-03-09 | 496 | 175d |  |
| 501 | 1.2.4.7.2 | **طبقه اول** | 36d | 2016-02-13 | 2016-03-19 |  | 165d |  |
| 502 | 1.2.4.7.2.1 | کرم بندی و شیب بندی | 3d | 2016-02-13 | 2016-02-15 | 489 | 165d | 0d |
| 503 | 1.2.4.7.2.2 | نصب چارچوبهای در و پنجره | 3d | 2016-02-16 | 2016-02-18 | 502 | 165d | 0d |
| 504 | 1.2.4.7.2.3 | اجرای قرنیز و سنگ و پلاک فضای داخلی دیوارها | 10d | 2016-02-19 | 2016-02-28 | 503 | 165d | 0d |
| 505 | 1.2.4.7.2.4 | اجرای سنگ گرانیت کف | 5d | 2016-02-29 | 2016-03-04 | 504 | 165d | 0d |
| 506 | 1.2.4.7.2.5 | اجرای گچ سفید | 3d | 2016-02-29 | 2016-03-02 | 504 | 182d |  |
| 507 | 1.2.4.7.2.6 | اجرای سقف کاذب ( کناف فضای داخلی ) | 15d | 2016-03-05 | 2016-03-19 | 505 | 165d |  |
| 508 | 1.2.4.7.3 | **راه پله** | 66d | 2016-02-25 | 2016-04-30 |  | 123d |  |
| 509 | 1.2.4.7.3.1 | اجرای سنگ بدنه | 15d | 2016-02-25 | 2016-03-10 | 494 | 123d | 0d |
| 510 | 1.2.4.7.3.2 | اجرای سنگ پله ها | 20d | 2016-03-11 | 2016-03-30 | 509 | 123d | 0d |
| 511 | 1.2.4.7.3.3 | اجرای رابتس زیر پله | 5d | 2016-03-31 | 2016-04-04 | 510 | 123d | 0d |
| 512 | 1.2.4.7.3.4 | اجرای گچ و خاک پله ها | 10d | 2016-04-05 | 2016-04-14 | 511 | 123d | 0d |
| 513 | 1.2.4.7.3.5 | اجرای گچ سفید | 10d | 2016-04-15 | 2016-04-24 | 512 | 123d | 0d |
| 514 | 1.2.4.7.3.6 | اجرای لگه گیری گچ سفید زیر و بغل پله | 6d | 2016-04-25 | 2016-04-30 | 513 | 123d |  |

| ID | WBS | Task | Type | Duration | Start | Finish | Predecessors | Baseline start | Baseline finish | Baseline duration | Total slack | Free slack | Work | Text1 | Text4 | Text5 | Text22 | Text20 |
| --- | --- | --- | --- | --- | --- | --- | --- | --- | --- | --- | --- | --- | --- | --- | --- | --- | --- | --- |
| 515 | 1.2.4.7.4 | **نصبیات و تکمیلی نازک کاری** |  | 16d | 2016-04-15 | 2016-04-30 |  |  |  |  | 123d |  |  |  |  |  |  |  |
| 516 | 1.2.4.7.4.1 | نصب در و پنجره های جوبی ، فولادی و UPVC |  | 3d | 2016-04-15 | 2016-04-17 | 512 |  |  |  | 123d | 0d |  |  |  |  |  |  |
| 517 | 1.2.4.7.4.2 | نصب شیشه ها |  | 3d | 2016-04-18 | 2016-04-20 | 516 |  |  |  | 123d | 0d |  |  |  |  |  |  |
| 518 | 1.2.4.7.4.3 | رنگ آمیزی سقف و دیوار |  | 10d | 2016-04-21 | 2016-04-30 | 517 |  |  |  | 123d |  |  |  |  |  |  |  |
| 519 | 1.2.4.8 | **تاسیسات الکتریکی ( مرحله دوم )** |  | 46d | 2016-03-14 | 2016-04-28 |  | 2016-01-05 | 2016-08-04 | 0d | 115d |  | 72h | 7% | 170 | 170 | 73 |  |
| 520 | 1.2.4.8.1 | اجرای سیم کشی و کابل کشی ساختمان |  | 20d | 2016-03-14 | 2016-04-02 | 498FS+3d |  |  |  | 115d | 0d |  |  |  |  |  |  |
| 521 | 1.2.4.8.2 | کابل کشی مخابرات و تجهیزات مربوطه |  | 10d | 2016-04-03 | 2016-04-12 | 520 |  |  |  | 136d | 0d |  |  |  |  |  |  |
| 522 | 1.2.4.8.3 | اجرا و نصب تابلو برق و جریان ضعیف |  | 5d | 2016-04-13 | 2016-04-17 | 521 |  |  |  | 136d |  |  |  |  |  |  |  |
| 523 | 1.2.4.8.4 | کلید و پریز |  | 10d | 2016-04-03 | 2016-04-12 | 520 |  |  |  | 115d | 0d |  |  |  |  |  |  |
| 524 | 1.2.4.8.5 | چراغ های ایندور |  | 5d | 2016-04-13 | 2016-04-17 | 523 |  |  |  | 115d | 0d |  |  |  |  |  |  |
| 525 | 1.2.4.8.6 | سیستم اعلام حریق |  | 5d | 2016-04-18 | 2016-04-22 | 524 |  |  |  | 115d | 0d |  |  |  |  |  |  |
| 526 | 1.2.4.8.7 | سیستم آنتن مرکزی |  | 3d | 2016-04-23 | 2016-04-25 | 525 |  |  |  | 115d | 0d |  |  |  |  |  |  |
| 527 | 1.2.4.8.8 | ارت سازی |  | 3d | 2016-04-26 | 2016-04-28 | 526 | 2016-01-05 | 2016-01-14 | 0d | 115d | 0d | 72h | 60% | 9 روز | 9 روز | 10 |  |
| 528 | 1.2.4.9 | **تاسیسات مکانیکی ( مرحله دوم )** |  | 10d | 2016-04-29 | 2016-05-08 |  |  |  |  | 115d |  | 360h |  |  |  |  |  |
| 529 | 1.2.4.9.1 | شیر آلات بهداشتی |  | 5d | 2016-04-29 | 2016-05-03 | 527 | 2016-01-28 | 2016-02-11 | 0d | 115d | 0d | 104h | 100% | 13 روز | 13 روز | 10 |  |
| 530 | 1.2.4.9.2 | تجهیزات آتش نشانی |  | 4d | 2016-04-29 | 2016-05-02 | 529SS |  |  |  | 121d |  |  |  |  |  |  |  |
| 531 | 1.2.4.9.3 | نصب رادیاتور |  | 7d | 2016-04-29 | 2016-05-05 | 529SS | 2016-02-13 | 2016-02-23 | 0d | 115d | 0d | 80h | 0% | 10 روز | 10 روز |  |  |
| 532 | 1.2.4.9.4 | نصب دریچه های هوا و کولر |  | 3d | 2016-05-06 | 2016-05-08 | 531 | 2016-02-24 | 2016-04-03 | 0d | 115d |  | 176h | 0% | 22 روز | 22 روز | 12 |  |
| 533 | 1.2.5 | **ساختمان ستاد گردان** |  | 375d | 2015-07-01 | 2016-07-09 |  | 2015-05-20 | 2016-10-01 | 0d | 53d |  | 1956.5h | 37% | 349 روز | 417 روز | 296 | 296 |
| 534 | 1.2.5.1 | ابلاغ نقشه های فصل مشترک |  | 1d | 2015-07-01 | 2015-07-01 | 433SS |  |  |  | 130d | 0d |  |  |  |  |  |  |
| 535 | 1.2.5.2 | **اجرای سازه** |  | 180d | 2015-07-02 | 2015-12-28 |  | 2015-05-20 | 2016-04-07 | 0d | 130d |  | 952h | 96% | 161 روز | 266 روز | 120 |  |
| 536 | 1.2.5.2.1 | **اجرای دیوار بتنی حائل** |  | 180d | 2015-07-02 | 2015-12-28 |  | 2015-09-20 | 2015-10-03 | 0d | 130d |  | 952h | 100% | 12 روز | 12 روز | 10 |  |
| 537 | 1.2.5.2.1.1 | آرماتور بندی |  | 90d | 2015-07-02 | 2015-09-29 | 534 | 2015-09-20 | 2016-01-02 | 0d | 130d | 0d | 760h | 100% | 90 روز | 90 روز | 120 |  |
| 538 | 1.2.5.2.1.2 | قالب بندی |  | 90d | 2015-09-20 | 2015-12-18 | 537FS-10d | 2015-09-20 | 2015-10-11 | 0d | 130d | 0d | 152h | 100% | 19 روز | 19 روز | 15 |  |
| 539 | 1.2.5.2.1.3 | بتن ریزی | milestone | 10d | 2015-12-19 | 2015-12-28 | 538 | 2015-10-04 | 2015-10-08 | 0d | 130d | 0d | 40h | 100% | 5 روز | 5 روز |  |  |

| ID | WBS | Task | Duration | Start | Finish | Predecessors | Baseline start | Baseline finish | Baseline duration | Total slack | Free slack | Work | Text1 | Text4 | Text5 | Text22 |
| --- | --- | --- | --- | --- | --- | --- | --- | --- | --- | --- | --- | --- | --- | --- | --- | --- |
| 540 | 1.2.5.3 | **اجرای سقف** | 92d | 2015-12-29 | 2016-03-29 |  | 2015-10-25 | 2015-11-01 | 0d | 130d |  | 572.5h | 100% | 7 روز | 7 روز |  |
| 541 | 1.2.5.3.1 | **زیر زمین** | 14d | 2015-12-29 | 2016-01-11 |  |  |  |  | 130d |  |  |  |  |  |  |
| 542 | 1.2.5.3.1.1 | برش کاری و نصب و پانچ ورقهای متال | 7d | 2015-12-29 | 2016-01-04 | 539 |  |  |  | 130d | 0d |  |  |  |  |  |
| 543 | 1.2.5.3.1.2 | جوشکاری گل میخ ها | 3d | 2016-01-05 | 2016-01-07 | 542 |  |  |  | 130d | 0d |  |  |  |  |  |
| 544 | 1.2.5.3.1.3 | آرماتور بندی | 3d | 2016-01-08 | 2016-01-10 | 543 |  |  |  | 130d | 0d |  |  |  |  |  |
| 545 | 1.2.5.3.1.4 | بتن ریزی | 1d | 2016-01-11 | 2016-01-11 | 544 |  |  |  | 130d | 0d |  |  |  |  |  |
| 546 | 1.2.5.3.2 | **همکف** | 14d | 2016-02-01 | 2016-02-14 |  | 2015-11-02 | 2015-11-09 | 0d | 130d |  | 304h | 100% | 7 روز | 7 روز |  |
| 547 | 1.2.5.3.2.1 | برش کاری و نصب و پانچ ورقهای متال | 7d | 2016-02-01 | 2016-02-07 | 545FS+20d | 2015-11-10 | 2015-11-19 | 0d | 130d | 0d | 72h | 100% | 9 روز | 9 روز |  |
| 548 | 1.2.5.3.2.2 | جوشکاری گل میخ ها | 3d | 2016-02-08 | 2016-02-10 | 547 | 2015-11-21 | 2015-11-28 | 0d | 130d | 0d | 56h | 100% | 7 روز | 7 روز |  |
| 549 | 1.2.5.3.2.3 | آرماتور بندی | 3d | 2016-02-11 | 2016-02-13 | 548 | 2015-11-29 | 2015-12-09 | 0d | 130d | 0d | 64h | 100% | 10 روز | 10 روز |  |
| 550 | 1.2.5.3.2.4 | بتن ریزی | 1d | 2016-02-14 | 2016-02-14 | 549 | 2015-12-10 | 2015-12-26 | 0d | 130d | 0d | 112h | 100% | 14 روز | 14 روز |  |
| 551 | 1.2.5.3.3 | **طبقه اول** | 14d | 2016-03-16 | 2016-03-29 | 550 | 2015-12-27 | 2016-02-16 | 0d | 130d |  | 268.5h | 100% | 45 روز | 45 روز | 35 |
| 552 | 1.2.5.3.3.1 | برش کاری و نصب و پانچ ورقهای متال | 7d | 2016-03-16 | 2016-03-22 | 550FS+30d | 2015-12-27 | 2016-01-06 | 0d | 130d | 0d | 80h | 100% | 10 روز | 10 روز |  |
| 553 | 1.2.5.3.3.2 | جوشکاری گل میخ ها | 3d | 2016-03-23 | 2016-03-25 | 552 | 2016-02-17 | 2016-02-29 | 0d | 130d | 0d | 88h | 100% | 11 روز | 11 روز |  |
| 554 | 1.2.5.3.3.3 | آرماتور بندی | 3d | 2016-03-26 | 2016-03-28 | 553 | 2016-03-01 | 2016-03-07 | 0d | 130d | 0d | 48h | 100% | 6 روز | 6 روز |  |
| 555 | 1.2.5.3.3.4 | بتن ریزی | 1d | 2016-03-29 | 2016-03-29 | 554 | 2016-03-08 | 2016-03-15 | 0d | 130d | 0d | 52.5h | 50% | 7 روز | 7 روز |  |
| 556 | 1.2.5.4 | **سفت کاری** | 69d | 2016-02-15 | 2016-04-23 |  | 2015-12-27 | 2016-06-22 | 0d | 130d |  |  | 48% | 142 روز | 142 روز |  |
| 557 | 1.2.5.4.1 | **زیر زمین** | 25d | 2016-03-30 | 2016-04-23 |  | 2015-12-27 | 2016-01-25 | 0d | 130d |  |  | 60% | 26 روز | 26 روز |  |
| 558 | 1.2.5.4.1.1 | اجرای دیوارهای پیرامونی | 10d | 2016-03-30 | 2016-04-08 | 555 |  |  |  | 130d | 0d |  |  |  |  |  |
| 559 | 1.2.5.4.1.2 | ساخت و نصب نعل درگاه های پیرامونی | 10d | 2016-03-30 | 2016-04-08 | 558SS |  |  |  | 140d | 0d |  |  |  |  |  |
| 560 | 1.2.5.4.1.3 | ساخت فریم و چارچوب در و پنجره ها | 5d | 2016-03-30 | 2016-04-03 | 559SS |  |  |  | 140d | 0d |  |  |  |  |  |
| 561 | 1.2.5.4.1.4 | ساخت درهای فولادی | 10d | 2016-04-04 | 2016-04-13 | 560 |  |  |  | 140d | 0d |  |  |  |  |  |
| 562 | 1.2.5.4.1.5 | اجرای بلوکاژ | 5d | 2016-04-09 | 2016-04-13 | 559 |  |  |  | 140d |  |  |  |  |  |  |
| 563 | 1.2.5.4.1.6 | اجرای دیوار جداکننده داخلی | 5d | 2016-04-09 | 2016-04-13 | 558 |  |  |  | 130d | 0d |  |  |  |  |  |
| 564 | 1.2.5.4.1.7 | ساخت و نصب نعل درگاه های داخلی | 5d | 2016-04-04 | 2016-04-08 | 561SS |  |  |  | 145d |  |  |  |  |  |  |
| 565 | 1.2.5.4.1.8 | اجرای گچ و خاک دیوارها | 10d | 2016-04-14 | 2016-04-23 | 563 |  |  |  | 130d |  |  |  |  |  |  |

| ID | WBS | Task | Duration | Start | Finish | Predecessors | Total slack | Free slack | Constraint |
| --- | --- | --- | --- | --- | --- | --- | --- | --- | --- |
| 566 | 1.2.5.4.2 | **همکف** | 25d | 2016-02-15 | 2016-03-10 |  | 174d |  |  |
| 567 | 1.2.5.4.2.1 | اجرای دیوارهای پیرامونی | 5d | 2016-02-15 | 2016-02-19 | 550 | 174d | 0d |  |
| 568 | 1.2.5.4.2.2 | ساخت و نصب نعل درگاه های پیرامونی | 5d | 2016-02-15 | 2016-02-19 | 567SS | 174d | 0d |  |
| 569 | 1.2.5.4.2.3 | اجرای دیوار جداکننده داخلی | 5d | 2016-02-20 | 2016-02-24 | 568 | 174d | 0d |  |
| 570 | 1.2.5.4.2.4 | ساخت و نصب نعل درگاه های داخلی | 5d | 2016-02-20 | 2016-02-24 | 569SS | 189d |  |  |
| 571 | 1.2.5.4.2.5 | اجرای گچ و خاک دیوارها | 15d | 2016-02-25 | 2016-03-10 | 569 | 174d |  |  |
| 572 | 1.2.5.4.3 | **طبقه اول** | 25d | 2016-03-30 | 2016-04-23 |  | 130d |  |  |
| 573 | 1.2.5.4.3.1 | اجرای دیوارهای پیرامونی | 5d | 2016-03-30 | 2016-04-03 | 555 | 130d | 0d |  |
| 574 | 1.2.5.4.3.2 | ساخت و نصب نعل درگاه های پیرامونی | 5d | 2016-03-30 | 2016-04-03 | 573SS | 130d | 0d |  |
| 575 | 1.2.5.4.3.3 | اجرای دیوار جداکننده داخلی | 5d | 2016-04-04 | 2016-04-08 | 574 | 130d | 0d |  |
| 576 | 1.2.5.4.3.4 | ساخت و نصب نعل درگاه های داخلی | 5d | 2016-03-30 | 2016-04-03 | 574SS | 150d |  |  |
| 577 | 1.2.5.4.3.5 | اجرای گچ و خاک دیوارها | 15d | 2016-04-09 | 2016-04-23 | 575 | 130d |  |  |
| 578 | 1.2.5.5 | **بام ( مرحله اول )** | 19d | 2016-04-04 | 2016-04-22 |  | 131d |  |  |
| 579 | 1.2.5.5.1 | اجرای دیوار جان پناه پشت بام و خرپشته | 6d | 2016-04-04 | 2016-04-09 | 573 | 131d | 0d |  |
| 580 | 1.2.5.5.2 | سیمانکاری دیوار جانپناه | 3d | 2016-04-10 | 2016-04-12 | 579 | 131d | 0d |  |
| 581 | 1.2.5.5.3 | رابیتس بندی | 10d | 2016-04-13 | 2016-04-22 | 580 | 131d |  |  |
| 582 | 1.2.5.6 | **اجرای نمای بیرونی** | 82d | 2016-01-21 | 2016-04-11 |  | 142d |  |  |
| 583 | 1.2.5.6.1 | اجرای سنگ پلاک نما به همراه فتیله | 7d | 2016-01-21 | 2016-01-27 |  | 142d | 0d | start no earlier than 2016-01-21 |
| 584 | 1.2.5.6.2 | اجرای سنگ باکس تیر ها و ستون ها | 45d | 2016-01-28 | 2016-03-12 | 583 | 142d | 0d |  |
| 585 | 1.2.5.6.3 | اجرای سنگ پیش آمدگی ها | 30d | 2016-03-13 | 2016-04-11 | 584 | 142d |  |  |
| 586 | 1.2.5.6.4 | اجرای آستر سیمان سیاه دیوار جهت زیر سازی نمای شسته | 40d | 2016-01-21 | 2016-02-29 | 583SS | 144d | 0d |  |
| 587 | 1.2.5.6.5 | اجرای نمای شسته | 60d | 2016-01-31 | 2016-03-30 | 586SS+10d | 144d | 0d |  |
| 588 | 1.2.5.6.6 | اجرای درپوش بتنی جانپناه و کف پنجره ها | 10d | 2016-03-31 | 2016-04-09 | 587 | 144d |  |  |
| 589 | 1.2.5.7 | **تاسیسات مکانیکی ( مرحله اول )** | 60d | 2016-01-21 | 2016-03-20 |  | 53d |  |  |
| 590 | 1.2.5.7.1 | سوراخکاری و شیارزنی و کنده کاری داکت | 10d | 2016-01-21 | 2016-01-30 |  | 53d | 0d | start no earlier than 2016-01-21 |
| 591 | 1.2.5.7.2 | کانال کنی تاسیسات | 5d | 2016-01-21 | 2016-01-25 | 590SS | 53d | 0d |  |
| 592 | 1.2.5.7.3 | لوله کشی پلی اتیلن فاضلاب و آب باران | 20d | 2016-01-26 | 2016-02-14 | 591 | 53d | 0d |  |
| 593 | 1.2.5.7.4 | ساپورتهای لوله کشی تاسیسات | 5d | 2016-01-26 | 2016-01-30 | 592SS | 199d | 0d |  |
| 594 | 1.2.5.7.5 | لوله کشی گالوانیزه آب سرد و گرم | 15d | 2016-01-31 | 2016-02-14 | 593 | 199d |  |  |
| 595 | 1.2.5.7.6 | لوله کشی لوله های گرمایشی و پنج لایه | 25d | 2016-02-15 | 2016-03-10 | 592 | 125d | 0d |  |
| 596 | 1.2.5.7.7 | اجرای ساپورتهای کانال کولر | 5d | 2016-02-15 | 2016-02-19 | 592 | 53d | 0d |  |
| 597 | 1.2.5.7.8 | اجرای کانال کولر | 30d | 2016-02-20 | 2016-03-20 | 596 | 53d | 0d |  |
| 598 | 1.2.5.7.9 | اجرای کانال اگزاست | 20d | 2016-02-20 | 2016-03-10 | 597SS | 53d | 0d |  |
| 599 | 1.2.5.7.10 | عایق پشم شیشه و تست | 5d | 2016-03-11 | 2016-03-15 | 595 | 169d |  |  |
| 600 | 1.2.5.7.11 | اجرای لوله هایPVC | 2d | 2016-01-26 | 2016-01-27 | 592SS | 217d |  |  |

| ID | WBS | Task | Duration | Start | Finish | Predecessors | Total slack | Free slack | Constraint |
| --- | --- | --- | --- | --- | --- | --- | --- | --- | --- |
| 601 | 1.2.5.8 | **تاسیسات الکتریکی ( مرحله اول )** | 35d | 2016-01-21 | 2016-02-24 |  | 189d |  |  |
| 602 | 1.2.5.8.1 | شیارزنی | 10d | 2016-01-21 | 2016-01-30 | 590SS | 199d | 0d |  |
| 603 | 1.2.5.8.2 | اجرای لوله های PVC . PG13/5 | 15d | 2016-01-31 | 2016-02-14 | 602 | 199d | 0d |  |
| 604 | 1.2.5.8.3 | اجرای لوله های PVC . PG16-42 | 15d | 2016-01-31 | 2016-02-14 | 603SS | 199d | 0d |  |
| 605 | 1.2.5.8.4 | تهیه ساخت و سفارش تابلو برق | 10d | 2016-01-21 | 2016-01-30 | 602SS | 213d | 0d |  |
| 606 | 1.2.5.8.5 | غلاف گزاری | 3d | 2016-01-31 | 2016-02-02 | 604SS | 211d |  |  |
| 607 | 1.2.5.8.6 | سینی کابل | 5d | 2016-02-20 | 2016-02-24 | 598SS | 189d |  |  |
| 608 | 1.2.5.8.7 | نصب تابلو | 1d | 2016-01-31 | 2016-01-31 | 605 | 213d |  |  |
| 609 | 1.2.5.9 | **بام ( مرحله دوم )** | 42d | 2016-02-04 | 2016-03-16 |  | 168d |  |  |
| 610 | 1.2.5.9.1 | شیب بندی و اجرای بتن سبک بام | 5d | 2016-02-04 | 2016-02-08 |  | 168d | 0d | start no earlier than 2016-02-04 |
| 611 | 1.2.5.9.2 | اجرای سیمانکاری لیسه ای زیر عایق | 2d | 2016-02-09 | 2016-02-10 | 610 | 168d | 0d |  |
| 612 | 1.2.5.9.3 | اجرای عایق پشت بام | 2d | 2016-02-11 | 2016-02-12 | 611 | 168d | 0d |  |
| 613 | 1.2.5.9.4 | نصب تور مرغی قبل از سنگ اندود | 1d | 2016-02-13 | 2016-02-13 | 612 | 168d | 0d |  |
| 614 | 1.2.5.9.5 | اجرای سنگ قرنیز لاشتر | 4d | 2016-02-14 | 2016-02-17 | 613 | 168d | 0d |  |
| 615 | 1.2.5.9.6 | اجرای آستر سیمان سیاه و سفید بام | 10d | 2016-02-18 | 2016-02-27 | 614 | 168d | 0d |  |
| 616 | 1.2.5.9.7 | شیب بندی و اجرای موزاییک بام | 15d | 2016-02-28 | 2016-03-13 | 615 | 168d | 0d |  |
| 617 | 1.2.5.9.8 | نصب قرنیز گالوانیزه بام | 3d | 2016-03-14 | 2016-03-16 | 616 | 168d |  |  |
| 618 | 1.2.5.10 | **نازک کاری** | 105d | 2016-02-20 | 2016-06-03 |  | 53d |  |  |
| 619 | 1.2.5.10.1 | **زیر زمین** | 36d | 2016-02-20 | 2016-03-26 |  | 53d |  |  |
| 620 | 1.2.5.10.1.1 | اجرای کرم بندی و شیب بندی سرویسها و سالن غذاخوری | 4d | 2016-02-20 | 2016-02-23 | 598SS | 53d | 0d |  |
| 621 | 1.2.5.10.1.2 | اجرای عایق رطوبتی سالن غذاخوری و سرویسها | 2d | 2016-02-24 | 2016-02-25 | 620 | 53d | 0d |  |
| 622 | 1.2.5.10.1.3 | اجرای سیمان محافظ روی عایق | 2d | 2016-02-26 | 2016-02-27 | 621 | 186d |  |  |
| 623 | 1.2.5.10.1.4 | چیدن دیوارهای داکت | 2d | 2016-02-20 | 2016-02-21 | 620SS | 192d |  |  |
| 624 | 1.2.5.10.1.5 | نصب چارچوبهای در و پنجره | 5d | 2016-02-20 | 2016-02-24 | 620SS | 189d |  |  |
| 625 | 1.2.5.10.1.6 | اجرای قرنیز و سنگ و پلاک فضای داخلی دیوارها | 10d | 2016-02-26 | 2016-03-06 | 621 | 53d | 0d |  |
| 626 | 1.2.5.10.1.7 | اجرای گچ سفید دیوارها | 15d | 2016-03-07 | 2016-03-21 | 625 | 163d |  |  |
| 627 | 1.2.5.10.1.8 | اجرای کاشی دیوار سرویسها | 20d | 2016-02-26 | 2016-03-16 | 621 | 163d | 0d |  |
| 628 | 1.2.5.10.1.9 | اجرای سرامیک کف | 5d | 2016-03-17 | 2016-03-21 | 627 | 163d |  |  |
| 629 | 1.2.5.10.1.10 | اجرای سنگ گرانیت و چینی و موزائیک کف | 10d | 2016-03-07 | 2016-03-16 | 625 | 158d | 0d |  |
| 630 | 1.2.5.10.1.11 | اجرای سقف کاذب ( کناف فضای داخلی ) | 10d | 2016-03-17 | 2016-03-26 | 629 | 158d |  |  |
| 631 | 1.2.5.10.1.12 | اجرای سقف کاذب ( سرویس بهداشتی ) | 4d | 2016-03-17 | 2016-03-20 | 627 | 164d |  |  |

| ID | WBS | Task | Duration | Start | Finish | Predecessors | Baseline start | Baseline finish | Baseline duration | Total slack | Free slack | Work | Text1 | Text4 | Text5 | Text22 |
| --- | --- | --- | --- | --- | --- | --- | --- | --- | --- | --- | --- | --- | --- | --- | --- | --- |
| 632 | 1.2.5.10.2 | **همکف** | 33d | 2016-03-11 | 2016-04-12 |  |  |  |  | 125d |  |  |  |  |  |  |
| 633 | 1.2.5.10.2.1 | نصب چارچوبهای در و پنجره | 3d | 2016-03-11 | 2016-03-13 | 595 |  |  |  | 125d | 0d |  |  |  |  |  |
| 634 | 1.2.5.10.2.2 | اجرای قرنیز و سنگ و پلاک فضای داخلی دیوارها | 10d | 2016-03-14 | 2016-03-23 | 633 |  |  |  | 125d | 0d |  |  |  |  |  |
| 635 | 1.2.5.10.2.3 | اجرای سنگ گرانیت کف | 5d | 2016-03-24 | 2016-03-28 | 634 |  |  |  | 125d | 0d |  |  |  |  |  |
| 636 | 1.2.5.10.2.4 | اجرای گچ سفید | 3d | 2016-03-24 | 2016-03-26 | 634 |  |  |  | 158d |  |  |  |  |  |  |
| 637 | 1.2.5.10.2.5 | اجرای سقف کاذب ( کناف فضای داخلی ) | 15d | 2016-03-29 | 2016-04-12 | 635 |  |  |  | 141d |  |  |  |  |  |  |
| 638 | 1.2.5.10.3 | **طبقه اول** | 31d | 2016-03-29 | 2016-04-28 |  |  |  |  | 125d |  |  |  |  |  |  |
| 639 | 1.2.5.10.3.1 | نصب چارچوبهای در و پنجره | 3d | 2016-03-29 | 2016-03-31 | 635 |  |  |  | 125d | 0d |  |  |  |  |  |
| 640 | 1.2.5.10.3.2 | اجرای قرنیز و سنگ و پلاک فضای داخلی دیوارها | 10d | 2016-04-01 | 2016-04-10 | 639 |  |  |  | 125d | 0d |  |  |  |  |  |
| 641 | 1.2.5.10.3.3 | اجرای سنگ گرانیت کف | 5d | 2016-04-11 | 2016-04-15 | 640 |  |  |  | 125d | 0d |  |  |  |  |  |
| 642 | 1.2.5.10.3.4 | اجرای گچ سفید | 3d | 2016-04-16 | 2016-04-18 | 641 |  |  |  | 125d | 0d |  |  |  |  |  |
| 643 | 1.2.5.10.3.5 | اجرای سقف کاذب ( کناف فضای داخلی ) | 10d | 2016-04-19 | 2016-04-28 | 642 |  |  |  | 125d |  |  |  |  |  |  |
| 644 | 1.2.5.10.4 | **راه پله** | 79d | 2016-03-07 | 2016-05-24 |  |  |  |  | 53d |  |  |  |  |  |  |
| 645 | 1.2.5.10.4.1 | اجرای سنگ بدنه | 15d | 2016-03-07 | 2016-03-21 | 625 |  |  |  | 53d | 0d |  |  |  |  |  |
| 646 | 1.2.5.10.4.2 | اجرای سنگ پله ها | 25d | 2016-03-22 | 2016-04-15 | 645 |  |  |  | 53d | 0d |  |  |  |  |  |
| 647 | 1.2.5.10.4.3 | اجرای رابتس زیر پله | 8d | 2016-04-16 | 2016-04-23 | 646 |  |  |  | 53d | 0d |  |  |  |  |  |
| 648 | 1.2.5.10.4.4 | اجرای گچ و خاک پله ها | 10d | 2016-04-24 | 2016-05-03 | 647 |  |  |  | 53d | 0d |  |  |  |  |  |
| 649 | 1.2.5.10.4.5 | اجرای گچ سفید | 15d | 2016-05-04 | 2016-05-18 | 648 |  |  |  | 53d | 0d |  |  |  |  |  |
| 650 | 1.2.5.10.4.6 | اجرای لگه گیری گچ سفید زیر و بغل پله | 6d | 2016-05-19 | 2016-05-24 | 649 |  |  |  | 99d |  |  |  |  |  |  |
| 651 | 1.2.5.10.5 | **نصبیات و تکمیلی نازک کاری** | 31d | 2016-05-04 | 2016-06-03 |  |  |  |  | 89d |  |  |  |  |  |  |
| 652 | 1.2.5.10.5.1 | نصب در و پنجره های جوبی ، فولادی و UPVC | 7d | 2016-05-04 | 2016-05-10 | 648 |  |  |  | 89d | 0d |  |  |  |  |  |
| 653 | 1.2.5.10.5.2 | نصب شیشه ها | 4d | 2016-05-11 | 2016-05-14 | 652 |  |  |  | 89d | 0d |  |  |  |  |  |
| 654 | 1.2.5.10.5.3 | رنگ آمیزی سقف و دیوار | 20d | 2016-05-15 | 2016-06-03 | 653 |  |  |  | 89d |  |  |  |  |  |  |
| 655 | 1.2.5.11 | **تاسیسات الکتریکی ( مرحله دوم )** | 41d | 2016-05-19 | 2016-06-28 |  | 2016-01-05 | 2016-08-04 | 0d | 53d |  | 72h | 7% | 170 | 170 | 73 |
| 656 | 1.2.5.11.1 | اجرای سیم کشی و کابل کشی ساختمان | 20d | 2016-05-19 | 2016-06-07 | 649 |  |  |  | 53d | 0d |  |  |  |  |  |
| 657 | 1.2.5.11.2 | کابل کشی مخابرات و تجهیزات مربوطه | 5d | 2016-06-08 | 2016-06-12 | 656 |  |  |  | 75d | 0d |  |  |  |  |  |
| 658 | 1.2.5.11.3 | اجرا و نصب تابلو برق و جریان ضعیف | 5d | 2016-06-13 | 2016-06-17 | 657 |  |  |  | 75d |  |  |  |  |  |  |
| 659 | 1.2.5.11.4 | کلید و پریز | 5d | 2016-06-08 | 2016-06-12 | 656 |  |  |  | 53d | 0d |  |  |  |  |  |
| 660 | 1.2.5.11.5 | چراغ های ایندور | 5d | 2016-06-13 | 2016-06-17 | 659 |  |  |  | 53d | 0d |  |  |  |  |  |
| 661 | 1.2.5.11.6 | سیستم اعلام حریق | 5d | 2016-06-18 | 2016-06-22 | 660 |  |  |  | 53d | 0d |  |  |  |  |  |
| 662 | 1.2.5.11.7 | سیستم آنتن مرکزی | 3d | 2016-06-23 | 2016-06-25 | 661 |  |  |  | 53d | 0d |  |  |  |  |  |
| 663 | 1.2.5.11.8 | ارت سازی | 3d | 2016-06-26 | 2016-06-28 | 662 | 2016-01-05 | 2016-01-14 | 0d | 53d | 0d | 72h | 60% | 9 روز | 9 روز | 10 |

| ID | WBS | Task | Duration | Start | Finish | Predecessors | Baseline start | Baseline finish | Baseline duration | Total slack | Free slack | Constraint | Work | Text1 | Text4 | Text5 | Text22 | Text20 |
| --- | --- | --- | --- | --- | --- | --- | --- | --- | --- | --- | --- | --- | --- | --- | --- | --- | --- | --- |
| 664 | 1.2.5.12 | **تاسیسات مکانیکی ( مرحله دوم )** | 11d | 2016-06-29 | 2016-07-09 |  |  |  |  | 53d |  |  | 360h |  |  |  |  |  |
| 665 | 1.2.5.12.1 | شیر آلات بهداشتی | 4d | 2016-06-29 | 2016-07-02 | 663 | 2016-01-28 | 2016-02-11 | 0d | 53d | 0d |  | 104h | 100% | 13 روز | 13 روز | 10 |  |
| 666 | 1.2.5.12.2 | تجهیزات آتش نشانی | 4d | 2016-06-29 | 2016-07-02 | 665SS |  |  |  | 60d |  |  |  |  |  |  |  |  |
| 667 | 1.2.5.12.3 | نصب رادیاتور | 8d | 2016-06-29 | 2016-07-06 | 665SS | 2016-02-13 | 2016-02-23 | 0d | 53d | 0d |  | 80h | 0% | 10 روز | 10 روز |  |  |
| 668 | 1.2.5.12.4 | نصب دریچه های هوا و کولر | 3d | 2016-07-07 | 2016-07-09 | 667 | 2016-02-24 | 2016-04-03 | 0d | 53d |  |  | 176h | 0% | 22 روز | 22 روز | 12 |  |
| 669 | 1.2.6 | **ساختمان سرویس بهداشتی** | 289d | 2015-07-01 | 2016-04-14 |  | 2015-05-20 | 2016-10-01 | 0d | 139d |  |  | 615.5h | 37% | 349 روز | 417 روز | 296 | 296 |
| 670 | 1.2.6.1 | ابلاغ نقشه های فصل مشترک | 1d | 2015-07-01 | 2015-07-01 |  | 2015-09-19 | 2015-09-19 | 0d | 139d | 0d | start no earlier than 2015-07-01 | 7.5h | 100% | 1 روز | 1 روز |  |  |
| 671 | 1.2.6.2 | **سفت کاری** | 50d | 2015-12-25 | 2016-02-12 |  | 2015-12-27 | 2016-06-22 | 0d | 139d |  |  | 176h | 48% | 142 روز | 142 روز |  |  |
| 672 | 1.2.6.2.1 | اصلاح و اجرا دیوارهای پیرامونی | 25d | 2015-12-25 | 2016-01-18 | 670FS+176d |  |  |  | 139d | 0d |  |  |  |  |  |  |  |
| 673 | 1.2.6.2.2 | ساخت و نصب نعل درگاه های پیرامونی | 7d | 2016-01-19 | 2016-01-25 | 672 | 2015-12-27 | 2016-01-05 | 0d | 139d | 0d |  | 72h | 100% | 9 روز | 9 روز |  |  |
| 674 | 1.2.6.2.3 | اصلاح و اجرای دیوار جداکننده داخلی | 15d | 2016-01-19 | 2016-02-02 | 673SS | 2015-12-27 | 2016-01-05 | 0d | 139d | 0d |  | 104h | 69% | 9 روز | 9 روز |  |  |
| 675 | 1.2.6.2.4 | ساخت و نصب نعل درگاه های داخلی | 10d | 2016-02-03 | 2016-02-12 | 674 |  |  |  | 139d | 0d |  |  |  |  |  |  |  |
| 676 | 1.2.6.3 | **بام ( مرحله اول )** | 27d | 2016-02-13 | 2016-03-10 |  |  |  |  | 139d |  |  |  |  |  |  |  |  |
| 677 | 1.2.6.3.1 | اصلاح دیوار جان پناه پشت بام | 10d | 2016-02-13 | 2016-02-22 | 675 |  |  |  | 139d | 0d |  |  |  |  |  |  |  |
| 678 | 1.2.6.3.2 | اصلاح سیمانکاری دیوار جانپناه | 10d | 2016-02-23 | 2016-03-03 | 677 |  |  |  | 139d | 0d |  |  |  |  |  |  |  |
| 679 | 1.2.6.3.3 | رابیتس بندی | 7d | 2016-03-04 | 2016-03-10 | 678 |  |  |  | 139d | 0d |  |  |  |  |  |  |  |
| 680 | 1.2.6.4 | **اجرای نمای بیرونی** | 35d | 2016-03-11 | 2016-04-14 |  |  |  |  | 139d |  |  |  |  |  |  |  |  |
| 681 | 1.2.6.4.1 | اصلاح سنگ پلاک نما به همراه فتیله | 7d | 2016-03-11 | 2016-03-17 | 679 |  |  |  | 139d | 0d | start no earlier than 2016-01-21 |  |  |  |  |  |  |
| 682 | 1.2.6.4.2 | اجرای سنگ پیش آمدگی ها | 10d | 2016-03-18 | 2016-03-27 | 681 |  |  |  | 157d |  |  |  |  |  |  |  |  |
| 683 | 1.2.6.4.3 | اجرای آستر سیمان سیاه دیوار جهت زیر سازی نمای شسته | 25d | 2016-03-11 | 2016-04-04 | 681SS |  |  |  | 139d | 0d |  |  |  |  |  |  |  |
| 684 | 1.2.6.4.4 | اجرای نمای شسته | 25d | 2016-03-21 | 2016-04-14 | 683SS+10d |  |  |  | 139d | 0d |  |  |  |  |  |  |  |
| 685 | 1.2.6.4.5 | اجرای درپوش بتنی جانپناه و کف پنجره ها | 7d | 2016-03-21 | 2016-03-27 | 684SS |  |  |  | 157d |  |  |  |  |  |  |  |  |
| 686 | 1.2.6.5 | **تاسیسات مکانیکی ( مرحله اول )** | 39d | 2016-02-13 | 2016-03-22 |  |  |  |  | 154d |  |  |  |  |  |  |  |  |
| 687 | 1.2.6.5.1 | سوراخکاری و شیارزنی و کنده کاری داکت | 5d | 2016-02-13 | 2016-02-17 | 675 |  |  |  | 154d | 0d | start no earlier than 2016-01-21 |  |  |  |  |  |  |
| 688 | 1.2.6.5.2 | کانال کنی تاسیسات | 2d | 2016-02-18 | 2016-02-19 | 687 |  |  |  | 162d | 0d |  |  |  |  |  |  |  |
| 689 | 1.2.6.5.3 | لوله کشی پلی اتیلن فاضلاب و آب باران | 12d | 2016-02-20 | 2016-03-02 | 688 |  |  |  | 162d | 0d |  |  |  |  |  |  |  |
| 690 | 1.2.6.5.4 | ساپورتهای لوله کشی تاسیسات | 4d | 2016-03-03 | 2016-03-06 | 689 |  |  |  | 166d | 0d |  |  |  |  |  |  |  |
| 691 | 1.2.6.5.5 | لوله کشی گالوانیزه آب سرد و گرم | 12d | 2016-03-07 | 2016-03-18 | 690 |  |  |  | 166d |  |  |  |  |  |  |  |  |
| 692 | 1.2.6.5.6 | لوله کشی لوله های گرمایشی و پنج لایه | 15d | 2016-03-03 | 2016-03-17 | 689 |  |  |  | 162d | 0d |  |  |  |  |  |  |  |
| 693 | 1.2.6.5.7 | اجرای ساپورتهای کانال اگزاست | 5d | 2016-03-03 | 2016-03-07 | 689 |  |  |  | 177d |  |  |  |  |  |  |  |  |
| 694 | 1.2.6.5.8 | اجرای کانال اگزاست | 12d | 2016-02-13 | 2016-02-24 | 687SS |  |  |  | 154d | 0d |  |  |  |  |  |  |  |
| 695 | 1.2.6.5.9 | عایق پشم شیشه و تست | 5d | 2016-03-18 | 2016-03-22 | 692 |  |  |  | 162d |  |  |  |  |  |  |  |  |

| ID | WBS | Task | Duration | Start | Finish | Predecessors | Total slack | Free slack | Constraint |
| --- | --- | --- | --- | --- | --- | --- | --- | --- | --- |
| 696 | 1.2.6.6 | **تاسیسات الکتریکی ( مرحله اول )** | 32d | 2016-02-13 | 2016-03-15 |  | 169d |  |  |
| 697 | 1.2.6.6.1 | شیارزنی | 2d | 2016-02-13 | 2016-02-14 | 687SS | 169d | 0d |  |
| 698 | 1.2.6.6.2 | اجرای لوله های PVC . PG13/5 | 15d | 2016-02-15 | 2016-02-29 | 697 | 169d | 0d |  |
| 699 | 1.2.6.6.3 | اجرای لوله های PVC . PG16-42 | 15d | 2016-03-01 | 2016-03-15 | 698 | 169d | 0d |  |
| 700 | 1.2.6.6.4 | تهیه ساخت و سفارش تابلو برق | 15d | 2016-02-15 | 2016-02-29 | 697 | 183d | 0d |  |
| 701 | 1.2.6.6.5 | غلاف گزاری | 3d | 2016-03-01 | 2016-03-03 | 699SS | 181d |  |  |
| 702 | 1.2.6.6.6 | نصب تابلو | 1d | 2016-03-01 | 2016-03-01 | 700 | 183d |  |  |
| 703 | 1.2.6.7 | **بام ( مرحله دوم )** | 31d | 2016-02-23 | 2016-03-24 |  | 160d |  |  |
| 704 | 1.2.6.7.1 | شیب بندی و اجرای بتن سبک بام | 5d | 2016-02-23 | 2016-02-27 | 678SS | 160d | 0d | start no earlier than 2016-02-04 |
| 705 | 1.2.6.7.2 | اجرای سیمانکاری لیسه ای زیر عایق | 2d | 2016-02-28 | 2016-02-29 | 704 | 160d | 0d |  |
| 706 | 1.2.6.7.3 | اجرای عایق پشت بام | 2d | 2016-03-01 | 2016-03-02 | 705 | 160d | 0d |  |
| 707 | 1.2.6.7.4 | نصب تور مرغی قبل از سنگ اندود | 1d | 2016-03-03 | 2016-03-03 | 706 | 160d | 0d |  |
| 708 | 1.2.6.7.5 | اجرای سنگ قرنیز لاشتر | 4d | 2016-03-04 | 2016-03-07 | 707 | 160d | 0d |  |
| 709 | 1.2.6.7.6 | اجرای آستر سیمان سیاه و سفید بام | 5d | 2016-03-08 | 2016-03-12 | 708 | 160d | 0d |  |
| 710 | 1.2.6.7.7 | شیب بندی و اجرای موزاییک بام | 10d | 2016-03-13 | 2016-03-22 | 709 | 160d | 0d |  |
| 711 | 1.2.6.7.8 | نصب قرنیز گالوانیزه بام | 2d | 2016-03-23 | 2016-03-24 | 710 | 160d |  |  |
| 712 | 1.2.6.8 | **نازک کاری** | 35d | 2016-02-13 | 2016-03-18 |  | 154d |  |  |
| 713 | 1.2.6.8.1 | اجرای کرم بندی و شیب بندی سرویسها | 4d | 2016-02-13 | 2016-02-16 | 694SS | 154d | 0d |  |
| 714 | 1.2.6.8.2 | اجرای عایق رطوبتی | 2d | 2016-02-17 | 2016-02-18 | 713 | 154d | 0d |  |
| 715 | 1.2.6.8.3 | اجرای سیمان محافظ روی عایق | 1d | 2016-02-19 | 2016-02-19 | 714 | 194d |  |  |
| 716 | 1.2.6.8.4 | نصب چارچوبهای در و پنجره | 3d | 2016-02-13 | 2016-02-15 | 713SS | 198d |  |  |
| 717 | 1.2.6.8.5 | اجرای گچ سفید دیوارها | 4d | 2016-03-15 | 2016-03-18 | 720 | 166d |  |  |
| 718 | 1.2.6.8.6 | اجرای کاشی دیوار سرویسها | 20d | 2016-02-19 | 2016-03-09 | 714 | 154d | 0d |  |
| 719 | 1.2.6.8.7 | اجرای سرامیک کف | 4d | 2016-03-10 | 2016-03-13 | 718 | 154d | 0d |  |
| 720 | 1.2.6.8.8 | اجرای سنگ گرانیت و چینی و موزائیک کف | 5d | 2016-03-10 | 2016-03-14 | 719SS | 154d | 0d |  |
| 721 | 1.2.6.8.9 | اجرای سقف کاذب ( سرویس بهداشتی ) | 5d | 2016-03-10 | 2016-03-14 | 718 | 170d |  |  |

| ID | WBS | Task | Type | Duration | Start | Finish | Predecessors | Baseline start | Baseline finish | Baseline duration | Total slack | Free slack | Constraint | Work | Text1 | Text4 | Text5 | Text22 | Text20 |
| --- | --- | --- | --- | --- | --- | --- | --- | --- | --- | --- | --- | --- | --- | --- | --- | --- | --- | --- | --- |
| 722 | 1.2.6.9 | **نصبیات و تکمیلی نازک کاری** |  | 16d | 2016-03-15 | 2016-03-30 |  |  |  |  | 154d |  |  |  |  |  |  |  |  |
| 723 | 1.2.6.9.1 | نصب در و پنجره های جوبی ، فولادی و UPVC |  | 3d | 2016-03-15 | 2016-03-17 | 720 |  |  |  | 154d | 0d |  |  |  |  |  |  |  |
| 724 | 1.2.6.9.2 | نصب شیشه ها |  | 3d | 2016-03-18 | 2016-03-20 | 723 |  |  |  | 154d | 0d |  |  |  |  |  |  |  |
| 725 | 1.2.6.9.3 | رنگ آمیزی سقف و دیوار |  | 10d | 2016-03-21 | 2016-03-30 | 724 |  |  |  | 154d |  |  |  |  |  |  |  |  |
| 726 | 1.2.6.10 | **تاسیسات الکتریکی ( مرحله دوم )** |  | 16d | 2016-03-10 | 2016-03-25 |  | 2016-01-05 | 2016-08-04 | 0d | 157d |  |  | 72h | 7% | 170 | 170 | 73 |  |
| 727 | 1.2.6.10.1 | اجرای سیم کشی و کابل کشی ساختمان |  | 10d | 2016-03-10 | 2016-03-19 | 718 |  |  |  | 157d | 0d |  |  |  |  |  |  |  |
| 728 | 1.2.6.10.2 | کابل کشی مخابرات و تجهیزات مربوطه |  | 5d | 2016-03-20 | 2016-03-24 | 727 |  |  |  | 159d | 0d |  |  |  |  |  |  |  |
| 729 | 1.2.6.10.3 | اجرا و نصب تابلو برق و جریان ضعیف |  | 1d | 2016-03-25 | 2016-03-25 | 728 |  |  |  | 159d |  |  |  |  |  |  |  |  |
| 730 | 1.2.6.10.4 | کلید و پریز |  | 3d | 2016-03-20 | 2016-03-22 | 727 |  |  |  | 157d | 0d |  |  |  |  |  |  |  |
| 731 | 1.2.6.10.5 | چراغ های ایندور |  | 1d | 2016-03-23 | 2016-03-23 | 730 |  |  |  | 157d | 0d |  |  |  |  |  |  |  |
| 732 | 1.2.6.10.6 | سیستم اعلام حریق |  | 1d | 2016-03-24 | 2016-03-24 | 731 |  |  |  | 157d | 0d |  |  |  |  |  |  |  |
| 733 | 1.2.6.10.7 | ارت سازی |  | 1d | 2016-03-25 | 2016-03-25 | 732 | 2016-01-05 | 2016-01-14 | 0d | 157d | 0d |  | 72h | 60% | 9 روز | 9 روز | 10 |  |
| 734 | 1.2.6.11 | **تاسیسات مکانیکی ( مرحله دوم )** |  | 2d | 2016-03-26 | 2016-03-27 |  |  |  |  | 157d |  |  | 360h |  |  |  |  |  |
| 735 | 1.2.6.11.1 | شیر آلات بهداشتی |  | 2d | 2016-03-26 | 2016-03-27 | 733 | 2016-01-28 | 2016-02-11 | 0d | 157d | 0d |  | 104h | 100% | 13 روز | 13 روز | 10 |  |
| 736 | 1.2.6.11.2 | نصب رادیاتور |  | 1d | 2016-03-26 | 2016-03-26 | 735SS | 2016-02-13 | 2016-02-23 | 0d | 157d | 0d |  | 80h | 0% | 10 روز | 10 روز |  |  |
| 737 | 1.2.6.11.3 | نصب دریچه های هوا و اگزاست |  | 1d | 2016-03-27 | 2016-03-27 | 736 | 2016-02-24 | 2016-04-03 | 0d | 157d |  |  | 176h | 0% | 22 روز | 22 روز | 12 |  |
| 738 | 1.2.7 | **ساختمان حمام 1** |  | 396d | 2015-07-01 | 2016-07-30 |  | 2015-05-20 | 2016-10-01 | 0d | 32d |  |  | 1923.5h | 37% | 349 روز | 417 روز | 296 | 296 |
| 739 | 1.2.7.1 | ابلاغ نقشه های فصل مشترک |  | 1d | 2015-07-01 | 2015-07-01 |  | 2015-09-19 | 2015-09-19 | 0d | 42.12d | 0d | start no earlier than 2015-07-01 | 7.5h | 100% | 1 روز | 1 روز |  |  |
| 740 | 1.2.7.2 | **آماده سازی زمین** |  | 16d | 2015-07-02 | 2015-07-17 |  | 2015-06-29 | 2015-08-04 | 31.56d | 42d |  |  | 60h | 100% |  |  |  |  |
| 741 | 1.2.7.2.1 | نقشه برداري |  | 1d | 2015-07-02 | 2015-07-02 | 739 | 2015-06-29 | 2015-06-29 | 0.94d | 42.12d | 0d |  | 7.5h | 100% |  |  |  |  |
| 742 | 1.2.7.2.2 | پياده كردن كروكي ساختمان | milestone | 1d | 2015-07-03 | 2015-07-03 | 741 | 2015-06-29 | 2015-06-30 | 0.94d | 42.12d | 0d |  | 7.5h | 100% |  |  |  |  |
| 743 | 1.2.7.2.3 | تهیه فصل مشترک (برداشت از خاک های دپو شده) و حمل خاکها |  | 10d | 2015-07-04 | 2015-07-14 | 742 | 2015-06-30 | 2015-07-29 | 10d | 42.12d | 0.12d |  | 7.5h | 100% |  |  |  |  |
| 744 | 1.2.7.2.4 | پی کنی کل ساختمان |  | 3d | 2015-07-15 | 2015-07-17 | 743 | 2015-07-29 | 2015-08-04 | 4.69d | 42d | 0d | start no earlier than 2015-07-15 | 37.5h | 100% |  |  |  |  |
| 745 | 1.2.7.3 | **اجرای فونداسیون** |  | 47d | 2015-07-18 | 2015-09-02 |  |  |  |  | 42d |  |  |  |  |  |  |  |  |
| 746 | 1.2.7.3.1 | پیاده سازی ، رگلاژ و تسطیح |  | 10d | 2015-07-18 | 2015-07-27 | 744 |  |  |  | 42d | 0d |  |  |  |  |  |  |  |
| 747 | 1.2.7.3.2 | بتن مگر |  | 3d | 2015-07-28 | 2015-07-30 | 746 |  |  |  | 42d | 0d |  |  |  |  |  |  |  |
| 748 | 1.2.7.3.3 | آرماتور بندی فونداسیون و نصب صفحه ستون ها |  | 15d | 2015-07-31 | 2015-08-14 | 747 |  |  |  | 42d | 0d |  |  |  |  |  |  |  |
| 749 | 1.2.7.3.4 | قالب بندی |  | 12d | 2015-08-15 | 2015-08-26 | 748 |  |  |  | 42d | 0d |  |  |  |  |  |  |  |
| 750 | 1.2.7.3.5 | بتن ریزی |  | 2d | 2015-08-27 | 2015-08-28 | 749 |  |  |  | 42d | 0d |  |  |  |  |  |  |  |
| 751 | 1.2.7.3.6 | قلوه ریزی بین چشمه های فونداسیون |  | 5d | 2015-08-29 | 2015-09-02 | 750 |  |  |  | 42d | 0d |  |  |  |  |  |  |  |

| ID | WBS | Task | Type | Duration | Start | Finish | Predecessors | Baseline start | Baseline finish | Baseline duration | Total slack | Free slack | Constraint | Work | Text1 | Text4 | Text5 | Text22 |
| --- | --- | --- | --- | --- | --- | --- | --- | --- | --- | --- | --- | --- | --- | --- | --- | --- | --- | --- |
| 752 | 1.2.7.4 | **اجرای اسکلت فلزی** |  | 163d | 2015-09-03 | 2016-02-12 |  | 2015-05-20 | 2016-04-07 | 0d | 42d |  |  | 944h | 96% | 161 روز | 266 روز | 120 |
| 753 | 1.2.7.4.1 | توقف عملیات اجرای اسکلت طبق دستور نظارت |  | 60d | 2015-09-03 | 2015-11-01 | 751 |  |  |  | 42d | 0d |  |  |  |  |  |  |
| 754 | 1.2.7.4.2 | ساخت و مونتاژ ستون ها |  | 65d | 2015-11-02 | 2016-01-05 | 753 | 2015-09-20 | 2015-10-03 | 0d | 42d | 0d |  | 96h | 100% | 12 روز | 12 روز | 10 |
| 755 | 1.2.7.4.3 | ساخت و مونتاژ تیرهای حمال و تودلی |  | 30d | 2016-01-06 | 2016-02-04 | 754 | 2015-09-20 | 2016-01-02 | 0d | 42d | 0d |  | 760h | 100% | 90 روز | 90 روز | 120 |
| 756 | 1.2.7.4.4 | نصب ستون ها | milestone | 3d | 2016-02-05 | 2016-02-07 | 755 | 2015-10-04 | 2015-10-08 | 0d | 42d | 0d |  | 40h | 100% | 5 روز | 5 روز |  |
| 757 | 1.2.7.4.5 | نصب تیر های حمال و تودلی سقف همکف |  | 5d | 2016-02-08 | 2016-02-12 | 756 | 2015-10-10 | 2015-10-15 | 0d | 42d | 0d |  | 48h | 100% | 6 روز | 6 روز |  |
| 758 | 1.2.7.5 | **اجرای سقف** |  | 10d | 2016-02-13 | 2016-02-22 |  | 2015-10-25 | 2015-11-01 | 0d | 191d |  |  | 304h | 100% | 7 روز | 7 روز |  |
| 759 | 1.2.7.5.1 | برش کاری و نصب و پانچ ورقهای متال |  | 5d | 2016-02-13 | 2016-02-17 | 757 | 2015-11-10 | 2015-11-19 | 0d | 191d | 0d |  | 72h | 100% | 9 روز | 9 روز |  |
| 760 | 1.2.7.5.2 | جوشکاری گل میخ ها |  | 2d | 2016-02-18 | 2016-02-19 | 759 | 2015-11-21 | 2015-11-28 | 0d | 191d | 0d |  | 56h | 100% | 7 روز | 7 روز |  |
| 761 | 1.2.7.5.3 | آرماتور بندی |  | 2d | 2016-02-20 | 2016-02-21 | 760 | 2015-11-29 | 2015-12-09 | 0d | 191d | 0d |  | 64h | 100% | 10 روز | 10 روز |  |
| 762 | 1.2.7.5.4 | بتن ریزی |  | 1d | 2016-02-22 | 2016-02-22 | 761 | 2015-12-10 | 2015-12-26 | 0d | 191d | 0d |  | 112h | 100% | 14 روز | 14 روز |  |
| 763 | 1.2.7.6 | **سفت کاری** |  | 38d | 2016-02-23 | 2016-03-31 | 762 | 2015-12-27 | 2016-06-22 | 0d | 32d |  |  | 176h | 48% | 142 روز | 142 روز |  |
| 764 | 1.2.7.6.1 | کرسی چینی و ایزوگام |  | 7d | 2016-02-23 | 2016-02-29 | 757 |  |  |  | 32d | 0d |  |  |  |  |  |  |
| 765 | 1.2.7.6.2 | اجرای بلوکاژ (قلوه ریزی و شن نقلی ) |  | 3d | 2016-03-01 | 2016-03-03 | 764 |  |  |  | 32d | 0d |  |  |  |  |  |  |
| 766 | 1.2.7.6.3 | اجرای دیوارهای پیرامونی |  | 6d | 2016-03-04 | 2016-03-09 | 765 |  |  |  | 32d | 0d |  |  |  |  |  |  |
| 767 | 1.2.7.6.4 | ساخت و نصب نعل درگاه های پیرامونی |  | 5d | 2016-03-10 | 2016-03-14 | 766 | 2015-12-27 | 2016-01-05 | 0d | 32d | 0d |  | 72h | 100% | 9 روز | 9 روز |  |
| 768 | 1.2.7.6.5 | اجرای دیوار جداکننده داخلی |  | 7d | 2016-03-10 | 2016-03-16 | 767SS | 2015-12-27 | 2016-01-05 | 0d | 32d | 0d |  | 104h | 69% | 9 روز | 9 روز |  |
| 769 | 1.2.7.6.6 | ساخت و نصب نعل درگاه های داخلی |  | 5d | 2016-03-17 | 2016-03-21 | 768 |  |  |  | 32d | 0d |  |  |  |  |  |  |
| 770 | 1.2.7.6.7 | اجرای گچ و خاک دیوارها |  | 10d | 2016-03-22 | 2016-03-31 | 769 |  |  |  | 153d |  |  |  |  |  |  |  |
| 771 | 1.2.7.7 | **بام ( مرحله اول )** |  | 19d | 2016-03-22 | 2016-04-09 |  |  |  |  | 32d |  |  |  |  |  |  |  |
| 772 | 1.2.7.7.1 | اجرای دیوار جان پناه پشت بام و خرپشته |  | 6d | 2016-03-22 | 2016-03-27 | 769 |  |  |  | 32d | 0d |  |  |  |  |  |  |
| 773 | 1.2.7.7.2 | سیمانکاری دیوار جانپناه |  | 3d | 2016-03-28 | 2016-03-30 | 772 |  |  |  | 32d | 0d |  |  |  |  |  |  |
| 774 | 1.2.7.7.3 | رابیتس بندی |  | 10d | 2016-03-31 | 2016-04-09 | 773 |  |  |  | 79d | 0d |  |  |  |  |  |  |
| 775 | 1.2.7.8 | **اجرای نمای بیرونی** |  | 65d | 2016-04-10 | 2016-06-13 |  |  |  |  | 79d |  |  |  |  |  |  |  |
| 776 | 1.2.7.8.1 | اجرای سنگ پلاک نما به همراه فتیله |  | 5d | 2016-04-10 | 2016-04-14 | 774 |  |  |  | 79d | 0d | start no earlier than 2016-01-21 |  |  |  |  |  |
| 777 | 1.2.7.8.2 | اجرای سنگ پیش آمدگی ها |  | 10d | 2016-04-15 | 2016-04-24 | 776 |  |  |  | 79d | 0d |  |  |  |  |  |  |
| 778 | 1.2.7.8.3 | اجرای آستر سیمان سیاه دیوار جهت زیر سازی نمای شسته |  | 20d | 2016-04-25 | 2016-05-14 | 777 |  |  |  | 79d | 0d |  |  |  |  |  |  |
| 779 | 1.2.7.8.4 | اجرای نمای شسته |  | 30d | 2016-05-05 | 2016-06-03 | 778SS+10d |  |  |  | 79d | 0d |  |  |  |  |  |  |
| 780 | 1.2.7.8.5 | اجرای درپوش بتنی جانپناه و کف پنجره ها |  | 10d | 2016-06-04 | 2016-06-13 | 779 |  |  |  | 79d |  |  |  |  |  |  |  |

| ID | WBS | Task | Duration | Start | Finish | Predecessors | Total slack | Free slack | Constraint |
| --- | --- | --- | --- | --- | --- | --- | --- | --- | --- |
| 781 | 1.2.7.9 | **تاسیسات مکانیکی ( مرحله اول )** | 57d | 2016-03-31 | 2016-05-26 |  | 32d |  |  |
| 782 | 1.2.7.9.1 | سوراخکاری و شیارزنی و کنده کاری داکت | 7d | 2016-03-31 | 2016-04-06 | 773 | 32d | 0d | start no earlier than 2016-01-21 |
| 783 | 1.2.7.9.2 | کانال کنی تاسیسات | 2d | 2016-03-31 | 2016-04-01 | 782SS | 32d | 0d |  |
| 784 | 1.2.7.9.3 | لوله کشی پلی اتیلن فاضلاب و آب باران | 20d | 2016-04-02 | 2016-04-21 | 783 | 32d | 0d |  |
| 785 | 1.2.7.9.4 | ساپورتهای لوله کشی تاسیسات | 5d | 2016-04-02 | 2016-04-06 | 784SS | 132d | 0d |  |
| 786 | 1.2.7.9.5 | لوله کشی گالوانیزه آب سرد و گرم | 15d | 2016-04-07 | 2016-04-21 | 785 | 132d |  |  |
| 787 | 1.2.7.9.6 | لوله کشی لوله های گرمایشی و پنج لایه | 25d | 2016-04-22 | 2016-05-16 | 784 | 102d | 0d |  |
| 788 | 1.2.7.9.7 | اجرای ساپورتهای کانال کولر | 5d | 2016-04-22 | 2016-04-26 | 784 | 32d | 0d |  |
| 789 | 1.2.7.9.8 | اجرای کانال کولر | 30d | 2016-04-27 | 2016-05-26 | 788 | 32d | 0d |  |
| 790 | 1.2.7.9.9 | اجرای کانال اگزاست | 20d | 2016-04-27 | 2016-05-16 | 789SS | 32d | 0d |  |
| 791 | 1.2.7.9.10 | عایق پشم شیشه و تست | 5d | 2016-05-17 | 2016-05-21 | 787 | 102d |  |  |
| 792 | 1.2.7.9.11 | اجرای لوله هایPVC | 2d | 2016-04-02 | 2016-04-03 | 784SS | 108d | 0d |  |
| 793 | 1.2.7.10 | **تاسیسات الکتریکی ( مرحله اول )** | 32d | 2016-03-31 | 2016-05-01 |  | 122d |  |  |
| 794 | 1.2.7.10.1 | شیارزنی | 10d | 2016-03-31 | 2016-04-09 | 782SS | 129d | 0d |  |
| 795 | 1.2.7.10.2 | اجرای لوله های PVC . PG13/5 | 15d | 2016-04-10 | 2016-04-24 | 794 | 129d | 0d |  |
| 796 | 1.2.7.10.3 | اجرای لوله های PVC . PG16-42 | 15d | 2016-04-10 | 2016-04-24 | 795SS | 129d | 0d |  |
| 797 | 1.2.7.10.4 | تهیه ساخت و سفارش تابلو برق | 10d | 2016-03-31 | 2016-04-09 | 794SS | 143d | 0d |  |
| 798 | 1.2.7.10.5 | غلاف گزاری | 3d | 2016-04-10 | 2016-04-12 | 796SS | 141d |  |  |
| 799 | 1.2.7.10.6 | سینی کابل | 5d | 2016-04-27 | 2016-05-01 | 790SS | 122d |  |  |
| 800 | 1.2.7.10.7 | نصب تابلو | 1d | 2016-04-10 | 2016-04-10 | 797 | 143d |  |  |
| 801 | 1.2.7.11 | **بام ( مرحله دوم )** | 42d | 2016-04-04 | 2016-05-15 |  | 108d |  |  |
| 802 | 1.2.7.11.1 | شیب بندی و اجرای بتن سبک بام | 5d | 2016-04-04 | 2016-04-08 | 792 | 108d | 0d | start no earlier than 2016-02-04 |
| 803 | 1.2.7.11.2 | اجرای سیمانکاری لیسه ای زیر عایق | 2d | 2016-04-09 | 2016-04-10 | 802 | 108d | 0d |  |
| 804 | 1.2.7.11.3 | اجرای عایق پشت بام | 2d | 2016-04-11 | 2016-04-12 | 803 | 108d | 0d |  |
| 805 | 1.2.7.11.4 | نصب تور مرغی قبل از سنگ اندود | 1d | 2016-04-13 | 2016-04-13 | 804 | 108d | 0d |  |
| 806 | 1.2.7.11.5 | اجرای سنگ قرنیز لاشتر | 4d | 2016-04-14 | 2016-04-17 | 805 | 108d | 0d |  |
| 807 | 1.2.7.11.6 | اجرای آستر سیمان سیاه و سفید بام | 10d | 2016-04-18 | 2016-04-27 | 806 | 108d | 0d |  |
| 808 | 1.2.7.11.7 | شیب بندی و اجرای موزاییک بام | 15d | 2016-04-28 | 2016-05-12 | 807 | 108d | 0d |  |
| 809 | 1.2.7.11.8 | نصب قرنیز گالوانیزه بام | 3d | 2016-05-13 | 2016-05-15 | 808 | 108d |  |  |

| ID | WBS | Task | Duration | Start | Finish | Predecessors | Baseline start | Baseline finish | Baseline duration | Total slack | Free slack | Work | Text1 | Text4 | Text5 | Text22 |
| --- | --- | --- | --- | --- | --- | --- | --- | --- | --- | --- | --- | --- | --- | --- | --- | --- |
| 810 | 1.2.7.12 | **نازک کاری** | 70d | 2016-04-27 | 2016-07-05 |  |  |  |  | 32d |  |  |  |  |  |  |
| 811 | 1.2.7.12.1 | اجرای کرم بندی و شیب بندی سرویسها | 10d | 2016-04-27 | 2016-05-06 | 790SS |  |  |  | 32d | 0d |  |  |  |  |  |
| 812 | 1.2.7.12.2 | اجرای عایق رطوبتی | 5d | 2016-05-07 | 2016-05-11 | 811 |  |  |  | 32d | 0d |  |  |  |  |  |
| 813 | 1.2.7.12.3 | اجرای سیمان محافظ روی عایق | 2d | 2016-05-12 | 2016-05-13 | 812 |  |  |  | 110d |  |  |  |  |  |  |
| 814 | 1.2.7.12.4 | چیدن دیوارهای داکت | 2d | 2016-04-27 | 2016-04-28 | 811SS |  |  |  | 125d |  |  |  |  |  |  |
| 815 | 1.2.7.12.5 | نصب چارچوبهای در و پنجره | 5d | 2016-04-27 | 2016-05-01 | 811SS |  |  |  | 122d |  |  |  |  |  |  |
| 816 | 1.2.7.12.6 | اجرای قرنیز و سنگ و پلاک فضای داخلی دیوارها | 10d | 2016-05-12 | 2016-05-21 | 812 |  |  |  | 32d | 0d |  |  |  |  |  |
| 817 | 1.2.7.12.7 | اجرای گچ سفید دیوارها | 15d | 2016-05-22 | 2016-06-05 | 816 |  |  |  | 87d |  |  |  |  |  |  |
| 818 | 1.2.7.12.8 | اجرای کاشی دیوار سرویسها | 40d | 2016-05-12 | 2016-06-20 | 812 |  |  |  | 57d | 0d |  |  |  |  |  |
| 819 | 1.2.7.12.9 | اجرای سرامیک کف | 15d | 2016-06-21 | 2016-07-05 | 818 |  |  |  | 57d |  |  |  |  |  |  |
| 820 | 1.2.7.12.10 | اجرای سنگ گرانیت و چینی و موزائیک کف | 10d | 2016-05-22 | 2016-05-31 | 816 |  |  |  | 32d | 0d |  |  |  |  |  |
| 821 | 1.2.7.12.11 | اجرای سقف کاذب ( کناف فضای داخلی ) | 4d | 2016-06-01 | 2016-06-04 | 820 |  |  |  | 32d | 0d |  |  |  |  |  |
| 822 | 1.2.7.12.12 | اجرای سقف کاذب ( سرویس بهداشتی ) | 10d | 2016-06-21 | 2016-06-30 | 818 |  |  |  | 62d |  |  |  |  |  |  |
| 823 | 1.2.7.13 | **نصبیات و تکمیلی نازک کاری** | 16d | 2016-06-01 | 2016-06-16 |  |  |  |  | 76d |  |  |  |  |  |  |
| 824 | 1.2.7.13.1 | نصب در و پنجره های جوبی ، فولادی و UPVC | 3d | 2016-06-01 | 2016-06-03 | 821SS |  |  |  | 76d | 0d |  |  |  |  |  |
| 825 | 1.2.7.13.2 | نصب شیشه ها | 3d | 2016-06-04 | 2016-06-06 | 824 |  |  |  | 76d | 0d |  |  |  |  |  |
| 826 | 1.2.7.13.3 | رنگ آمیزی سقف و دیوار | 10d | 2016-06-07 | 2016-06-16 | 825 |  |  |  | 76d |  |  |  |  |  |  |
| 827 | 1.2.7.14 | **تاسیسات الکتریکی ( مرحله دوم )** | 41d | 2016-06-05 | 2016-07-15 |  | 2016-01-05 | 2016-08-04 | 0d | 32d |  | 72h | 7% | 170 | 170 | 73 |
| 828 | 1.2.7.14.1 | اجرای سیم کشی و کابل کشی ساختمان | 20d | 2016-06-05 | 2016-06-24 | 821 |  |  |  | 32d | 0d |  |  |  |  |  |
| 829 | 1.2.7.14.2 | کابل کشی مخابرات و تجهیزات مربوطه | 5d | 2016-06-25 | 2016-06-29 | 828 |  |  |  | 32d | 0d |  |  |  |  |  |
| 830 | 1.2.7.14.3 | اجرا و نصب تابلو برق و جریان ضعیف | 5d | 2016-06-30 | 2016-07-04 | 829 |  |  |  | 58d |  |  |  |  |  |  |
| 831 | 1.2.7.14.4 | کلید و پریز | 5d | 2016-06-25 | 2016-06-29 | 828 |  |  |  | 47d | 0d |  |  |  |  |  |
| 832 | 1.2.7.14.5 | چراغ های ایندور | 5d | 2016-06-30 | 2016-07-04 | 831 |  |  |  | 47d | 0d |  |  |  |  |  |
| 833 | 1.2.7.14.6 | سیستم اعلام حریق | 5d | 2016-07-05 | 2016-07-09 | 832 |  |  |  | 47d | 0d |  |  |  |  |  |
| 834 | 1.2.7.14.7 | سیستم آنتن مرکزی | 3d | 2016-07-10 | 2016-07-12 | 833 |  |  |  | 47d | 0d |  |  |  |  |  |
| 835 | 1.2.7.14.8 | ارت سازی | 3d | 2016-07-13 | 2016-07-15 | 834 | 2016-01-05 | 2016-01-14 | 0d | 47d |  | 72h | 60% | 9 روز | 9 روز | 10 |

| ID | WBS | Task | Type | Duration | Start | Finish | Predecessors | Baseline start | Baseline finish | Baseline duration | Total slack | Free slack | Constraint | Work | Text1 | Text4 | Text5 | Text22 | Text20 |
| --- | --- | --- | --- | --- | --- | --- | --- | --- | --- | --- | --- | --- | --- | --- | --- | --- | --- | --- | --- |
| 836 | 1.2.7.15 | **تاسیسات مکانیکی ( مرحله دوم )** |  | 30d | 2016-07-01 | 2016-07-30 |  |  |  |  | 32d |  |  | 360h |  |  |  |  |  |
| 837 | 1.2.7.15.1 | شیر آلات بهداشتی |  | 5d | 2016-07-01 | 2016-07-05 | 829FS+1d | 2016-01-28 | 2016-02-11 | 0d | 32d | 0d |  | 104h | 100% | 13 روز | 13 روز | 10 |  |
| 838 | 1.2.7.15.2 | تجهیزات آتش نشانی |  | 4d | 2016-07-01 | 2016-07-04 | 837SS |  |  |  | 58d |  |  |  |  |  |  |  |  |
| 839 | 1.2.7.15.3 | نصب رادیاتور |  | 10d | 2016-07-01 | 2016-07-10 | 837SS | 2016-02-13 | 2016-02-23 | 0d | 32d | 0d |  | 80h | 0% | 10 روز | 10 روز |  |  |
| 840 | 1.2.7.15.4 | نصب دریچه های هوا و کولر |  | 3d | 2016-07-01 | 2016-07-03 | 839SS | 2016-02-24 | 2016-04-03 | 0d | 59d |  |  | 176h | 0% | 22 روز | 22 روز | 12 |  |
| 841 | 1.2.7.15.5 | نصبیات موتورخانه |  | 30d | 2016-07-01 | 2016-07-30 | 839SS |  |  |  | 32d |  |  |  |  |  |  |  |  |
| 842 | 1.2.8 | **ساختمان حمام 2** |  | 396d | 2015-07-01 | 2016-07-30 |  | 2015-05-20 | 2016-10-01 | 0d | 32d |  |  | 1923.5h | 37% | 349 روز | 417 روز | 296 | 296 |
| 843 | 1.2.8.1 | ابلاغ نقشه های فصل مشترک |  | 1d | 2015-07-01 | 2015-07-01 |  | 2015-09-19 | 2015-09-19 | 0d | 38d | 0d | start no earlier than 2015-07-01 | 7.5h | 100% | 1 روز | 1 روز |  |  |
| 844 | 1.2.8.2 | **آماده سازی زمین** |  | 30d | 2015-07-02 | 2015-07-31 |  | 2015-06-29 | 2015-08-04 | 31.56d | 38d |  |  | 60h | 100% |  |  |  |  |
| 845 | 1.2.8.2.1 | نقشه برداري |  | 1d | 2015-07-02 | 2015-07-02 | 843 | 2015-06-29 | 2015-06-29 | 0.94d | 38d | 0d |  | 7.5h | 100% |  |  |  |  |
| 846 | 1.2.8.2.2 | پياده كردن كروكي ساختمان | milestone | 1d | 2015-07-03 | 2015-07-03 | 845 | 2015-06-29 | 2015-06-30 | 0.94d | 38d | 0d |  | 7.5h | 100% |  |  |  |  |
| 847 | 1.2.8.2.3 | تهیه فصل مشترک (برداشت از خاک های دپو شده) و حمل خاکها |  | 10d | 2015-07-04 | 2015-07-28 | 846 | 2015-06-30 | 2015-07-29 | 10d | 38d | 0d |  | 7.5h | 100% |  |  |  |  |
| 848 | 1.2.8.2.4 | پی کنی کل ساختمان |  | 3d | 2015-07-29 | 2015-07-31 | 847 | 2015-07-29 | 2015-08-04 | 4.69d | 38d | 0d |  | 37.5h | 100% |  |  |  |  |
| 849 | 1.2.8.3 | **اجرای فونداسیون** |  | 48d | 2015-08-01 | 2015-09-17 |  |  |  |  | 38d |  |  |  |  |  |  |  |  |
| 850 | 1.2.8.3.1 | پیاده سازی ، رگلاژ و تسطیح |  | 10d | 2015-08-01 | 2015-08-10 | 848 |  |  |  | 38d | 0d |  |  |  |  |  |  |  |
| 851 | 1.2.8.3.2 | بتن مگر |  | 5d | 2015-08-11 | 2015-08-15 | 850 |  |  |  | 38d | 0d |  |  |  |  |  |  |  |
| 852 | 1.2.8.3.3 | آرماتور بندی فونداسیون و نصب صفحه ستون ها |  | 15d | 2015-08-16 | 2015-08-30 | 851 |  |  |  | 38d | 0d |  |  |  |  |  |  |  |
| 853 | 1.2.8.3.4 | قالب بندی |  | 12d | 2015-08-31 | 2015-09-11 | 852 |  |  |  | 38d | 0d |  |  |  |  |  |  |  |
| 854 | 1.2.8.3.5 | بتن ریزی |  | 1d | 2015-09-12 | 2015-09-12 | 853 |  |  |  | 38d | 0d |  |  |  |  |  |  |  |
| 855 | 1.2.8.3.6 | قلوه ریزی بین چشمه های فونداسیون |  | 5d | 2015-09-13 | 2015-09-17 | 854 |  |  |  | 38d | 0d |  |  |  |  |  |  |  |
| 856 | 1.2.8.4 | **اجرای اسکلت فلزی** |  | 145d | 2015-09-18 | 2016-02-09 |  | 2015-05-20 | 2016-04-07 | 0d | 38d |  |  | 944h | 96% | 161 روز | 266 روز | 120 |  |
| 857 | 1.2.8.4.1 | توقف عملیات اجرای اسکلت طبق دستور نظارت |  | 60d | 2015-09-18 | 2015-11-16 | 855 |  |  |  | 38d | 0d |  |  |  |  |  |  |  |
| 858 | 1.2.8.4.2 | ساخت و مونتاژ ستون ها |  | 60d | 2015-11-17 | 2016-01-15 | 857 | 2015-09-20 | 2015-10-03 | 0d | 38d | 0d |  | 96h | 100% | 12 روز | 12 روز | 10 |  |
| 859 | 1.2.8.4.3 | ساخت و مونتاژ تیرهای حمال و تودلی |  | 20d | 2016-01-16 | 2016-02-04 | 858 | 2015-09-20 | 2016-01-02 | 0d | 38d | 0d |  | 760h | 100% | 90 روز | 90 روز | 120 |  |
| 860 | 1.2.8.4.4 | نصب ستون ها | milestone | 2d | 2016-02-05 | 2016-02-06 | 859 | 2015-10-04 | 2015-10-08 | 0d | 38d | 0d |  | 40h | 100% | 5 روز | 5 روز |  |  |
| 861 | 1.2.8.4.5 | نصب تیر های حمال و تودلی سقف همکف |  | 3d | 2016-02-07 | 2016-02-09 | 860 | 2015-10-10 | 2015-10-15 | 0d | 38d | 0d |  | 48h | 100% | 6 روز | 6 روز |  |  |

| ID | WBS | Task | Duration | Start | Finish | Predecessors | Baseline start | Baseline finish | Baseline duration | Total slack | Free slack | Constraint | Work | Text1 | Text4 | Text5 |
| --- | --- | --- | --- | --- | --- | --- | --- | --- | --- | --- | --- | --- | --- | --- | --- | --- |
| 862 | 1.2.8.5 | **اجرای سقف** | 6d | 2016-02-10 | 2016-02-15 |  | 2015-10-25 | 2015-11-01 | 0d | 198d |  |  | 304h | 100% | 7 روز | 7 روز |
| 863 | 1.2.8.5.1 | برش کاری و نصب و پانچ ورقهای متال | 3d | 2016-02-10 | 2016-02-12 | 861 | 2015-11-10 | 2015-11-19 | 0d | 198d | 0d |  | 72h | 100% | 9 روز | 9 روز |
| 864 | 1.2.8.5.2 | جوشکاری گل میخ ها | 1d | 2016-02-13 | 2016-02-13 | 863 | 2015-11-21 | 2015-11-28 | 0d | 198d | 0d |  | 56h | 100% | 7 روز | 7 روز |
| 865 | 1.2.8.5.3 | آرماتور بندی | 1d | 2016-02-14 | 2016-02-14 | 864 | 2015-11-29 | 2015-12-09 | 0d | 198d | 0d |  | 64h | 100% | 10 روز | 10 روز |
| 866 | 1.2.8.5.4 | بتن ریزی | 1d | 2016-02-15 | 2016-02-15 | 865 | 2015-12-10 | 2015-12-26 | 0d | 198d | 0d |  | 112h | 100% | 14 روز | 14 روز |
| 867 | 1.2.8.6 | **سفت کاری** | 28d | 2016-02-16 | 2016-03-14 | 866 | 2015-12-27 | 2016-06-22 | 0d | 32d |  |  | 176h | 48% | 142 روز | 142 روز |
| 868 | 1.2.8.6.1 | کرسی چینی و ایزوگام | 5d | 2016-02-16 | 2016-02-20 | 861 |  |  |  | 32d | 0d |  |  |  |  |  |
| 869 | 1.2.8.6.2 | اجرای بلوکاژ (قلوه ریزی و شن نقلی ) | 3d | 2016-02-21 | 2016-02-23 | 868 |  |  |  | 32d | 0d |  |  |  |  |  |
| 870 | 1.2.8.6.3 | اجرای دیوارهای پیرامونی | 5d | 2016-02-24 | 2016-02-28 | 869 |  |  |  | 32d | 0d |  |  |  |  |  |
| 871 | 1.2.8.6.4 | ساخت و نصب نعل درگاه های پیرامونی | 5d | 2016-02-29 | 2016-03-04 | 870 | 2015-12-27 | 2016-01-05 | 0d | 32d | 0d |  | 72h | 100% | 9 روز | 9 روز |
| 872 | 1.2.8.6.5 | اجرای دیوار جداکننده داخلی | 5d | 2016-02-29 | 2016-03-04 | 871SS | 2015-12-27 | 2016-01-05 | 0d | 32d | 0d |  | 104h | 69% | 9 روز | 9 روز |
| 873 | 1.2.8.6.6 | ساخت و نصب نعل درگاه های داخلی | 5d | 2016-03-05 | 2016-03-09 | 872 |  |  |  | 32d | 0d |  |  |  |  |  |
| 874 | 1.2.8.6.7 | اجرای گچ و خاک دیوارها | 5d | 2016-03-10 | 2016-03-14 | 873 |  |  |  | 170d |  |  |  |  |  |  |
| 875 | 1.2.8.7 | **بام ( مرحله اول )** | 19d | 2016-03-10 | 2016-03-28 |  |  |  |  | 32d |  |  |  |  |  |  |
| 876 | 1.2.8.7.1 | اجرای دیوار جان پناه پشت بام و خرپشته | 6d | 2016-03-10 | 2016-03-15 | 873 |  |  |  | 32d | 0d |  |  |  |  |  |
| 877 | 1.2.8.7.2 | سیمانکاری دیوار جانپناه | 3d | 2016-03-16 | 2016-03-18 | 876 |  |  |  | 32d | 0d |  |  |  |  |  |
| 878 | 1.2.8.7.3 | رابیتس بندی | 10d | 2016-03-19 | 2016-03-28 | 877 |  |  |  | 91d | 0d |  |  |  |  |  |
| 879 | 1.2.8.8 | **اجرای نمای بیرونی** | 65d | 2016-03-29 | 2016-06-01 |  |  |  |  | 91d |  |  |  |  |  |  |
| 880 | 1.2.8.8.1 | اجرای سنگ پلاک نما به همراه فتیله | 5d | 2016-03-29 | 2016-04-02 | 878 |  |  |  | 91d | 0d | start no earlier than 2016-01-21 |  |  |  |  |
| 881 | 1.2.8.8.2 | اجرای سنگ پیش آمدگی ها | 10d | 2016-04-03 | 2016-04-12 | 880 |  |  |  | 91d | 0d |  |  |  |  |  |
| 882 | 1.2.8.8.3 | اجرای آستر سیمان سیاه دیوار جهت زیر سازی نمای شسته | 20d | 2016-04-13 | 2016-05-02 | 881 |  |  |  | 91d | 0d |  |  |  |  |  |
| 883 | 1.2.8.8.4 | اجرای نمای شسته | 30d | 2016-04-23 | 2016-05-22 | 882SS+10d |  |  |  | 91d | 0d |  |  |  |  |  |
| 884 | 1.2.8.8.5 | اجرای درپوش بتنی جانپناه و کف پنجره ها | 10d | 2016-05-23 | 2016-06-01 | 883 |  |  |  | 91d |  |  |  |  |  |  |
| 885 | 1.2.8.9 | **تاسیسات مکانیکی ( مرحله اول )** | 57d | 2016-03-19 | 2016-05-14 |  |  |  |  | 32d |  |  |  |  |  |  |
| 886 | 1.2.8.9.1 | سوراخکاری و شیارزنی و کنده کاری داکت | 7d | 2016-03-19 | 2016-03-25 | 877 |  |  |  | 32d | 0d | start no earlier than 2016-01-21 |  |  |  |  |
| 887 | 1.2.8.9.2 | کانال کنی تاسیسات | 2d | 2016-03-19 | 2016-03-20 | 886SS |  |  |  | 32d | 0d |  |  |  |  |  |
| 888 | 1.2.8.9.3 | لوله کشی پلی اتیلن فاضلاب و آب باران | 20d | 2016-03-21 | 2016-04-09 | 887 |  |  |  | 32d | 0d |  |  |  |  |  |
| 889 | 1.2.8.9.4 | ساپورتهای لوله کشی تاسیسات | 5d | 2016-03-21 | 2016-03-25 | 888SS |  |  |  | 144d | 0d |  |  |  |  |  |
| 890 | 1.2.8.9.5 | لوله کشی گالوانیزه آب سرد و گرم | 15d | 2016-03-26 | 2016-04-09 | 889 |  |  |  | 144d |  |  |  |  |  |  |
| 891 | 1.2.8.9.6 | لوله کشی لوله های گرمایشی و پنج لایه | 25d | 2016-04-10 | 2016-05-04 | 888 |  |  |  | 114d | 0d |  |  |  |  |  |
| 892 | 1.2.8.9.7 | اجرای ساپورتهای کانال کولر | 5d | 2016-04-10 | 2016-04-14 | 888 |  |  |  | 32d | 0d |  |  |  |  |  |
| 893 | 1.2.8.9.8 | اجرای کانال کولر | 30d | 2016-04-15 | 2016-05-14 | 892 |  |  |  | 32d | 0d |  |  |  |  |  |
| 894 | 1.2.8.9.9 | اجرای کانال اگزاست | 20d | 2016-04-15 | 2016-05-04 | 893SS |  |  |  | 32d | 0d |  |  |  |  |  |
| 895 | 1.2.8.9.10 | عایق پشم شیشه و تست | 5d | 2016-05-05 | 2016-05-09 | 891 |  |  |  | 114d |  |  |  |  |  |  |
| 896 | 1.2.8.9.11 | اجرای لوله هایPVC | 2d | 2016-03-21 | 2016-03-22 | 888SS |  |  |  | 120d | 0d |  |  |  |  |  |

| ID | WBS | Task | Duration | Start | Finish | Predecessors | Total slack | Free slack | Constraint |
| --- | --- | --- | --- | --- | --- | --- | --- | --- | --- |
| 897 | 1.2.8.10 | **تاسیسات الکتریکی ( مرحله اول )** | 32d | 2016-03-19 | 2016-04-19 |  | 134d |  |  |
| 898 | 1.2.8.10.1 | شیارزنی | 10d | 2016-03-19 | 2016-03-28 | 886SS | 141d | 0d |  |
| 899 | 1.2.8.10.2 | اجرای لوله های PVC . PG13/5 | 15d | 2016-03-29 | 2016-04-12 | 898 | 141d | 0d |  |
| 900 | 1.2.8.10.3 | اجرای لوله های PVC . PG16-42 | 15d | 2016-03-29 | 2016-04-12 | 899SS | 141d | 0d |  |
| 901 | 1.2.8.10.4 | تهیه ساخت و سفارش تابلو برق | 10d | 2016-03-19 | 2016-03-28 | 898SS | 155d | 0d |  |
| 902 | 1.2.8.10.5 | غلاف گزاری | 3d | 2016-03-29 | 2016-03-31 | 900SS | 153d |  |  |
| 903 | 1.2.8.10.6 | سینی کابل | 5d | 2016-04-15 | 2016-04-19 | 894SS | 134d |  |  |
| 904 | 1.2.8.10.7 | نصب تابلو | 1d | 2016-03-29 | 2016-03-29 | 901 | 155d |  |  |
| 905 | 1.2.8.11 | **بام ( مرحله دوم )** | 42d | 2016-03-23 | 2016-05-03 |  | 120d |  |  |
| 906 | 1.2.8.11.1 | شیب بندی و اجرای بتن سبک بام | 5d | 2016-03-23 | 2016-03-27 | 896 | 120d | 0d | start no earlier than 2016-02-04 |
| 907 | 1.2.8.11.2 | اجرای سیمانکاری لیسه ای زیر عایق | 2d | 2016-03-28 | 2016-03-29 | 906 | 120d | 0d |  |
| 908 | 1.2.8.11.3 | اجرای عایق پشت بام | 2d | 2016-03-30 | 2016-03-31 | 907 | 120d | 0d |  |
| 909 | 1.2.8.11.4 | نصب تور مرغی قبل از سنگ اندود | 1d | 2016-04-01 | 2016-04-01 | 908 | 120d | 0d |  |
| 910 | 1.2.8.11.5 | اجرای سنگ قرنیز لاشتر | 4d | 2016-04-02 | 2016-04-05 | 909 | 120d | 0d |  |
| 911 | 1.2.8.11.6 | اجرای آستر سیمان سیاه و سفید بام | 10d | 2016-04-06 | 2016-04-15 | 910 | 120d | 0d |  |
| 912 | 1.2.8.11.7 | شیب بندی و اجرای موزاییک بام | 15d | 2016-04-16 | 2016-04-30 | 911 | 120d | 0d |  |
| 913 | 1.2.8.11.8 | نصب قرنیز گالوانیزه بام | 3d | 2016-05-01 | 2016-05-03 | 912 | 120d |  |  |
| 914 | 1.2.8.12 | **نازک کاری** | 70d | 2016-04-15 | 2016-06-23 |  | 32d |  |  |
| 915 | 1.2.8.12.1 | اجرای کرم بندی و شیب بندی سرویسها | 10d | 2016-04-15 | 2016-04-24 | 894SS | 32d | 0d |  |
| 916 | 1.2.8.12.2 | اجرای عایق رطوبتی | 5d | 2016-04-25 | 2016-04-29 | 915 | 32d | 0d |  |
| 917 | 1.2.8.12.3 | اجرای سیمان محافظ روی عایق | 2d | 2016-04-30 | 2016-05-01 | 916 | 122d |  |  |
| 918 | 1.2.8.12.4 | چیدن دیوارهای داکت | 2d | 2016-04-15 | 2016-04-16 | 915SS | 137d |  |  |
| 919 | 1.2.8.12.5 | نصب چارچوبهای در و پنجره | 5d | 2016-04-15 | 2016-04-19 | 915SS | 134d |  |  |
| 920 | 1.2.8.12.6 | اجرای قرنیز و سنگ و پلاک فضای داخلی دیوارها | 10d | 2016-04-30 | 2016-05-09 | 916 | 32d | 0d |  |
| 921 | 1.2.8.12.7 | اجرای گچ سفید دیوارها | 15d | 2016-05-10 | 2016-05-24 | 920 | 99d |  |  |
| 922 | 1.2.8.12.8 | اجرای کاشی دیوار سرویسها | 40d | 2016-04-30 | 2016-06-08 | 916 | 69d | 0d |  |
| 923 | 1.2.8.12.9 | اجرای سرامیک کف | 15d | 2016-06-09 | 2016-06-23 | 922 | 69d |  |  |
| 924 | 1.2.8.12.10 | اجرای سنگ گرانیت و چینی و موزائیک کف | 10d | 2016-05-10 | 2016-05-19 | 920 | 32d | 0d |  |
| 925 | 1.2.8.12.11 | اجرای سقف کاذب ( کناف فضای داخلی ) | 4d | 2016-05-20 | 2016-05-23 | 924 | 32d | 0d |  |
| 926 | 1.2.8.12.12 | اجرای سقف کاذب ( سرویس بهداشتی ) | 10d | 2016-06-09 | 2016-06-18 | 922 | 74d |  |  |

| ID | WBS | Task | Duration | Start | Finish | Predecessors | Baseline start | Baseline finish | Baseline duration | Total slack | Free slack | Constraint | Work | Text1 | Text4 | Text5 | Text22 | Text20 |
| --- | --- | --- | --- | --- | --- | --- | --- | --- | --- | --- | --- | --- | --- | --- | --- | --- | --- | --- |
| 927 | 1.2.8.13 | **نصبیات و تکمیلی نازک کاری** | 16d | 2016-05-20 | 2016-06-04 |  |  |  |  | 88d |  |  |  |  |  |  |  |  |
| 928 | 1.2.8.13.1 | نصب در و پنجره های جوبی ، فولادی و UPVC | 3d | 2016-05-20 | 2016-05-22 | 925SS |  |  |  | 88d | 0d |  |  |  |  |  |  |  |
| 929 | 1.2.8.13.2 | نصب شیشه ها | 3d | 2016-05-23 | 2016-05-25 | 928 |  |  |  | 88d | 0d |  |  |  |  |  |  |  |
| 930 | 1.2.8.13.3 | رنگ آمیزی سقف و دیوار | 10d | 2016-05-26 | 2016-06-04 | 929 |  |  |  | 88d |  |  |  |  |  |  |  |  |
| 931 | 1.2.8.14 | **تاسیسات الکتریکی ( مرحله دوم )** | 41d | 2016-05-24 | 2016-07-03 |  | 2016-01-05 | 2016-08-04 | 0d | 32d |  |  | 72h | 7% | 170 | 170 | 73 |  |
| 932 | 1.2.8.14.1 | اجرای سیم کشی و کابل کشی ساختمان | 20d | 2016-05-24 | 2016-06-12 | 925 |  |  |  | 32d | 0d |  |  |  |  |  |  |  |
| 933 | 1.2.8.14.2 | کابل کشی مخابرات و تجهیزات مربوطه | 5d | 2016-06-13 | 2016-06-17 | 932 |  |  |  | 32d | 0d |  |  |  |  |  |  |  |
| 934 | 1.2.8.14.3 | اجرا و نصب تابلو برق و جریان ضعیف | 5d | 2016-06-18 | 2016-06-22 | 933 |  |  |  | 70d |  |  |  |  |  |  |  |  |
| 935 | 1.2.8.14.4 | کلید و پریز | 5d | 2016-06-13 | 2016-06-17 | 932 |  |  |  | 59d | 0d |  |  |  |  |  |  |  |
| 936 | 1.2.8.14.5 | چراغ های ایندور | 5d | 2016-06-18 | 2016-06-22 | 935 |  |  |  | 59d | 0d |  |  |  |  |  |  |  |
| 937 | 1.2.8.14.6 | سیستم اعلام حریق | 5d | 2016-06-23 | 2016-06-27 | 936 |  |  |  | 59d | 0d |  |  |  |  |  |  |  |
| 938 | 1.2.8.14.7 | سیستم آنتن مرکزی | 3d | 2016-06-28 | 2016-06-30 | 937 |  |  |  | 59d | 0d |  |  |  |  |  |  |  |
| 939 | 1.2.8.14.8 | ارت سازی | 3d | 2016-07-01 | 2016-07-03 | 938 | 2016-01-05 | 2016-01-14 | 0d | 59d |  |  | 72h | 60% | 9 روز | 9 روز | 10 |  |
| 940 | 1.2.8.15 | **تاسیسات مکانیکی ( مرحله دوم )** | 43d | 2016-06-18 | 2016-07-30 |  |  |  |  | 32d |  |  | 360h |  |  |  |  |  |
| 941 | 1.2.8.15.1 | شیر آلات بهداشتی | 5d | 2016-06-18 | 2016-06-22 | 933 | 2016-01-28 | 2016-02-11 | 0d | 32d | 0d |  | 104h | 100% | 13 روز | 13 روز | 10 |  |
| 942 | 1.2.8.15.2 | تجهیزات آتش نشانی | 4d | 2016-06-18 | 2016-06-21 | 941SS |  |  |  | 71d |  |  |  |  |  |  |  |  |
| 943 | 1.2.8.15.3 | نصب رادیاتور | 5d | 2016-06-18 | 2016-06-22 | 941SS | 2016-02-13 | 2016-02-23 | 0d | 32d | 0d |  | 80h | 0% | 10 روز | 10 روز |  |  |
| 944 | 1.2.8.15.4 | نصب دریچه های هوا و کولر | 3d | 2016-06-18 | 2016-06-20 | 943SS | 2016-02-24 | 2016-04-03 | 0d | 32d | 0d |  | 176h | 0% | 22 روز | 22 روز | 12 |  |
| 945 | 1.2.8.15.5 | نصبیات موتورخانه | 40d | 2016-06-21 | 2016-07-30 | 944 |  |  |  | 32d |  |  |  |  |  |  |  |  |
| 946 | 1.2.9 | **ساختمان سوله انبار 1** | 355d | 2015-07-01 | 2016-06-19 |  | 2015-05-20 | 2016-10-01 | 0d | 73d |  |  | 1598.5h | 37% | 349 روز | 417 روز | 296 | 296 |
| 947 | 1.2.9.1 | ابلاغ نقشه های فصل مشترک | 1d | 2015-07-01 | 2015-07-01 |  | 2015-09-19 | 2015-09-19 | 0d | 73d | 0d | start no earlier than 2015-07-01 | 7.5h | 100% | 1 روز | 1 روز |  |  |
| 948 | 1.2.9.2 | **آماده سازی زمین** | 33d | 2015-07-28 | 2015-08-29 |  | 2015-06-29 | 2015-08-05 | 33d | 73d |  |  | 87h | 100% |  |  |  |  |
| 949 | 1.2.9.2.1 | نقشه برداري | 1d | 2015-07-28 | 2015-07-28 | 947FS+26d | 2015-06-29 | 2015-06-29 | 1d | 73d | 0d |  | 8h | 100% |  |  |  |  |
| 950 | 1.2.9.2.2 | پياده كردن كروكي ساختمان | 1d | 2015-07-29 | 2015-07-29 | 949 | 2015-06-30 | 2015-06-30 | 1d | 73d | 0d |  | 8h | 100% |  |  |  |  |
| 951 | 1.2.9.2.3 | تهیه فصل مشترک (برداشت از خاک های دپو شده) و حمل خاکها | 3d | 2015-07-30 | 2015-08-15 | 950 | 2015-07-01 | 2015-07-20 | 3d | 73d | 0d |  | 7.5h | 100% |  |  |  |  |
| 952 | 1.2.9.2.4 | اجرای عملیات بنایی با سنگ (بدلیل پایین بودن سطح خاکبرداری) | 7d | 2015-08-16 | 2015-08-22 | 951 | 2015-07-21 | 2015-07-28 | 7d | 73d | 0d |  | 7.5h | 100% |  |  |  |  |
| 953 | 1.2.9.2.5 | پی کنی | 7d | 2015-08-23 | 2015-08-29 | 952 | 2015-07-29 | 2015-08-05 | 7d | 368d |  |  | 56h | 100% |  |  |  |  |

Notes:
- 951: تاخی تا تاری 4/30 بابت تعیی تکلی و صورتجلسه جهت حمل خاک های دپو شده

| ID | WBS | Task | Type | Duration | Start | Finish | Predecessors | Baseline start | Baseline finish | Baseline duration | Total slack | Free slack | Work | Text1 | Text4 | Text5 | Text22 |
| --- | --- | --- | --- | --- | --- | --- | --- | --- | --- | --- | --- | --- | --- | --- | --- | --- | --- |
| 954 | 1.2.9.3 | **اجرای فونداسیون** |  | 42d | 2015-08-23 | 2015-10-03 |  |  |  |  | 73d |  |  |  |  |  |  |
| 955 | 1.2.9.3.1 | پیاده سازی ، رگلاژ و تسطیح |  | 7d | 2015-08-23 | 2015-08-29 | 952 |  |  |  | 73d | 0d |  |  |  |  |  |
| 956 | 1.2.9.3.2 | بتن مگر |  | 6d | 2015-08-30 | 2015-09-04 | 955 |  |  |  | 73d | 0d |  |  |  |  |  |
| 957 | 1.2.9.3.3 | آرماتور بندی فونداسیون و نصب صفحه ستون ها |  | 12d | 2015-09-05 | 2015-09-16 | 956 |  |  |  | 73d | 0d |  |  |  |  |  |
| 958 | 1.2.9.3.4 | قالب بندی |  | 8d | 2015-09-17 | 2015-09-24 | 957 |  |  |  | 73d | 0d |  |  |  |  |  |
| 959 | 1.2.9.3.5 | بتن ریزی |  | 1d | 2015-09-25 | 2015-09-25 | 958 |  |  |  | 73d | 0d |  |  |  |  |  |
| 960 | 1.2.9.3.6 | قلوه ریزی بین چشمه های فونداسیون |  | 8d | 2015-09-26 | 2015-10-03 | 959 |  |  |  | 73d | 0d |  |  |  |  |  |
| 961 | 1.2.9.4 | **اجرای اسکلت فلزی** |  | 94d | 2015-10-04 | 2016-01-05 |  | 2015-05-20 | 2016-04-07 | 0d | 73d |  | 896h | 96% | 161 روز | 266 روز | 120 |
| 962 | 1.2.9.4.1 | ساخت و مونتاژ ستون ها و رفترها (قاب اصلی ) |  | 60d | 2015-10-04 | 2015-12-02 | 960 | 2015-09-20 | 2015-10-03 | 0d | 73d | 0d | 96h | 100% | 12 روز | 12 روز | 10 |
| 963 | 1.2.9.4.2 | ساخت و مونتاژ والپست ها و تیر ریزی داخلی وبادبند ها |  | 15d | 2015-12-03 | 2015-12-17 | 962 | 2015-09-20 | 2016-01-02 | 0d | 73d | 0d | 760h | 100% | 90 روز | 90 روز | 120 |
| 964 | 1.2.9.4.3 | نصب قاب های اصلی سوله | milestone | 7d | 2015-12-18 | 2015-12-24 | 963 | 2015-10-04 | 2015-10-08 | 0d | 73d | 0d | 40h | 100% | 5 روز | 5 روز |  |
| 965 | 1.2.9.4.4 | نصب والپست ها و ستون های میانی |  | 5d | 2015-12-25 | 2015-12-29 | 964 | 2015-10-10 | 2015-10-15 | 0d | 73d | 0d |  | 100% | 6 روز | 6 روز |  |
| 966 | 1.2.9.4.5 | نصب بادبند ها |  | 7d | 2015-12-30 | 2016-01-05 | 965 |  |  |  | 73d | 0d |  |  |  |  |  |
| 967 | 1.2.9.5 | **اجرای سقف سوله (ورق کرکره ای و پشم شیشه )** |  | 10d | 2016-01-06 | 2016-01-15 |  |  |  |  | 229d |  |  |  |  |  |  |
| 968 | 1.2.9.5.1 | اجرای تور مرغی |  | 2d | 2016-01-06 | 2016-01-07 | 966 |  |  |  | 229d | 0d |  |  |  |  |  |
| 969 | 1.2.9.5.2 | اجرای پشم شیشه |  | 2d | 2016-01-08 | 2016-01-09 | 968 |  |  |  | 229d | 0d |  |  |  |  |  |
| 970 | 1.2.9.5.3 | اجرای ورق کرکره ای |  | 4d | 2016-01-10 | 2016-01-13 | 969 |  |  |  | 229d | 0d |  |  |  |  |  |
| 971 | 1.2.9.5.4 | اجرای آبراه باران |  | 2d | 2016-01-14 | 2016-01-15 | 970 |  |  |  | 229d |  |  |  |  |  |  |
| 972 | 1.2.9.6 | **سفت کاری** |  | 59d | 2016-01-06 | 2016-03-04 |  | 2015-12-27 | 2016-06-22 | 0d | 73d |  | 176h | 48% | 142 روز | 142 روز |  |
| 973 | 1.2.9.6.1 | کرسی چینی و ایزوگام |  | 5d | 2016-01-06 | 2016-01-10 | 966 |  |  |  | 73d | 0d |  |  |  |  |  |
| 974 | 1.2.9.6.2 | اجرای بلوکاژ (قلوه ریزی و شن نقلی ) |  | 3d | 2016-01-11 | 2016-01-13 | 973 |  |  |  | 73d | 0d |  |  |  |  |  |
| 975 | 1.2.9.6.3 | اجرای دیوارهای پیرامونی |  | 4d | 2016-01-14 | 2016-01-17 | 974 |  |  |  | 73d | 0d |  |  |  |  |  |
| 976 | 1.2.9.6.4 | ساخت و نصب نعل درگاه های پیرامونی |  | 15d | 2016-01-18 | 2016-02-01 | 975 | 2015-12-27 | 2016-01-05 | 0d | 73d | 0d | 72h | 100% | 9 روز | 9 روز |  |
| 977 | 1.2.9.6.5 | اجرای دیوار جداکننده داخلی |  | 2d | 2016-02-17 | 2016-02-18 | 976SS+30d | 2015-12-27 | 2016-01-05 | 0d | 73d | 0d | 104h | 69% | 9 روز | 9 روز |  |
| 978 | 1.2.9.6.6 | ساخت و نصب نعل درگاه های داخلی |  | 5d | 2016-02-19 | 2016-02-23 | 977 |  |  |  | 73d | 0d |  |  |  |  |  |
| 979 | 1.2.9.6.7 | اجرای گچ و خاک دیوارها |  | 10d | 2016-02-24 | 2016-03-04 | 978 |  |  |  | 73d | 0d |  |  |  |  |  |

| ID | WBS | Task | Duration | Start | Finish | Predecessors | Total slack | Free slack | Constraint |
| --- | --- | --- | --- | --- | --- | --- | --- | --- | --- |
| 980 | 1.2.9.7 | **اجرای نمای بیرونی** | 82d | 2016-02-24 | 2016-05-15 |  | 108d |  |  |
| 981 | 1.2.9.7.1 | اجرای سنگ پلاک نما به همراه فتیله | 7d | 2016-02-24 | 2016-03-01 | 978 | 108d | 0d | start no earlier than 2016-01-21 |
| 982 | 1.2.9.7.2 | اجرای سنگ باکس تیر ها و ستون ها | 45d | 2016-03-02 | 2016-04-15 | 981 | 108d | 0d |  |
| 983 | 1.2.9.7.3 | اجرای سنگ پیش آمدگی ها | 30d | 2016-04-16 | 2016-05-15 | 982 | 108d |  |  |
| 984 | 1.2.9.7.4 | اجرای آستر سیمان سیاه دیوار جهت زیر سازی نمای شسته | 40d | 2016-02-24 | 2016-04-03 | 981SS | 110d | 0d |  |
| 985 | 1.2.9.7.5 | اجرای نمای شسته | 60d | 2016-03-05 | 2016-05-03 | 984SS+10d | 110d | 0d |  |
| 986 | 1.2.9.7.6 | اجرای درپوش بتنی جانپناه و کف پنجره ها | 10d | 2016-05-04 | 2016-05-13 | 985 | 110d |  |  |
| 987 | 1.2.9.8 | **تاسیسات مکانیکی ( مرحله اول )** | 60d | 2016-03-05 | 2016-05-03 |  | 73d |  |  |
| 988 | 1.2.9.8.1 | سوراخکاری و شیارزنی و کنده کاری داکت | 10d | 2016-03-05 | 2016-03-14 | 979 | 73d | 0d | start no earlier than 2016-01-21 |
| 989 | 1.2.9.8.2 | کانال کنی تاسیسات | 5d | 2016-03-05 | 2016-03-09 | 988SS | 73d | 0d |  |
| 990 | 1.2.9.8.3 | لوله کشی پلی اتیلن فاضلاب و آب باران | 20d | 2016-03-10 | 2016-03-29 | 989 | 73d | 0d |  |
| 991 | 1.2.9.8.4 | ساپورتهای لوله کشی تاسیسات | 5d | 2016-03-10 | 2016-03-14 | 990SS | 155d | 0d |  |
| 992 | 1.2.9.8.5 | لوله کشی گالوانیزه آب سرد و گرم | 15d | 2016-03-15 | 2016-03-29 | 991 | 155d |  |  |
| 993 | 1.2.9.8.6 | لوله کشی لوله های گرمایشی و پنج لایه | 25d | 2016-03-30 | 2016-04-23 | 990 | 125d | 0d |  |
| 994 | 1.2.9.8.7 | اجرای ساپورتهای کانال کولر | 5d | 2016-03-30 | 2016-04-03 | 990 | 73d | 0d |  |
| 995 | 1.2.9.8.8 | اجرای کانال کولر | 30d | 2016-04-04 | 2016-05-03 | 994 | 73d | 0d |  |
| 996 | 1.2.9.8.9 | اجرای کانال اگزاست | 20d | 2016-04-04 | 2016-04-23 | 995SS | 73d | 0d |  |
| 997 | 1.2.9.8.10 | عایق پشم شیشه و تست | 5d | 2016-04-24 | 2016-04-28 | 993 | 125d |  |  |
| 998 | 1.2.9.8.11 | اجرای لوله هایPVC | 2d | 2016-03-10 | 2016-03-11 | 990SS | 173d |  |  |
| 999 | 1.2.9.9 | **تاسیسات الکتریکی ( مرحله اول )** | 35d | 2016-03-05 | 2016-04-08 |  | 145d |  |  |
| 1000 | 1.2.9.9.1 | شیارزنی | 10d | 2016-03-05 | 2016-03-14 | 988SS | 155d | 0d |  |
| 1001 | 1.2.9.9.2 | اجرای لوله های PVC . PG13/5 | 15d | 2016-03-15 | 2016-03-29 | 1000 | 155d | 0d |  |
| 1002 | 1.2.9.9.3 | اجرای لوله های PVC . PG16-42 | 15d | 2016-03-15 | 2016-03-29 | 1001SS | 155d | 0d |  |
| 1003 | 1.2.9.9.4 | تهیه ساخت و سفارش تابلو برق | 10d | 2016-03-05 | 2016-03-14 | 1000SS | 169d | 0d |  |
| 1004 | 1.2.9.9.5 | غلاف گزاری | 3d | 2016-03-15 | 2016-03-17 | 1002SS | 167d |  |  |
| 1005 | 1.2.9.9.6 | سینی کابل | 5d | 2016-04-04 | 2016-04-08 | 996SS | 145d |  |  |
| 1006 | 1.2.9.9.7 | نصب تابلو | 1d | 2016-03-15 | 2016-03-15 | 1003 | 169d |  |  |

| ID | WBS | Task | Duration | Start | Finish | Predecessors | Baseline start | Baseline finish | Baseline duration | Total slack | Free slack | Work | Text1 | Text4 | Text5 | Text22 |
| --- | --- | --- | --- | --- | --- | --- | --- | --- | --- | --- | --- | --- | --- | --- | --- | --- |
| 1007 | 1.2.9.10 | **نازک کاری** | 36d | 2016-04-04 | 2016-05-09 |  |  |  |  | 73d |  |  |  |  |  |  |
| 1008 | 1.2.9.10.1 | اجرای کرم بندی و شیب بندی سرویسها | 4d | 2016-04-04 | 2016-04-07 | 996SS |  |  |  | 73d | 0d |  |  |  |  |  |
| 1009 | 1.2.9.10.2 | اجرای عایق رطوبتی | 2d | 2016-04-08 | 2016-04-09 | 1008 |  |  |  | 73d | 0d |  |  |  |  |  |
| 1010 | 1.2.9.10.3 | اجرای سیمان محافظ روی عایق | 2d | 2016-04-10 | 2016-04-11 | 1009 |  |  |  | 142d |  |  |  |  |  |  |
| 1011 | 1.2.9.10.4 | چیدن دیوارهای داکت | 2d | 2016-04-04 | 2016-04-05 | 1008SS |  |  |  | 148d |  |  |  |  |  |  |
| 1012 | 1.2.9.10.5 | نصب چارچوبهای در و پنجره | 5d | 2016-04-04 | 2016-04-08 | 1008SS |  |  |  | 145d |  |  |  |  |  |  |
| 1013 | 1.2.9.10.6 | اجرای قرنیز و سنگ و پلاک فضای داخلی دیوارها | 10d | 2016-04-10 | 2016-04-19 | 1009 |  |  |  | 73d | 0d |  |  |  |  |  |
| 1014 | 1.2.9.10.7 | اجرای گچ سفید دیوارها | 15d | 2016-04-20 | 2016-05-04 | 1013 |  |  |  | 119d |  |  |  |  |  |  |
| 1015 | 1.2.9.10.8 | اجرای کاشی دیوار سرویسها | 20d | 2016-04-10 | 2016-04-29 | 1009 |  |  |  | 119d | 0d |  |  |  |  |  |
| 1016 | 1.2.9.10.9 | اجرای سرامیک کف | 5d | 2016-04-30 | 2016-05-04 | 1015 |  |  |  | 119d |  |  |  |  |  |  |
| 1017 | 1.2.9.10.10 | اجرای سنگ گرانیت و چینی و موزائیک کف | 10d | 2016-04-20 | 2016-04-29 | 1013 |  |  |  | 73d | 0d |  |  |  |  |  |
| 1018 | 1.2.9.10.11 | اجرای سقف کاذب ( کناف فضای داخلی ) | 10d | 2016-04-30 | 2016-05-09 | 1017 |  |  |  | 73d | 0d |  |  |  |  |  |
| 1019 | 1.2.9.10.12 | اجرای سقف کاذب ( سرویس بهداشتی ) | 4d | 2016-04-30 | 2016-05-03 | 1015 |  |  |  | 120d |  |  |  |  |  |  |
| 1020 | 1.2.9.11 | **نصبیات و تکمیلی نازک کاری** | 16d | 2016-04-30 | 2016-05-15 |  |  |  |  | 108d |  |  |  |  |  |  |
| 1021 | 1.2.9.11.1 | نصب در و پنجره های جوبی ، فولادی و UPVC | 3d | 2016-04-30 | 2016-05-02 | 1018SS |  |  |  | 108d | 0d |  |  |  |  |  |
| 1022 | 1.2.9.11.2 | نصب شیشه ها | 3d | 2016-05-03 | 2016-05-05 | 1021 |  |  |  | 108d | 0d |  |  |  |  |  |
| 1023 | 1.2.9.11.3 | رنگ آمیزی سقف و دیوار | 10d | 2016-05-06 | 2016-05-15 | 1022 |  |  |  | 108d |  |  |  |  |  |  |
| 1024 | 1.2.9.12 | **تاسیسات الکتریکی ( مرحله دوم )** | 41d | 2016-04-30 | 2016-06-09 |  | 2016-01-05 | 2016-08-04 | 0d | 73d |  | 72h | 7% | 170 | 170 | 73 |
| 1025 | 1.2.9.12.1 | اجرای سیم کشی و کابل کشی ساختمان | 20d | 2016-04-30 | 2016-05-19 | 1018SS |  |  |  | 73d | 0d |  |  |  |  |  |
| 1026 | 1.2.9.12.2 | کابل کشی مخابرات و تجهیزات مربوطه | 5d | 2016-05-20 | 2016-05-24 | 1025 |  |  |  | 94d | 0d |  |  |  |  |  |
| 1027 | 1.2.9.12.3 | اجرا و نصب تابلو برق و جریان ضعیف | 5d | 2016-05-25 | 2016-05-29 | 1026 |  |  |  | 94d |  |  |  |  |  |  |
| 1028 | 1.2.9.12.4 | کلید و پریز | 5d | 2016-05-20 | 2016-05-24 | 1025 |  |  |  | 73d | 0d |  |  |  |  |  |
| 1029 | 1.2.9.12.5 | چراغ های ایندور | 5d | 2016-05-25 | 2016-05-29 | 1028 |  |  |  | 73d | 0d |  |  |  |  |  |
| 1030 | 1.2.9.12.6 | سیستم اعلام حریق | 5d | 2016-05-30 | 2016-06-03 | 1029 |  |  |  | 73d | 0d |  |  |  |  |  |
| 1031 | 1.2.9.12.7 | سیستم آنتن مرکزی | 3d | 2016-06-04 | 2016-06-06 | 1030 |  |  |  | 73d | 0d |  |  |  |  |  |
| 1032 | 1.2.9.12.8 | ارت سازی | 3d | 2016-06-07 | 2016-06-09 | 1031 | 2016-01-05 | 2016-01-14 | 0d | 73d | 0d | 72h | 60% | 9 روز | 9 روز | 10 |

| ID | WBS | Task | Type | Duration | Start | Finish | Predecessors | Baseline start | Baseline finish | Baseline duration | Total slack | Free slack | Constraint | Work | Text1 | Text4 | Text5 | Text22 | Text20 |
| --- | --- | --- | --- | --- | --- | --- | --- | --- | --- | --- | --- | --- | --- | --- | --- | --- | --- | --- | --- |
| 1033 | 1.2.9.13 | **تاسیسات مکانیکی ( مرحله دوم )** |  | 10d | 2016-06-10 | 2016-06-19 |  |  |  |  | 73d |  |  | 360h |  |  |  |  |  |
| 1034 | 1.2.9.13.1 | شیر آلات بهداشتی |  | 5d | 2016-06-10 | 2016-06-14 | 1032 | 2016-01-28 | 2016-02-11 | 0d | 73d | 0d |  | 104h | 100% | 13 روز | 13 روز | 10 |  |
| 1035 | 1.2.9.13.2 | تجهیزات آتش نشانی |  | 4d | 2016-06-10 | 2016-06-13 | 1034SS |  |  |  | 79d |  |  |  |  |  |  |  |  |
| 1036 | 1.2.9.13.3 | نصب رادیاتور |  | 7d | 2016-06-10 | 2016-06-16 | 1034SS | 2016-02-13 | 2016-02-23 | 0d | 73d | 0d |  | 80h | 0% | 10 روز | 10 روز |  |  |
| 1037 | 1.2.9.13.4 | نصب دریچه های هوا و کولر |  | 3d | 2016-06-17 | 2016-06-19 | 1036 | 2016-02-24 | 2016-04-03 | 0d | 73d |  |  | 176h | 0% | 22 روز | 22 روز | 12 |  |
| 1038 | 1.2.10 | **ساختمان سوله انبار 2** |  | 377d | 2015-07-01 | 2016-07-11 |  | 2015-05-20 | 2016-10-01 | 0d | 51d |  |  | 1598.5h | 37% | 349 روز | 417 روز | 296 | 296 |
| 1039 | 1.2.10.1 | ابلاغ نقشه های فصل مشترک |  | 1d | 2015-07-01 | 2015-07-01 |  | 2015-09-19 | 2015-09-19 | 0d | 51d | 0d | start no earlier than 2015-07-01 | 7.5h | 100% | 1 روز | 1 روز |  |  |
| 1040 | 1.2.10.2 | **آماده سازی زمین** |  | 33d | 2015-07-28 | 2015-08-29 |  | 2015-06-29 | 2015-08-05 | 33d | 51d |  |  | 87h | 100% |  |  |  |  |
| 1041 | 1.2.10.2.1 | نقشه برداري |  | 1d | 2015-07-28 | 2015-07-28 | 1039FS+26d | 2015-06-29 | 2015-06-29 | 1d | 51d | 0d |  | 8h | 100% |  |  |  |  |
| 1042 | 1.2.10.2.2 | پياده كردن كروكي ساختمان |  | 1d | 2015-07-29 | 2015-07-29 | 1041 | 2015-06-30 | 2015-06-30 | 1d | 51d | 0d |  | 8h | 100% |  |  |  |  |
| 1043 | 1.2.10.2.3 | تهیه فصل مشترک (برداشت از خاک های دپو شده) و حمل خاکها |  | 3d | 2015-07-30 | 2015-08-15 | 1042 | 2015-07-01 | 2015-07-20 | 3d | 51d | 0d |  | 7.5h | 100% |  |  |  |  |
| 1044 | 1.2.10.2.4 | اجرای عملیات بنایی با سنگ (بدلیل پایین بودن سطح خاکبرداری) |  | 7d | 2015-08-16 | 2015-08-22 | 1043 | 2015-07-21 | 2015-07-28 | 7d | 51d | 0d |  | 7.5h | 100% |  |  |  |  |
| 1045 | 1.2.10.2.5 | پی کنی |  | 7d | 2015-08-23 | 2015-08-29 | 1044 | 2015-07-29 | 2015-08-05 | 7d | 368d |  |  | 56h | 100% |  |  |  |  |
| 1046 | 1.2.10.3 | **اجرای فونداسیون** |  | 48d | 2015-08-23 | 2015-10-09 |  |  |  |  | 51d |  |  |  |  |  |  |  |  |
| 1047 | 1.2.10.3.1 | پیاده سازی ، رگلاژ و تسطیح |  | 10d | 2015-08-23 | 2015-09-01 | 1044 |  |  |  | 51d | 0d |  |  |  |  |  |  |  |
| 1048 | 1.2.10.3.2 | بتن مگر |  | 5d | 2015-09-02 | 2015-09-06 | 1047 |  |  |  | 51d | 0d |  |  |  |  |  |  |  |
| 1049 | 1.2.10.3.3 | آرماتور بندی فونداسیون و نصب صفحه ستون ها |  | 15d | 2015-09-07 | 2015-09-21 | 1048 |  |  |  | 51d | 0d |  |  |  |  |  |  |  |
| 1050 | 1.2.10.3.4 | قالب بندی |  | 7d | 2015-09-22 | 2015-09-28 | 1049 |  |  |  | 51d | 0d |  |  |  |  |  |  |  |
| 1051 | 1.2.10.3.5 | بتن ریزی |  | 1d | 2015-09-29 | 2015-09-29 | 1050 |  |  |  | 51d | 0d |  |  |  |  |  |  |  |
| 1052 | 1.2.10.3.6 | قلوه ریزی بین چشمه های فونداسیون |  | 10d | 2015-09-30 | 2015-10-09 | 1051 |  |  |  | 51d | 0d |  |  |  |  |  |  |  |
| 1053 | 1.2.10.4 | **اجرای اسکلت فلزی** |  | 146d | 2015-10-10 | 2016-03-03 |  | 2015-05-20 | 2016-04-07 | 0d | 51d |  |  | 896h | 96% | 161 روز | 266 روز | 120 |  |
| 1054 | 1.2.10.4.1 | ساخت و مونتاژ ستون ها و رفترها (قاب اصلی ) |  | 60d | 2015-10-10 | 2015-12-08 | 1052 | 2015-09-20 | 2015-10-03 | 0d | 51d | 0d |  | 96h | 100% | 12 روز | 12 روز | 10 |  |
| 1055 | 1.2.10.4.2 | ساخت و مونتاژ والپست ها و تیر ریزی داخلی وبادبند ها |  | 15d | 2016-01-28 | 2016-02-11 | 1054FS+50d | 2015-09-20 | 2016-01-02 | 0d | 51d | 0d |  | 760h | 100% | 90 روز | 90 روز | 120 |  |
| 1056 | 1.2.10.4.3 | نصب قاب های اصلی سوله | milestone | 7d | 2016-02-12 | 2016-02-18 | 1055 | 2015-10-04 | 2015-10-08 | 0d | 51d | 0d |  | 40h | 100% | 5 روز | 5 روز |  |  |
| 1057 | 1.2.10.4.4 | نصب والپست ها و ستون های میانی |  | 7d | 2016-02-19 | 2016-02-25 | 1056 | 2015-10-10 | 2015-10-15 | 0d | 51d | 0d |  |  | 100% | 6 روز | 6 روز |  |  |
| 1058 | 1.2.10.4.5 | نصب بادبند ها |  | 7d | 2016-02-26 | 2016-03-03 | 1057 |  |  |  | 51d | 0d |  |  |  |  |  |  |  |

Notes:
- 1043: تاخی تا تاری 4/30 بابت تعیی تکلی و صورتجلسه جهت حمل خاک های دپو شده

| ID | WBS | Task | Duration | Start | Finish | Predecessors | Baseline start | Baseline finish | Baseline duration | Total slack | Free slack | Constraint | Work | Text1 | Text4 | Text5 |
| --- | --- | --- | --- | --- | --- | --- | --- | --- | --- | --- | --- | --- | --- | --- | --- | --- |
| 1059 | 1.2.10.5 | **اجرای سقف سوله (ورق کرکره ای و پشم شیشه )** | 10d | 2016-03-04 | 2016-03-13 |  |  |  |  | 171d |  |  |  |  |  |  |
| 1060 | 1.2.10.5.1 | اجرای تور مرغی | 2d | 2016-03-04 | 2016-03-05 | 1058 |  |  |  | 171d | 0d |  |  |  |  |  |
| 1061 | 1.2.10.5.2 | اجرای پشم شیشه | 2d | 2016-03-06 | 2016-03-07 | 1060 |  |  |  | 171d | 0d |  |  |  |  |  |
| 1062 | 1.2.10.5.3 | اجرای ورق کرکره ای | 4d | 2016-03-08 | 2016-03-11 | 1061 |  |  |  | 171d | 0d |  |  |  |  |  |
| 1063 | 1.2.10.5.4 | اجرای آبراه باران | 2d | 2016-03-12 | 2016-03-13 | 1062 |  |  |  | 171d |  |  |  |  |  |  |
| 1064 | 1.2.10.6 | **سفت کاری** | 29d | 2016-03-04 | 2016-04-01 |  | 2015-12-27 | 2016-06-22 | 0d | 51d |  |  | 176h | 48% | 142 روز | 142 روز |
| 1065 | 1.2.10.6.1 | کرسی چینی و ایزوگام | 5d | 2016-03-04 | 2016-03-08 | 1058 |  |  |  | 51d | 0d |  |  |  |  |  |
| 1066 | 1.2.10.6.2 | اجرای بلوکاژ (قلوه ریزی و شن نقلی ) | 3d | 2016-03-09 | 2016-03-11 | 1065 |  |  |  | 51d | 0d |  |  |  |  |  |
| 1067 | 1.2.10.6.3 | اجرای دیوارهای پیرامونی | 4d | 2016-03-12 | 2016-03-15 | 1066 |  |  |  | 51d | 0d |  |  |  |  |  |
| 1068 | 1.2.10.6.4 | ساخت و نصب نعل درگاه های پیرامونی | 10d | 2016-03-16 | 2016-03-25 | 1067 | 2015-12-27 | 2016-01-05 | 0d | 51d | 0d |  | 72h | 100% | 9 روز | 9 روز |
| 1069 | 1.2.10.6.5 | اجرای دیوار جداکننده داخلی | 2d | 2016-03-16 | 2016-03-17 | 1068SS | 2015-12-27 | 2016-01-05 | 0d | 51d | 0d |  | 104h | 69% | 9 روز | 9 روز |
| 1070 | 1.2.10.6.6 | ساخت و نصب نعل درگاه های داخلی | 5d | 2016-03-18 | 2016-03-22 | 1069 |  |  |  | 51d | 0d |  |  |  |  |  |
| 1071 | 1.2.10.6.7 | اجرای گچ و خاک دیوارها | 10d | 2016-03-23 | 2016-04-01 | 1070 |  |  |  | 51d | 0d |  |  |  |  |  |
| 1072 | 1.2.10.7 | **اجرای نمای بیرونی** | 82d | 2016-03-23 | 2016-06-12 |  |  |  |  | 80d |  |  |  |  |  |  |
| 1073 | 1.2.10.7.1 | اجرای سنگ پلاک نما به همراه فتیله | 7d | 2016-03-23 | 2016-03-29 | 1070 |  |  |  | 80d | 0d | start no earlier than 2016-01-21 |  |  |  |  |
| 1074 | 1.2.10.7.2 | اجرای سنگ باکس تیر ها و ستون ها | 45d | 2016-03-30 | 2016-05-13 | 1073 |  |  |  | 80d | 0d |  |  |  |  |  |
| 1075 | 1.2.10.7.3 | اجرای سنگ پیش آمدگی ها | 30d | 2016-05-14 | 2016-06-12 | 1074 |  |  |  | 80d |  |  |  |  |  |  |
| 1076 | 1.2.10.7.4 | اجرای آستر سیمان سیاه دیوار جهت زیر سازی نمای شسته | 40d | 2016-03-23 | 2016-05-01 | 1073SS |  |  |  | 82d | 0d |  |  |  |  |  |
| 1077 | 1.2.10.7.5 | اجرای نمای شسته | 60d | 2016-04-02 | 2016-05-31 | 1076SS+10d |  |  |  | 82d | 0d |  |  |  |  |  |
| 1078 | 1.2.10.7.6 | اجرای درپوش بتنی جانپناه و کف پنجره ها | 10d | 2016-06-01 | 2016-06-10 | 1077 |  |  |  | 82d |  |  |  |  |  |  |
| 1079 | 1.2.10.8 | **تاسیسات مکانیکی ( مرحله اول )** | 60d | 2016-04-02 | 2016-05-31 |  |  |  |  | 51d |  |  |  |  |  |  |
| 1080 | 1.2.10.8.1 | سوراخکاری و شیارزنی و کنده کاری داکت | 10d | 2016-04-02 | 2016-04-11 | 1071 |  |  |  | 51d | 0d | start no earlier than 2016-01-21 |  |  |  |  |
| 1081 | 1.2.10.8.2 | کانال کنی تاسیسات | 5d | 2016-04-02 | 2016-04-06 | 1080SS |  |  |  | 51d | 0d |  |  |  |  |  |
| 1082 | 1.2.10.8.3 | لوله کشی پلی اتیلن فاضلاب و آب باران | 20d | 2016-04-07 | 2016-04-26 | 1081 |  |  |  | 51d | 0d |  |  |  |  |  |
| 1083 | 1.2.10.8.4 | ساپورتهای لوله کشی تاسیسات | 5d | 2016-04-07 | 2016-04-11 | 1082SS |  |  |  | 127d | 0d |  |  |  |  |  |
| 1084 | 1.2.10.8.5 | لوله کشی گالوانیزه آب سرد و گرم | 15d | 2016-04-12 | 2016-04-26 | 1083 |  |  |  | 127d |  |  |  |  |  |  |
| 1085 | 1.2.10.8.6 | لوله کشی لوله های گرمایشی و پنج لایه | 25d | 2016-04-27 | 2016-05-21 | 1082 |  |  |  | 97d | 0d |  |  |  |  |  |
| 1086 | 1.2.10.8.7 | اجرای ساپورتهای کانال کولر | 5d | 2016-04-27 | 2016-05-01 | 1082 |  |  |  | 51d | 0d |  |  |  |  |  |
| 1087 | 1.2.10.8.8 | اجرای کانال کولر | 30d | 2016-05-02 | 2016-05-31 | 1086 |  |  |  | 51d | 0d |  |  |  |  |  |
| 1088 | 1.2.10.8.9 | اجرای کانال اگزاست | 20d | 2016-05-02 | 2016-05-21 | 1087SS |  |  |  | 51d | 0d |  |  |  |  |  |
| 1089 | 1.2.10.8.10 | عایق پشم شیشه و تست | 5d | 2016-05-22 | 2016-05-26 | 1085 |  |  |  | 97d |  |  |  |  |  |  |
| 1090 | 1.2.10.8.11 | اجرای لوله هایPVC | 2d | 2016-04-07 | 2016-04-08 | 1082SS |  |  |  | 145d |  |  |  |  |  |  |

| ID | WBS | Task | Duration | Start | Finish | Predecessors | Total slack | Free slack |
| --- | --- | --- | --- | --- | --- | --- | --- | --- |
| 1091 | 1.2.10.9 | **تاسیسات الکتریکی ( مرحله اول )** | 35d | 2016-04-02 | 2016-05-06 |  | 117d |  |
| 1092 | 1.2.10.9.1 | شیارزنی | 10d | 2016-04-02 | 2016-04-11 | 1080SS | 127d | 0d |
| 1093 | 1.2.10.9.2 | اجرای لوله های PVC . PG13/5 | 15d | 2016-04-12 | 2016-04-26 | 1092 | 127d | 0d |
| 1094 | 1.2.10.9.3 | اجرای لوله های PVC . PG16-42 | 15d | 2016-04-12 | 2016-04-26 | 1093SS | 127d | 0d |
| 1095 | 1.2.10.9.4 | تهیه ساخت و سفارش تابلو برق | 10d | 2016-04-02 | 2016-04-11 | 1092SS | 141d | 0d |
| 1096 | 1.2.10.9.5 | غلاف گزاری | 3d | 2016-04-12 | 2016-04-14 | 1094SS | 139d |  |
| 1097 | 1.2.10.9.6 | سینی کابل | 5d | 2016-05-02 | 2016-05-06 | 1088SS | 117d |  |
| 1098 | 1.2.10.9.7 | نصب تابلو | 1d | 2016-04-12 | 2016-04-12 | 1095 | 141d |  |
| 1099 | 1.2.10.10 | **نازک کاری** | 36d | 2016-05-02 | 2016-06-06 |  | 51d |  |
| 1100 | 1.2.10.10.1 | اجرای کرم بندی و شیب بندی سرویسها | 4d | 2016-05-02 | 2016-05-05 | 1088SS | 51d | 0d |
| 1101 | 1.2.10.10.2 | اجرای عایق رطوبتی | 2d | 2016-05-06 | 2016-05-07 | 1100 | 51d | 0d |
| 1102 | 1.2.10.10.3 | اجرای سیمان محافظ روی عایق | 2d | 2016-05-08 | 2016-05-09 | 1101 | 114d |  |
| 1103 | 1.2.10.10.4 | چیدن دیوارهای داکت | 2d | 2016-05-02 | 2016-05-03 | 1100SS | 120d |  |
| 1104 | 1.2.10.10.5 | نصب چارچوبهای در و پنجره | 5d | 2016-05-02 | 2016-05-06 | 1100SS | 117d |  |
| 1105 | 1.2.10.10.6 | اجرای قرنیز و سنگ و پلاک فضای داخلی دیوارها | 10d | 2016-05-08 | 2016-05-17 | 1101 | 51d | 0d |
| 1106 | 1.2.10.10.7 | اجرای گچ سفید دیوارها | 15d | 2016-05-18 | 2016-06-01 | 1105 | 91d |  |
| 1107 | 1.2.10.10.8 | اجرای کاشی دیوار سرویسها | 20d | 2016-05-08 | 2016-05-27 | 1101 | 91d | 0d |
| 1108 | 1.2.10.10.9 | اجرای سرامیک کف | 5d | 2016-05-28 | 2016-06-01 | 1107 | 91d |  |
| 1109 | 1.2.10.10.10 | اجرای سنگ گرانیت و چینی و موزائیک کف | 10d | 2016-05-18 | 2016-05-27 | 1105 | 51d | 0d |
| 1110 | 1.2.10.10.11 | اجرای سقف کاذب ( کناف فضای داخلی ) | 10d | 2016-05-28 | 2016-06-06 | 1109 | 51d | 0d |
| 1111 | 1.2.10.10.12 | اجرای سقف کاذب ( سرویس بهداشتی ) | 4d | 2016-05-28 | 2016-05-31 | 1107 | 92d |  |
| 1112 | 1.2.10.11 | **نصبیات و تکمیلی نازک کاری** | 16d | 2016-05-28 | 2016-06-12 |  | 80d |  |
| 1113 | 1.2.10.11.1 | نصب در و پنجره های جوبی ، فولادی و UPVC | 3d | 2016-05-28 | 2016-05-30 | 1110SS | 80d | 0d |
| 1114 | 1.2.10.11.2 | نصب شیشه ها | 3d | 2016-05-31 | 2016-06-02 | 1113 | 80d | 0d |
| 1115 | 1.2.10.11.3 | رنگ آمیزی سقف و دیوار | 10d | 2016-06-03 | 2016-06-12 | 1114 | 80d |  |

| ID | WBS | Task | Duration | Start | Finish | Predecessors | Baseline start | Baseline finish | Baseline duration | Total slack | Free slack | Constraint | Work | Text1 | Text4 | Text5 | Text22 | Text20 |
| --- | --- | --- | --- | --- | --- | --- | --- | --- | --- | --- | --- | --- | --- | --- | --- | --- | --- | --- |
| 1116 | 1.2.10.12 | **تاسیسات الکتریکی ( مرحله دوم )** | 41d | 2016-05-28 | 2016-07-07 |  | 2016-01-05 | 2016-08-04 | 0d | 51d |  |  | 72h | 7% | 170 | 170 | 73 |  |
| 1117 | 1.2.10.12.1 | اجرای سیم کشی و کابل کشی ساختمان | 20d | 2016-05-28 | 2016-06-16 | 1110SS |  |  |  | 51d | 0d |  |  |  |  |  |  |  |
| 1118 | 1.2.10.12.2 | کابل کشی مخابرات و تجهیزات مربوطه | 5d | 2016-06-17 | 2016-06-21 | 1117 |  |  |  | 66d | 0d |  |  |  |  |  |  |  |
| 1119 | 1.2.10.12.3 | اجرا و نصب تابلو برق و جریان ضعیف | 5d | 2016-06-22 | 2016-06-26 | 1118 |  |  |  | 66d |  |  |  |  |  |  |  |  |
| 1120 | 1.2.10.12.4 | کلید و پریز | 5d | 2016-06-17 | 2016-06-21 | 1117 |  |  |  | 51d | 0d |  |  |  |  |  |  |  |
| 1121 | 1.2.10.12.5 | چراغ های ایندور | 5d | 2016-06-22 | 2016-06-26 | 1120 |  |  |  | 51d | 0d |  |  |  |  |  |  |  |
| 1122 | 1.2.10.12.6 | سیستم اعلام حریق | 5d | 2016-06-27 | 2016-07-01 | 1121 |  |  |  | 51d | 0d |  |  |  |  |  |  |  |
| 1123 | 1.2.10.12.7 | سیستم آنتن مرکزی | 3d | 2016-07-02 | 2016-07-04 | 1122 |  |  |  | 55d | 0d |  |  |  |  |  |  |  |
| 1124 | 1.2.10.12.8 | ارت سازی | 3d | 2016-07-05 | 2016-07-07 | 1123 | 2016-01-05 | 2016-01-14 | 0d | 55d |  |  | 72h | 60% | 9 روز | 9 روز | 10 |  |
| 1125 | 1.2.10.13 | **تاسیسات مکانیکی ( مرحله دوم )** | 10d | 2016-07-02 | 2016-07-11 |  |  |  |  | 51d |  |  | 360h |  |  |  |  |  |
| 1126 | 1.2.10.13.1 | شیر آلات بهداشتی | 5d | 2016-07-02 | 2016-07-06 | 1122 | 2016-01-28 | 2016-02-11 | 0d | 51d | 0d |  | 104h | 100% | 13 روز | 13 روز | 10 |  |
| 1127 | 1.2.10.13.2 | تجهیزات آتش نشانی | 4d | 2016-07-02 | 2016-07-05 | 1126SS |  |  |  | 57d |  |  |  |  |  |  |  |  |
| 1128 | 1.2.10.13.3 | نصب رادیاتور | 10d | 2016-07-02 | 2016-07-11 | 1126SS | 2016-02-13 | 2016-02-23 | 0d | 51d | 0d |  | 80h | 0% | 10 روز | 10 روز |  |  |
| 1129 | 1.2.10.13.4 | نصب دریچه های هوا و کولر | 3d | 2016-07-02 | 2016-07-04 | 1128SS | 2016-02-24 | 2016-04-03 | 0d | 58d |  |  | 176h | 0% | 22 روز | 22 روز | 12 |  |
| 1130 | 1.2.11 | **ساختمان سوله تعمیرگاه 1** | 342d | 2015-07-01 | 2016-06-06 |  | 2015-05-20 | 2016-10-01 | 0d | 86d |  |  | 1511.5h | 37% | 349 روز | 417 روز | 296 | 296 |
| 1131 | 1.2.11.1 | ابلاغ نقشه های فصل مشترک | 1d | 2015-07-01 | 2015-07-01 |  | 2015-09-19 | 2015-09-19 | 0d | 86d | 0d | start no earlier than 2015-07-01 | 7.5h | 100% | 1 روز | 1 روز |  |  |
| 1132 | 1.2.11.2 | سنگ چینی به ارتفاع 2.25 متر | 75d | 2015-07-02 | 2015-09-14 | 1131 |  |  |  | 86d | 0d |  |  |  |  |  |  |  |
| 1133 | 1.2.11.3 | **اجرای فونداسیون** | 48d | 2015-09-15 | 2015-11-01 |  |  |  |  | 86d |  |  |  |  |  |  |  |  |
| 1134 | 1.2.11.3.1 | پیاده سازی ، رگلاژ و تسطیح | 10d | 2015-09-15 | 2015-09-24 | 1132 |  |  |  | 86d | 0d |  |  |  |  |  |  |  |
| 1135 | 1.2.11.3.2 | بتن مگر | 7d | 2015-09-25 | 2015-10-01 | 1134 |  |  |  | 86d | 0d |  |  |  |  |  |  |  |
| 1136 | 1.2.11.3.3 | آرماتور بندی فونداسیون و نصب صفحه ستون ها | 12d | 2015-10-02 | 2015-10-13 | 1135 |  |  |  | 86d | 0d |  |  |  |  |  |  |  |
| 1137 | 1.2.11.3.4 | قالب بندی | 8d | 2015-10-14 | 2015-10-21 | 1136 |  |  |  | 86d | 0d |  |  |  |  |  |  |  |
| 1138 | 1.2.11.3.5 | بتن ریزی | 1d | 2015-10-22 | 2015-10-22 | 1137 |  |  |  | 86d | 0d |  |  |  |  |  |  |  |
| 1139 | 1.2.11.3.6 | قلوه ریزی بین چشمه های فونداسیون | 10d | 2015-10-23 | 2015-11-01 | 1138 |  |  |  | 86d | 0d |  |  |  |  |  |  |  |

| ID | WBS | Task | Type | Duration | Start | Finish | Predecessors | Baseline start | Baseline finish | Baseline duration | Total slack | Free slack | Work | Text1 | Text4 | Text5 | Text22 |
| --- | --- | --- | --- | --- | --- | --- | --- | --- | --- | --- | --- | --- | --- | --- | --- | --- | --- |
| 1140 | 1.2.11.4 | **اجرای اسکلت فلزی** |  | 77d | 2015-11-02 | 2016-01-17 |  | 2015-05-20 | 2016-04-07 | 0d | 86d |  | 896h | 96% | 161 روز | 266 روز | 120 |
| 1141 | 1.2.11.4.1 | ساخت و مونتاژ ستون ها و رفترها (قاب اصلی ) |  | 45d | 2015-11-02 | 2015-12-16 | 1139 | 2015-09-20 | 2015-10-03 | 0d | 86d | 0d | 96h | 100% | 12 روز | 12 روز | 10 |
| 1142 | 1.2.11.4.2 | ساخت و مونتاژ والپست ها و تیر ریزی داخلی وبادبند ها |  | 14d | 2015-12-17 | 2015-12-30 | 1141 | 2015-09-20 | 2016-01-02 | 0d | 86d | 0d | 760h | 100% | 90 روز | 90 روز | 120 |
| 1143 | 1.2.11.4.3 | نصب قاب های اصلی سوله | milestone | 6d | 2015-12-31 | 2016-01-05 | 1142 | 2015-10-04 | 2015-10-08 | 0d | 86d | 0d | 40h | 100% | 5 روز | 5 روز |  |
| 1144 | 1.2.11.4.4 | نصب والپست ها و ستون های میانی |  | 6d | 2016-01-06 | 2016-01-11 | 1143 | 2015-10-10 | 2015-10-15 | 0d | 86d | 0d |  | 100% | 6 روز | 6 روز |  |
| 1145 | 1.2.11.4.5 | نصب بادبند ها |  | 6d | 2016-01-12 | 2016-01-17 | 1144 |  |  |  | 86d | 0d |  |  |  |  |  |
| 1146 | 1.2.11.5 | **اجرای سقف سوله** |  | 9d | 2016-01-18 | 2016-01-26 |  |  |  |  | 210d |  |  |  |  |  |  |
| 1147 | 1.2.11.5.1 | اجرای تور مرغی |  | 2d | 2016-01-18 | 2016-01-19 | 1145 |  |  |  | 210d | 0d |  |  |  |  |  |
| 1148 | 1.2.11.5.2 | اجرای پشم شیشه |  | 2d | 2016-01-20 | 2016-01-21 | 1147 |  |  |  | 210d | 0d |  |  |  |  |  |
| 1149 | 1.2.11.5.3 | اجرای ورق کرکره ای |  | 3d | 2016-01-22 | 2016-01-24 | 1148 |  |  |  | 210d | 0d |  |  |  |  |  |
| 1150 | 1.2.11.5.4 | اجرای آبراه باران |  | 2d | 2016-01-25 | 2016-01-26 | 1149 |  |  |  | 210d | 0d |  |  |  |  |  |
| 1151 | 1.2.11.6 | **اجرای سقف نیم طبقه سوله** |  | 8d | 2016-01-27 | 2016-02-03 |  |  |  |  | 210d |  |  |  |  |  |  |
| 1152 | 1.2.11.6.1 | ساخت و مونتاژ تیرهای حمال و تودلی |  | 4d | 2016-01-27 | 2016-01-30 | 1150 |  |  |  | 210d | 0d |  |  |  |  |  |
| 1153 | 1.2.11.6.2 | نصب تیر های حمال و تودلی سقف همکف |  | 1d | 2016-01-31 | 2016-01-31 | 1152 |  |  |  | 210d | 0d |  |  |  |  |  |
| 1154 | 1.2.11.6.3 | اجرای ورق متال نیم طبقه و راه پله |  | 1d | 2016-02-01 | 2016-02-01 | 1153 |  |  |  | 210d | 0d |  |  |  |  |  |
| 1155 | 1.2.11.6.4 | اجرای جوشکاری گل میخ نیم طبقه و راه پله |  | 1d | 2016-02-02 | 2016-02-02 | 1154 |  |  |  | 210d | 0d |  |  |  |  |  |
| 1156 | 1.2.11.6.5 | بتن ریزی |  | 1d | 2016-02-03 | 2016-02-03 | 1155 |  |  |  | 210d |  |  |  |  |  |  |
| 1157 | 1.2.11.7 | **سفت کاری** |  | 44d | 2016-01-18 | 2016-03-01 |  | 2015-12-27 | 2016-06-22 | 0d | 86d |  | 176h | 48% | 142 روز | 142 روز |  |
| 1158 | 1.2.11.7.1 | کرسی چینی و ایزوگام |  | 5d | 2016-01-18 | 2016-01-22 | 1145 |  |  |  | 86d | 0d |  |  |  |  |  |
| 1159 | 1.2.11.7.2 | اجرای بلوکاژ (قلوه ریزی و شن نقلی ) |  | 3d | 2016-01-23 | 2016-01-25 | 1158 |  |  |  | 86d | 0d |  |  |  |  |  |
| 1160 | 1.2.11.7.3 | اجرای دیوارهای پیرامونی |  | 5d | 2016-01-26 | 2016-01-30 | 1159 |  |  |  | 86d | 0d |  |  |  |  |  |
| 1161 | 1.2.11.7.4 | ساخت و نصب نعل درگاه های پیرامونی |  | 1d | 2016-01-31 | 2016-01-31 | 1160 | 2015-12-27 | 2016-01-05 | 0d | 86d | 0d | 72h | 100% | 9 روز | 9 روز |  |
| 1162 | 1.2.11.7.5 | اجرای دیوار جداکننده داخلی |  | 10d | 2016-01-31 | 2016-02-09 | 1161SS | 2015-12-27 | 2016-01-05 | 0d | 86d | 0d | 104h | 69% | 9 روز | 9 روز |  |
| 1163 | 1.2.11.7.6 | ساخت و نصب نعل درگاه های داخلی |  | 1d | 2016-02-10 | 2016-02-10 | 1162 |  |  |  | 86d | 0d |  |  |  |  |  |
| 1164 | 1.2.11.7.7 | اجرای گچ و خاک دیوارها |  | 10d | 2016-02-21 | 2016-03-01 | 1163FS+10d |  |  |  | 86d | 0d |  |  |  |  |  |

| ID | WBS | Task | Duration | Start | Finish | Predecessors | Total slack | Free slack | Constraint |
| --- | --- | --- | --- | --- | --- | --- | --- | --- | --- |
| 1165 | 1.2.11.8 | **اجرای نمای بیرونی** | 80d | 2016-02-11 | 2016-04-30 |  | 123d |  |  |
| 1166 | 1.2.11.8.1 | اجرای سنگ پلاک نما به همراه فتیله | 7d | 2016-02-11 | 2016-02-17 | 1163 | 123d | 0d | start no earlier than 2016-01-21 |
| 1167 | 1.2.11.8.2 | اجرای سنگ پیش آمدگی ها | 20d | 2016-02-18 | 2016-03-08 | 1166 | 176d |  |  |
| 1168 | 1.2.11.8.3 | اجرای آستر سیمان سیاه دیوار جهت زیر سازی نمای شسته | 40d | 2016-02-11 | 2016-03-21 | 1166SS | 123d | 0d |  |
| 1169 | 1.2.11.8.4 | اجرای نمای شسته | 60d | 2016-02-21 | 2016-04-20 | 1168SS+10d | 123d | 0d |  |
| 1170 | 1.2.11.8.5 | اجرای درپوش بتنی جانپناه و کف پنجره ها | 10d | 2016-04-21 | 2016-04-30 | 1169 | 123d |  |  |
| 1171 | 1.2.11.9 | **تاسیسات مکانیکی ( مرحله اول )** | 45d | 2016-03-02 | 2016-04-15 |  | 86d |  |  |
| 1172 | 1.2.11.9.1 | سوراخکاری و شیارزنی و کنده کاری داکت | 3d | 2016-03-02 | 2016-03-04 | 1164 | 86d | 0d | start no earlier than 2016-01-21 |
| 1173 | 1.2.11.9.2 | کانال کنی تاسیسات | 3d | 2016-03-02 | 2016-03-04 | 1172SS | 86d | 0d |  |
| 1174 | 1.2.11.9.3 | لوله کشی پلی اتیلن فاضلاب و آب باران | 20d | 2016-03-05 | 2016-03-24 | 1173 | 86d | 0d |  |
| 1175 | 1.2.11.9.4 | ساپورتهای لوله کشی تاسیسات | 3d | 2016-03-05 | 2016-03-07 | 1174SS | 167d | 0d |  |
| 1176 | 1.2.11.9.5 | لوله کشی گالوانیزه آب سرد و گرم | 10d | 2016-03-08 | 2016-03-17 | 1175 | 167d |  |  |
| 1177 | 1.2.11.9.6 | لوله کشی لوله های گرمایشی و پنج لایه | 20d | 2016-03-25 | 2016-04-13 | 1174 | 138d | 0d |  |
| 1178 | 1.2.11.9.7 | اجرای ساپورتهای کانال کولر | 3d | 2016-03-25 | 2016-03-27 | 1174 | 86d | 0d |  |
| 1179 | 1.2.11.9.8 | اجرای کانال کولر | 15d | 2016-03-28 | 2016-04-11 | 1178 | 86d | 0d |  |
| 1180 | 1.2.11.9.9 | اجرای کانال اگزاست | 15d | 2016-03-28 | 2016-04-11 | 1179SS | 86d | 0d |  |
| 1181 | 1.2.11.9.10 | عایق پشم شیشه و تست | 2d | 2016-04-14 | 2016-04-15 | 1177 | 138d |  |  |
| 1182 | 1.2.11.9.11 | اجرای لوله هایPVC | 1d | 2016-03-05 | 2016-03-05 | 1174SS | 179d |  |  |
| 1183 | 1.2.11.10 | **تاسیسات الکتریکی ( مرحله اول )** | 31d | 2016-03-02 | 2016-04-01 |  | 152d |  |  |
| 1184 | 1.2.11.10.1 | شیارزنی | 3d | 2016-03-02 | 2016-03-04 | 1172SS | 165d | 0d |  |
| 1185 | 1.2.11.10.2 | اجرای لوله های PVC . PG13/5 | 15d | 2016-03-05 | 2016-03-19 | 1184 | 165d | 0d |  |
| 1186 | 1.2.11.10.3 | اجرای لوله های PVC . PG16-42 | 15d | 2016-03-05 | 2016-03-19 | 1185SS | 165d | 0d |  |
| 1187 | 1.2.11.10.4 | تهیه ساخت و سفارش تابلو برق | 10d | 2016-03-02 | 2016-03-11 | 1184SS | 172d | 0d |  |
| 1188 | 1.2.11.10.5 | غلاف گزاری | 3d | 2016-03-05 | 2016-03-07 | 1186SS | 177d |  |  |
| 1189 | 1.2.11.10.6 | سینی کابل | 5d | 2016-03-28 | 2016-04-01 | 1180SS | 152d |  |  |
| 1190 | 1.2.11.10.7 | نصب تابلو | 1d | 2016-03-12 | 2016-03-12 | 1187 | 172d |  |  |

| ID | WBS | Task | Duration | Start | Finish | Predecessors | Baseline start | Baseline finish | Baseline duration | Total slack | Free slack | Work | Text1 | Text4 | Text5 | Text22 |
| --- | --- | --- | --- | --- | --- | --- | --- | --- | --- | --- | --- | --- | --- | --- | --- | --- |
| 1191 | 1.2.11.11 | **نازک کاری** | 42d | 2016-03-28 | 2016-05-08 |  |  |  |  | 86d |  |  |  |  |  |  |
| 1192 | 1.2.11.11.1 | اجرای کرم بندی و شیب بندی سرویسها | 4d | 2016-03-28 | 2016-03-31 | 1180SS |  |  |  | 86d | 0d |  |  |  |  |  |
| 1193 | 1.2.11.11.2 | اجرای عایق رطوبتی | 2d | 2016-04-01 | 2016-04-02 | 1192 |  |  |  | 86d | 0d |  |  |  |  |  |
| 1194 | 1.2.11.11.3 | اجرای سیمان محافظ روی عایق | 2d | 2016-04-03 | 2016-04-04 | 1193 |  |  |  | 149d |  |  |  |  |  |  |
| 1195 | 1.2.11.11.4 | چیدن دیوارهای داکت | 2d | 2016-03-28 | 2016-03-29 | 1192SS |  |  |  | 155d |  |  |  |  |  |  |
| 1196 | 1.2.11.11.5 | نصب چارچوبهای در و پنجره | 5d | 2016-03-28 | 2016-04-01 | 1192SS |  |  |  | 152d |  |  |  |  |  |  |
| 1197 | 1.2.11.11.6 | اجرای قرنیز و سنگ و پلاک فضای داخلی دیوارها | 10d | 2016-04-03 | 2016-04-12 | 1193 |  |  |  | 86d | 0d |  |  |  |  |  |
| 1198 | 1.2.11.11.7 | اجرای گچ سفید دیوارها | 15d | 2016-04-13 | 2016-04-27 | 1197 |  |  |  | 126d |  |  |  |  |  |  |
| 1199 | 1.2.11.11.8 | اجرای کاشی دیوار سرویسها | 20d | 2016-04-03 | 2016-04-22 | 1193 |  |  |  | 126d | 0d |  |  |  |  |  |
| 1200 | 1.2.11.11.9 | اجرای سرامیک کف | 5d | 2016-04-23 | 2016-04-27 | 1199 |  |  |  | 126d |  |  |  |  |  |  |
| 1201 | 1.2.11.11.10 | اجرای سنگ گرانیت و چینی و موزائیک کف | 10d | 2016-04-13 | 2016-04-22 | 1197 |  |  |  | 86d | 0d |  |  |  |  |  |
| 1202 | 1.2.11.11.11 | اجرای سقف کاذب ( کناف فضای داخلی ) | 10d | 2016-04-23 | 2016-05-02 | 1201 |  |  |  | 86d | 0d |  |  |  |  |  |
| 1203 | 1.2.11.11.12 | اجرای سقف کاذب ( سرویس بهداشتی ) | 4d | 2016-04-23 | 2016-04-26 | 1199 |  |  |  | 127d |  |  |  |  |  |  |
| 1204 | 1.2.11.11.13 | **نصبیات و تکمیلی نازک کاری** | 16d | 2016-04-23 | 2016-05-08 |  |  |  |  | 115d |  |  |  |  |  |  |
| 1205 | 1.2.11.11.13.1 | نصب در و پنجره های جوبی ، فولادی و UPVC | 3d | 2016-04-23 | 2016-04-25 | 1202SS |  |  |  | 115d | 0d |  |  |  |  |  |
| 1206 | 1.2.11.11.13.2 | نصب شیشه ها | 3d | 2016-04-26 | 2016-04-28 | 1205 |  |  |  | 115d | 0d |  |  |  |  |  |
| 1207 | 1.2.11.11.13.3 | رنگ آمیزی سقف و دیوار | 10d | 2016-04-29 | 2016-05-08 | 1206 |  |  |  | 115d |  |  |  |  |  |  |
| 1208 | 1.2.11.12 | **تاسیسات الکتریکی ( مرحله دوم )** | 41d | 2016-04-23 | 2016-06-02 |  | 2016-01-05 | 2016-08-04 | 0d | 86d |  | 72h | 7% | 170 | 170 | 73 |
| 1209 | 1.2.11.12.1 | اجرای سیم کشی و کابل کشی ساختمان | 20d | 2016-04-23 | 2016-05-12 | 1202SS |  |  |  | 86d | 0d |  |  |  |  |  |
| 1210 | 1.2.11.12.2 | کابل کشی مخابرات و تجهیزات مربوطه | 5d | 2016-05-13 | 2016-05-17 | 1209 |  |  |  | 101d | 0d |  |  |  |  |  |
| 1211 | 1.2.11.12.3 | اجرا و نصب تابلو برق و جریان ضعیف | 5d | 2016-05-18 | 2016-05-22 | 1210 |  |  |  | 101d |  |  |  |  |  |  |
| 1212 | 1.2.11.12.4 | کلید و پریز | 5d | 2016-05-13 | 2016-05-17 | 1209 |  |  |  | 86d | 0d |  |  |  |  |  |
| 1213 | 1.2.11.12.5 | چراغ های ایندور | 5d | 2016-05-18 | 2016-05-22 | 1212 |  |  |  | 86d | 0d |  |  |  |  |  |
| 1214 | 1.2.11.12.6 | سیستم اعلام حریق | 5d | 2016-05-23 | 2016-05-27 | 1213 |  |  |  | 86d | 0d |  |  |  |  |  |
| 1215 | 1.2.11.12.7 | سیستم آنتن مرکزی | 3d | 2016-05-28 | 2016-05-30 | 1214 |  |  |  | 90d | 0d |  |  |  |  |  |
| 1216 | 1.2.11.12.8 | ارت سازی | 3d | 2016-05-31 | 2016-06-02 | 1215 | 2016-01-05 | 2016-01-14 | 0d | 90d |  | 72h | 60% | 9 روز | 9 روز | 10 |

| ID | WBS | Task | Type | Duration | Start | Finish | Predecessors | Baseline start | Baseline finish | Baseline duration | Total slack | Free slack | Constraint | Work | Text1 | Text4 | Text5 | Text22 | Text20 |
| --- | --- | --- | --- | --- | --- | --- | --- | --- | --- | --- | --- | --- | --- | --- | --- | --- | --- | --- | --- |
| 1217 | 1.2.11.13 | **تاسیسات مکانیکی ( مرحله دوم )** |  | 10d | 2016-05-28 | 2016-06-06 |  |  |  |  | 86d |  |  | 360h |  |  |  |  |  |
| 1218 | 1.2.11.13.1 | شیر آلات بهداشتی |  | 5d | 2016-05-28 | 2016-06-01 | 1214 | 2016-01-28 | 2016-02-11 | 0d | 86d | 0d |  | 104h | 100% | 13 روز | 13 روز | 10 |  |
| 1219 | 1.2.11.13.2 | تجهیزات آتش نشانی |  | 4d | 2016-05-28 | 2016-05-31 | 1218SS |  |  |  | 92d |  |  |  |  |  |  |  |  |
| 1220 | 1.2.11.13.3 | نصب رادیاتور |  | 10d | 2016-05-28 | 2016-06-06 | 1218SS | 2016-02-13 | 2016-02-23 | 0d | 86d | 0d |  | 80h | 0% | 10 روز | 10 روز |  |  |
| 1221 | 1.2.11.13.4 | نصب دریچه های هوا و کولر |  | 3d | 2016-05-28 | 2016-05-30 | 1220SS | 2016-02-24 | 2016-04-03 | 0d | 93d |  |  | 176h | 0% | 22 روز | 22 روز | 12 |  |
| 1222 | 1.2.12 | **ساختمان سوله تعمیرگاه 2** |  | 325d | 2015-07-01 | 2016-05-20 |  | 2015-05-20 | 2016-10-01 | 0d | 103d |  |  | 1511.5h | 37% | 349 روز | 417 روز | 296 | 296 |
| 1223 | 1.2.12.1 | ابلاغ نقشه های فصل مشترک |  | 1d | 2015-07-01 | 2015-07-01 |  | 2015-09-19 | 2015-09-19 | 0d | 103d | 0d | start no earlier than 2015-07-01 | 7.5h | 100% | 1 روز | 1 روز |  |  |
| 1224 | 1.2.12.2 | **اجرای فونداسیون** |  | 31d | 2015-07-02 | 2015-08-01 |  |  |  |  | 103d |  |  |  |  |  |  |  |  |
| 1225 | 1.2.12.2.1 | پیاده سازی ، رگلاژ و تسطیح |  | 5d | 2015-07-02 | 2015-07-06 | 1223 |  |  |  | 103d | 0d |  |  |  |  |  |  |  |
| 1226 | 1.2.12.2.2 | بتن مگر |  | 5d | 2015-07-07 | 2015-07-11 | 1225 |  |  |  | 103d | 0d |  |  |  |  |  |  |  |
| 1227 | 1.2.12.2.3 | آرماتور بندی فونداسیون و نصب صفحه ستون ها |  | 8d | 2015-07-12 | 2015-07-19 | 1226 |  |  |  | 103d | 0d |  |  |  |  |  |  |  |
| 1228 | 1.2.12.2.4 | قالب بندی |  | 5d | 2015-07-20 | 2015-07-24 | 1227 |  |  |  | 103d | 0d |  |  |  |  |  |  |  |
| 1229 | 1.2.12.2.5 | بتن ریزی |  | 1d | 2015-07-25 | 2015-07-25 | 1228 |  |  |  | 103d | 0d |  |  |  |  |  |  |  |
| 1230 | 1.2.12.2.6 | قلوه ریزی بین چشمه های فونداسیون |  | 7d | 2015-07-26 | 2015-08-01 | 1229 |  |  |  | 103d | 0d |  |  |  |  |  |  |  |
| 1231 | 1.2.12.3 | **اجرای اسکلت فلزی** |  | 104d | 2015-08-02 | 2015-11-13 |  | 2015-05-20 | 2016-04-07 | 0d | 103d |  |  | 896h | 96% | 161 روز | 266 روز | 120 |  |
| 1232 | 1.2.12.3.1 | ساخت و مونتاژ ستون ها و رفترها (قاب اصلی ) |  | 65d | 2015-08-02 | 2015-10-05 | 1230 | 2015-09-20 | 2015-10-03 | 0d | 103d | 0d |  | 96h | 100% | 12 روز | 12 روز | 10 |  |
| 1233 | 1.2.12.3.2 | ساخت و مونتاژ والپست ها و تیر ریزی داخلی وبادبند ها |  | 15d | 2015-10-06 | 2015-10-20 | 1232 | 2015-09-20 | 2016-01-02 | 0d | 103d | 0d |  | 760h | 100% | 90 روز | 90 روز | 120 |  |
| 1234 | 1.2.12.3.3 | نصب قاب های اصلی سوله | milestone | 8d | 2015-10-21 | 2015-10-28 | 1233 | 2015-10-04 | 2015-10-08 | 0d | 103d | 0d |  | 40h | 100% | 5 روز | 5 روز |  |  |
| 1235 | 1.2.12.3.4 | نصب والپست ها و ستون های میانی |  | 8d | 2015-10-29 | 2015-11-05 | 1234 | 2015-10-10 | 2015-10-15 | 0d | 103d | 0d |  |  | 100% | 6 روز | 6 روز |  |  |
| 1236 | 1.2.12.3.5 | نصب بادبند ها |  | 8d | 2015-11-06 | 2015-11-13 | 1235 |  |  |  | 103d | 0d |  |  |  |  |  |  |  |
| 1237 | 1.2.12.4 | **اجرای سقف سوله** |  | 9d | 2015-12-15 | 2015-12-23 |  |  |  |  | 244d |  |  |  |  |  |  |  |  |
| 1238 | 1.2.12.4.1 | اجرای تور مرغی |  | 2d | 2015-12-15 | 2015-12-16 | 1236FS+31d |  |  |  | 244d | 0d |  |  |  |  |  |  |  |
| 1239 | 1.2.12.4.2 | اجرای پشم شیشه |  | 2d | 2015-12-17 | 2015-12-18 | 1238 |  |  |  | 244d | 0d |  |  |  |  |  |  |  |
| 1240 | 1.2.12.4.3 | اجرای ورق کرکره ای |  | 3d | 2015-12-19 | 2015-12-21 | 1239 |  |  |  | 244d | 0d |  |  |  |  |  |  |  |
| 1241 | 1.2.12.4.4 | اجرای آبراه باران |  | 2d | 2015-12-22 | 2015-12-23 | 1240 |  |  |  | 244d | 0d |  |  |  |  |  |  |  |

| ID | WBS | Task | Duration | Start | Finish | Predecessors | Baseline start | Baseline finish | Baseline duration | Total slack | Free slack | Constraint | Work | Text1 | Text4 | Text5 |
| --- | --- | --- | --- | --- | --- | --- | --- | --- | --- | --- | --- | --- | --- | --- | --- | --- |
| 1242 | 1.2.12.5 | **اجرای سقف نیم طبقه سوله** | 8d | 2015-12-24 | 2015-12-31 |  |  |  |  | 244d |  |  |  |  |  |  |
| 1243 | 1.2.12.5.1 | ساخت و مونتاژ تیرهای حمال و تودلی | 4d | 2015-12-24 | 2015-12-27 | 1241 |  |  |  | 244d | 0d |  |  |  |  |  |
| 1244 | 1.2.12.5.2 | نصب تیر های حمال و تودلی سقف همکف | 1d | 2015-12-28 | 2015-12-28 | 1243 |  |  |  | 244d | 0d |  |  |  |  |  |
| 1245 | 1.2.12.5.3 | اجرای ورق متال نیم طبقه و راه پله | 1d | 2015-12-29 | 2015-12-29 | 1244 |  |  |  | 244d | 0d |  |  |  |  |  |
| 1246 | 1.2.12.5.4 | اجرای جوشکاری گل میخ نیم طبقه و راه پله | 1d | 2015-12-30 | 2015-12-30 | 1245 |  |  |  | 244d | 0d |  |  |  |  |  |
| 1247 | 1.2.12.5.5 | بتن ریزی | 1d | 2015-12-31 | 2015-12-31 | 1246 |  |  |  | 244d |  |  |  |  |  |  |
| 1248 | 1.2.12.6 | **سفت کاری** | 71d | 2015-11-14 | 2016-01-23 |  | 2015-12-27 | 2016-06-22 | 0d | 103d |  |  | 176h | 48% | 142 روز | 142 روز |
| 1249 | 1.2.12.6.1 | کرسی چینی و ایزوگام | 8d | 2015-11-14 | 2015-11-21 | 1236 |  |  |  | 103d | 0d |  |  |  |  |  |
| 1250 | 1.2.12.6.2 | اجرای بلوکاژ (قلوه ریزی و شن نقلی ) | 8d | 2015-11-22 | 2015-11-29 | 1249 |  |  |  | 103d | 0d |  |  |  |  |  |
| 1251 | 1.2.12.6.3 | اجرای دیوارهای پیرامونی | 12d | 2015-11-30 | 2015-12-11 | 1250 |  |  |  | 103d | 0d |  |  |  |  |  |
| 1252 | 1.2.12.6.4 | ساخت و نصب نعل درگاه های پیرامونی | 3d | 2015-12-12 | 2015-12-14 | 1251 | 2015-12-27 | 2016-01-05 | 0d | 103d | 0d |  | 72h | 100% | 9 روز | 9 روز |
| 1253 | 1.2.12.6.5 | اجرای دیوار جداکننده داخلی | 12d | 2015-12-12 | 2015-12-23 | 1252SS | 2015-12-27 | 2016-01-05 | 0d | 103d | 0d |  | 104h | 69% | 9 روز | 9 روز |
| 1254 | 1.2.12.6.6 | ساخت و نصب نعل درگاه های داخلی | 3d | 2015-12-24 | 2015-12-26 | 1253 |  |  |  | 103d | 0d |  |  |  |  |  |
| 1255 | 1.2.12.6.7 | اجرای گچ و خاک دیوارها | 15d | 2016-01-09 | 2016-01-23 | 1254FS+13d |  |  |  | 103d | 0d |  |  |  |  |  |
| 1256 | 1.2.12.7 | **اجرای نمای بیرونی** | 95d | 2016-01-21 | 2016-04-24 |  |  |  |  | 129d |  |  |  |  |  |  |
| 1257 | 1.2.12.7.1 | اجرای سنگ پلاک نما به همراه فتیله | 10d | 2016-01-21 | 2016-01-30 | 1254 |  |  |  | 129d | 0d | start no earlier than 2016-01-21 |  |  |  |  |
| 1258 | 1.2.12.7.2 | اجرای سنگ پیش آمدگی ها | 25d | 2016-01-31 | 2016-02-24 | 1257 |  |  |  | 189d |  |  |  |  |  |  |
| 1259 | 1.2.12.7.3 | اجرای آستر سیمان سیاه دیوار جهت زیر سازی نمای شسته | 45d | 2016-01-21 | 2016-03-05 | 1257SS |  |  |  | 129d | 0d |  |  |  |  |  |
| 1260 | 1.2.12.7.4 | اجرای نمای شسته | 75d | 2016-01-31 | 2016-04-14 | 1259SS+10d |  |  |  | 129d | 0d |  |  |  |  |  |
| 1261 | 1.2.12.7.5 | اجرای درپوش بتنی جانپناه و کف پنجره ها | 10d | 2016-04-15 | 2016-04-24 | 1260 |  |  |  | 129d |  |  |  |  |  |  |
| 1262 | 1.2.12.8 | **تاسیسات مکانیکی ( مرحله اول )** | 45d | 2016-01-24 | 2016-03-08 |  |  |  |  | 103d |  |  |  |  |  |  |
| 1263 | 1.2.12.8.1 | سوراخکاری و شیارزنی و کنده کاری داکت | 3d | 2016-01-24 | 2016-01-26 | 1255 |  |  |  | 103d | 0d | start no earlier than 2016-01-21 |  |  |  |  |
| 1264 | 1.2.12.8.2 | کانال کنی تاسیسات | 3d | 2016-01-24 | 2016-01-26 | 1263SS |  |  |  | 103d | 0d |  |  |  |  |  |
| 1265 | 1.2.12.8.3 | لوله کشی پلی اتیلن فاضلاب و آب باران | 20d | 2016-01-27 | 2016-02-15 | 1264 |  |  |  | 103d | 0d |  |  |  |  |  |
| 1266 | 1.2.12.8.4 | ساپورتهای لوله کشی تاسیسات | 3d | 2016-02-16 | 2016-02-18 | 1265 |  |  |  | 185d | 0d |  |  |  |  |  |
| 1267 | 1.2.12.8.5 | لوله کشی گالوانیزه آب سرد و گرم | 10d | 2016-02-19 | 2016-02-28 | 1266 |  |  |  | 185d |  |  |  |  |  |  |
| 1268 | 1.2.12.8.6 | لوله کشی لوله های گرمایشی و پنج لایه | 20d | 2016-02-16 | 2016-03-06 | 1265 |  |  |  | 176d | 0d |  |  |  |  |  |
| 1269 | 1.2.12.8.7 | اجرای ساپورتهای کانال کولر | 3d | 2016-02-16 | 2016-02-18 | 1265 |  |  |  | 103d | 0d |  |  |  |  |  |
| 1270 | 1.2.12.8.8 | اجرای کانال کولر | 15d | 2016-02-19 | 2016-03-04 | 1269 |  |  |  | 103d | 0d |  |  |  |  |  |
| 1271 | 1.2.12.8.9 | اجرای کانال اگزاست | 15d | 2016-02-19 | 2016-03-04 | 1270SS |  |  |  | 103d | 0d |  |  |  |  |  |
| 1272 | 1.2.12.8.10 | عایق پشم شیشه و تست | 2d | 2016-03-07 | 2016-03-08 | 1268 |  |  |  | 176d |  |  |  |  |  |  |
| 1273 | 1.2.12.8.11 | اجرای لوله هایPVC | 1d | 2016-01-27 | 2016-01-27 | 1265SS |  |  |  | 217d |  |  |  |  |  |  |

| ID | WBS | Task | Duration | Start | Finish | Predecessors | Total slack | Free slack |
| --- | --- | --- | --- | --- | --- | --- | --- | --- |
| 1274 | 1.2.12.9 | **تاسیسات الکتریکی ( مرحله اول )** | 31d | 2016-01-24 | 2016-02-23 |  | 190d |  |
| 1275 | 1.2.12.9.1 | شیارزنی | 3d | 2016-01-24 | 2016-01-26 | 1263SS | 203d | 0d |
| 1276 | 1.2.12.9.2 | اجرای لوله های PVC . PG13/5 | 15d | 2016-01-27 | 2016-02-10 | 1275 | 203d | 0d |
| 1277 | 1.2.12.9.3 | اجرای لوله های PVC . PG16-42 | 15d | 2016-01-27 | 2016-02-10 | 1276SS | 203d | 0d |
| 1278 | 1.2.12.9.4 | تهیه ساخت و سفارش تابلو برق | 10d | 2016-01-24 | 2016-02-02 | 1275SS | 210d | 0d |
| 1279 | 1.2.12.9.5 | غلاف گزاری | 3d | 2016-01-27 | 2016-01-29 | 1277SS | 215d |  |
| 1280 | 1.2.12.9.6 | سینی کابل | 5d | 2016-02-19 | 2016-02-23 | 1271SS | 190d |  |
| 1281 | 1.2.12.9.7 | نصب تابلو | 1d | 2016-02-03 | 2016-02-03 | 1278 | 210d |  |
| 1282 | 1.2.12.10 | **نازک کاری** | 42d | 2016-03-05 | 2016-04-15 |  | 103d |  |
| 1283 | 1.2.12.10.1 | اجرای کرم بندی و شیب بندی سرویسها | 4d | 2016-03-05 | 2016-03-08 | 1271 | 103d | 0d |
| 1284 | 1.2.12.10.2 | اجرای عایق رطوبتی | 2d | 2016-03-09 | 2016-03-10 | 1283 | 103d | 0d |
| 1285 | 1.2.12.10.3 | اجرای سیمان محافظ روی عایق | 2d | 2016-03-11 | 2016-03-12 | 1284 | 172d |  |
| 1286 | 1.2.12.10.4 | چیدن دیوارهای داکت | 2d | 2016-03-05 | 2016-03-06 | 1283SS | 178d |  |
| 1287 | 1.2.12.10.5 | نصب چارچوبهای در و پنجره | 5d | 2016-03-05 | 2016-03-09 | 1283SS | 175d |  |
| 1288 | 1.2.12.10.6 | اجرای قرنیز و سنگ و پلاک فضای داخلی دیوارها | 10d | 2016-03-11 | 2016-03-20 | 1284 | 103d | 0d |
| 1289 | 1.2.12.10.7 | اجرای گچ سفید دیوارها | 15d | 2016-03-21 | 2016-04-04 | 1288 | 149d |  |
| 1290 | 1.2.12.10.8 | اجرای کاشی دیوار سرویسها | 20d | 2016-03-11 | 2016-03-30 | 1284 | 149d | 0d |
| 1291 | 1.2.12.10.9 | اجرای سرامیک کف | 5d | 2016-03-31 | 2016-04-04 | 1290 | 149d |  |
| 1292 | 1.2.12.10.10 | اجرای سنگ گرانیت و چینی و موزائیک کف | 10d | 2016-03-21 | 2016-03-30 | 1288 | 103d | 0d |
| 1293 | 1.2.12.10.11 | اجرای سقف کاذب ( کناف فضای داخلی ) | 10d | 2016-03-31 | 2016-04-09 | 1292 | 103d | 0d |
| 1294 | 1.2.12.10.12 | اجرای سقف کاذب ( سرویس بهداشتی ) | 4d | 2016-03-31 | 2016-04-03 | 1290 | 150d |  |
| 1295 | 1.2.12.10.13 | **نصبیات و تکمیلی نازک کاری** | 16d | 2016-03-31 | 2016-04-15 |  | 138d |  |
| 1296 | 1.2.12.10.13.1 | نصب در و پنجره های جوبی ، فولادی و UPVC | 3d | 2016-03-31 | 2016-04-02 | 1293SS | 138d | 0d |
| 1297 | 1.2.12.10.13.2 | نصب شیشه ها | 3d | 2016-04-03 | 2016-04-05 | 1296 | 138d | 0d |
| 1298 | 1.2.12.10.13.3 | رنگ آمیزی سقف و دیوار | 10d | 2016-04-06 | 2016-04-15 | 1297 | 138d |  |

| ID | WBS | Task | Duration | Start | Finish | Predecessors | Baseline start | Baseline finish | Baseline duration | Total slack | Free slack | Constraint | Work | Text1 | Text4 | Text5 | Text22 | Text20 |
| --- | --- | --- | --- | --- | --- | --- | --- | --- | --- | --- | --- | --- | --- | --- | --- | --- | --- | --- |
| 1299 | 1.2.12.11 | **تاسیسات الکتریکی ( مرحله دوم )** | 41d | 2016-03-31 | 2016-05-10 |  | 2016-01-05 | 2016-08-04 | 0d | 103d |  |  | 72h | 7% | 170 | 170 | 73 |  |
| 1300 | 1.2.12.11.1 | اجرای سیم کشی و کابل کشی ساختمان | 20d | 2016-03-31 | 2016-04-19 | 1293SS |  |  |  | 103d | 0d |  |  |  |  |  |  |  |
| 1301 | 1.2.12.11.2 | کابل کشی مخابرات و تجهیزات مربوطه | 5d | 2016-04-20 | 2016-04-24 | 1300 |  |  |  | 124d | 0d |  |  |  |  |  |  |  |
| 1302 | 1.2.12.11.3 | اجرا و نصب تابلو برق و جریان ضعیف | 5d | 2016-04-25 | 2016-04-29 | 1301 |  |  |  | 124d |  |  |  |  |  |  |  |  |
| 1303 | 1.2.12.11.4 | کلید و پریز | 5d | 2016-04-20 | 2016-04-24 | 1300 |  |  |  | 103d | 0d |  |  |  |  |  |  |  |
| 1304 | 1.2.12.11.5 | چراغ های ایندور | 5d | 2016-04-25 | 2016-04-29 | 1303 |  |  |  | 103d | 0d |  |  |  |  |  |  |  |
| 1305 | 1.2.12.11.6 | سیستم اعلام حریق | 5d | 2016-04-30 | 2016-05-04 | 1304 |  |  |  | 103d | 0d |  |  |  |  |  |  |  |
| 1306 | 1.2.12.11.7 | سیستم آنتن مرکزی | 3d | 2016-05-05 | 2016-05-07 | 1305 |  |  |  | 103d | 0d |  |  |  |  |  |  |  |
| 1307 | 1.2.12.11.8 | ارت سازی | 3d | 2016-05-08 | 2016-05-10 | 1306 | 2016-01-05 | 2016-01-14 | 0d | 103d | 0d |  | 72h | 60% | 9 روز | 9 روز | 10 |  |
| 1308 | 1.2.12.12 | **تاسیسات مکانیکی ( مرحله دوم )** | 10d | 2016-05-11 | 2016-05-20 |  |  |  |  | 103d |  |  | 360h |  |  |  |  |  |
| 1309 | 1.2.12.12.1 | شیر آلات بهداشتی | 5d | 2016-05-11 | 2016-05-15 | 1307 | 2016-01-28 | 2016-02-11 | 0d | 103d | 0d |  | 104h | 100% | 13 روز | 13 روز | 10 |  |
| 1310 | 1.2.12.12.2 | تجهیزات آتش نشانی | 4d | 2016-05-11 | 2016-05-14 | 1309SS |  |  |  | 109d |  |  |  |  |  |  |  |  |
| 1311 | 1.2.12.12.3 | نصب رادیاتور | 7d | 2016-05-11 | 2016-05-17 | 1309SS | 2016-02-13 | 2016-02-23 | 0d | 103d | 0d |  | 80h | 0% | 10 روز | 10 روز |  |  |
| 1312 | 1.2.12.12.4 | نصب دریچه های هوا و کولر | 3d | 2016-05-18 | 2016-05-20 | 1311 | 2016-02-24 | 2016-04-03 | 0d | 103d |  |  | 176h | 0% | 22 روز | 22 روز | 12 |  |
| 1313 | 1.2.13 | **ساختمان سوله جند منظوره** | 325d | 2015-07-01 | 2016-05-20 |  | 2015-05-20 | 2016-10-01 | 0d | 103d |  |  | 615.5h | 37% | 349 روز | 417 روز | 296 | 296 |
| 1314 | 1.2.13.1 | ابلاغ نقشه های فصل مشترک | 1d | 2015-07-01 | 2015-07-01 |  | 2015-09-19 | 2015-09-19 | 0d | 103d | 0d | start no earlier than 2015-07-01 | 7.5h | 100% | 1 روز | 1 روز |  |  |
| 1315 | 1.2.13.2 | **اجرای سقف سوله** | 36d | 2015-07-02 | 2015-08-06 |  |  |  |  | 103d |  |  |  |  |  |  |  |  |
| 1316 | 1.2.13.2.1 | اجرای تور مرغی | 8d | 2015-07-02 | 2015-07-09 | 1314 |  |  |  | 103d | 0d |  |  |  |  |  |  |  |
| 1317 | 1.2.13.2.2 | اجرای پشم شیشه | 8d | 2015-07-10 | 2015-07-17 | 1316 |  |  |  | 103d | 0d |  |  |  |  |  |  |  |
| 1318 | 1.2.13.2.3 | اجرای ورق کرکره ای | 10d | 2015-07-18 | 2015-07-27 | 1317 |  |  |  | 103d | 0d |  |  |  |  |  |  |  |
| 1319 | 1.2.13.2.4 | اجرای آبراه باران | 10d | 2015-07-28 | 2015-08-06 | 1318 |  |  |  | 103d | 0d |  |  |  |  |  |  |  |
| 1320 | 1.2.13.3 | **اجرای سقف نیم طبقه سوله** | 81d | 2015-08-07 | 2015-10-26 |  |  |  |  | 103d |  |  |  |  |  |  |  |  |
| 1321 | 1.2.13.3.1 | ساخت و مونتاژ تیرهای حمال و تودلی | 20d | 2015-08-07 | 2015-08-26 | 1319 |  |  |  | 103d | 0d |  |  |  |  |  |  |  |
| 1322 | 1.2.13.3.2 | نصب تیر های حمال و تودلی سقف همکف | 20d | 2015-08-27 | 2015-09-15 | 1321 |  |  |  | 103d | 0d |  |  |  |  |  |  |  |
| 1323 | 1.2.13.3.3 | اجرای ورق متال نیم طبقه و راه پله | 20d | 2015-09-16 | 2015-10-05 | 1322 |  |  |  | 103d | 0d |  |  |  |  |  |  |  |
| 1324 | 1.2.13.3.4 | اجرای جوشکاری گل میخ نیم طبقه و راه پله | 20d | 2015-10-06 | 2015-10-25 | 1323 |  |  |  | 103d | 0d |  |  |  |  |  |  |  |
| 1325 | 1.2.13.3.5 | بتن ریزی | 1d | 2015-10-26 | 2015-10-26 | 1324 |  |  |  | 103d | 0d |  |  |  |  |  |  |  |

| ID | WBS | Task | Duration | Start | Finish | Predecessors | Baseline start | Baseline finish | Baseline duration | Total slack | Free slack | Constraint | Work | Text1 | Text4 | Text5 |
| --- | --- | --- | --- | --- | --- | --- | --- | --- | --- | --- | --- | --- | --- | --- | --- | --- |
| 1326 | 1.2.13.4 | **سفت کاری** | 76d | 2015-10-27 | 2016-01-10 |  | 2015-12-27 | 2016-06-22 | 0d | 103d |  |  | 176h | 48% | 142 روز | 142 روز |
| 1327 | 1.2.13.4.1 | کرسی چینی و ایزوگام | 10d | 2015-10-27 | 2015-11-05 | 1325 |  |  |  | 103d | 0d |  |  |  |  |  |
| 1328 | 1.2.13.4.2 | اجرای بلوکاژ (قلوه ریزی و شن نقلی ) | 7d | 2015-11-06 | 2015-11-12 | 1327 |  |  |  | 103d | 0d |  |  |  |  |  |
| 1329 | 1.2.13.4.3 | اجرای دیوارهای پیرامونی | 15d | 2015-11-13 | 2015-11-27 | 1328 |  |  |  | 103d | 0d |  |  |  |  |  |
| 1330 | 1.2.13.4.4 | ساخت و نصب نعل درگاه های پیرامونی | 4d | 2015-11-28 | 2015-12-01 | 1329 | 2015-12-27 | 2016-01-05 | 0d | 103d | 0d |  | 72h | 100% | 9 روز | 9 روز |
| 1331 | 1.2.13.4.5 | اجرای دیوار جداکننده داخلی | 15d | 2015-11-28 | 2015-12-12 | 1330SS | 2015-12-27 | 2016-01-05 | 0d | 103d | 0d |  | 104h | 69% | 9 روز | 9 روز |
| 1332 | 1.2.13.4.6 | ساخت و نصب نعل درگاه های داخلی | 4d | 2015-12-13 | 2015-12-16 | 1331 |  |  |  | 103d | 0d |  |  |  |  |  |
| 1333 | 1.2.13.4.7 | اجرای گچ و خاک دیوارها | 15d | 2015-12-27 | 2016-01-10 | 1332FS+10d |  |  |  | 103d | 0d |  |  |  |  |  |
| 1334 | 1.2.13.5 | **اجرای نمای بیرونی** | 80d | 2016-01-21 | 2016-04-09 |  |  |  |  | 103d |  |  |  |  |  |  |
| 1335 | 1.2.13.5.1 | اجرای سنگ پلاک نما به همراه فتیله | 10d | 2016-01-21 | 2016-01-30 | 1333FS+10d |  |  |  | 103d | 0d | start no earlier than 2016-01-21 |  |  |  |  |
| 1336 | 1.2.13.5.2 | اجرای سنگ پیش آمدگی ها | 25d | 2016-01-31 | 2016-02-24 | 1335 |  |  |  | 189d |  |  |  |  |  |  |
| 1337 | 1.2.13.5.3 | اجرای آستر سیمان سیاه دیوار جهت زیر سازی نمای شسته | 40d | 2016-01-21 | 2016-02-29 | 1335SS |  |  |  | 144d | 0d |  |  |  |  |  |
| 1338 | 1.2.13.5.4 | اجرای نمای شسته | 60d | 2016-01-31 | 2016-03-30 | 1337SS+10d |  |  |  | 144d | 0d |  |  |  |  |  |
| 1339 | 1.2.13.5.5 | اجرای درپوش بتنی جانپناه و کف پنجره ها | 10d | 2016-03-31 | 2016-04-09 | 1338 |  |  |  | 144d |  |  |  |  |  |  |
| 1340 | 1.2.13.6 | **تاسیسات مکانیکی ( مرحله اول )** | 45d | 2016-01-31 | 2016-03-15 |  |  |  |  | 103d |  |  |  |  |  |  |
| 1341 | 1.2.13.6.1 | سوراخکاری و شیارزنی و کنده کاری داکت | 3d | 2016-01-31 | 2016-02-02 | 1335 |  |  |  | 103d | 0d | start no earlier than 2016-01-21 |  |  |  |  |
| 1342 | 1.2.13.6.2 | کانال کنی تاسیسات | 3d | 2016-01-31 | 2016-02-02 | 1341SS |  |  |  | 103d | 0d |  |  |  |  |  |
| 1343 | 1.2.13.6.3 | لوله کشی پلی اتیلن فاضلاب و آب باران | 20d | 2016-02-03 | 2016-02-22 | 1342 |  |  |  | 103d | 0d |  |  |  |  |  |
| 1344 | 1.2.13.6.4 | ساپورتهای لوله کشی تاسیسات | 3d | 2016-02-03 | 2016-02-05 | 1343SS |  |  |  | 198d | 0d |  |  |  |  |  |
| 1345 | 1.2.13.6.5 | لوله کشی گالوانیزه آب سرد و گرم | 10d | 2016-02-06 | 2016-02-15 | 1344 |  |  |  | 198d |  |  |  |  |  |  |
| 1346 | 1.2.13.6.6 | لوله کشی لوله های گرمایشی و پنج لایه | 20d | 2016-02-23 | 2016-03-13 | 1343 |  |  |  | 169d | 0d |  |  |  |  |  |
| 1347 | 1.2.13.6.7 | اجرای ساپورتهای کانال کولر | 3d | 2016-02-23 | 2016-02-25 | 1343 |  |  |  | 103d | 0d |  |  |  |  |  |
| 1348 | 1.2.13.6.8 | اجرای کانال کولر | 15d | 2016-02-26 | 2016-03-11 | 1347 |  |  |  | 103d | 0d |  |  |  |  |  |
| 1349 | 1.2.13.6.9 | اجرای کانال اگزاست | 15d | 2016-02-26 | 2016-03-11 | 1348SS |  |  |  | 103d | 0d |  |  |  |  |  |
| 1350 | 1.2.13.6.10 | عایق پشم شیشه و تست | 2d | 2016-03-14 | 2016-03-15 | 1346 |  |  |  | 169d |  |  |  |  |  |  |
| 1351 | 1.2.13.6.11 | اجرای لوله هایPVC | 1d | 2016-02-03 | 2016-02-03 | 1343SS |  |  |  | 210d |  |  |  |  |  |  |

| ID | WBS | Task | Duration | Start | Finish | Predecessors | Total slack | Free slack |
| --- | --- | --- | --- | --- | --- | --- | --- | --- |
| 1352 | 1.2.13.7 | **تاسیسات الکتریکی ( مرحله اول )** | 31d | 2016-01-31 | 2016-03-01 |  | 183d |  |
| 1353 | 1.2.13.7.1 | شیارزنی | 3d | 2016-01-31 | 2016-02-02 | 1341SS | 196d | 0d |
| 1354 | 1.2.13.7.2 | اجرای لوله های PVC . PG13/5 | 15d | 2016-02-03 | 2016-02-17 | 1353 | 196d | 0d |
| 1355 | 1.2.13.7.3 | اجرای لوله های PVC . PG16-42 | 15d | 2016-02-03 | 2016-02-17 | 1354SS | 196d | 0d |
| 1356 | 1.2.13.7.4 | تهیه ساخت و سفارش تابلو برق | 10d | 2016-01-31 | 2016-02-09 | 1353SS | 203d | 0d |
| 1357 | 1.2.13.7.5 | غلاف گزاری | 3d | 2016-02-03 | 2016-02-05 | 1355SS | 208d |  |
| 1358 | 1.2.13.7.6 | سینی کابل | 5d | 2016-02-26 | 2016-03-01 | 1349SS | 183d |  |
| 1359 | 1.2.13.7.7 | نصب تابلو | 1d | 2016-02-10 | 2016-02-10 | 1356 | 203d |  |
| 1360 | 1.2.13.8 | **نازک کاری** | 44d | 2016-02-26 | 2016-04-09 |  | 103d |  |
| 1361 | 1.2.13.8.1 | اجرای کرم بندی و شیب بندی سرویسها | 4d | 2016-02-26 | 2016-02-29 | 1349SS | 103d | 0d |
| 1362 | 1.2.13.8.2 | اجرای عایق رطوبتی | 2d | 2016-03-01 | 2016-03-02 | 1361 | 103d | 0d |
| 1363 | 1.2.13.8.3 | اجرای سیمان محافظ روی عایق | 2d | 2016-03-03 | 2016-03-04 | 1362 | 180d |  |
| 1364 | 1.2.13.8.4 | چیدن دیوارهای داکت | 2d | 2016-02-26 | 2016-02-27 | 1361SS | 186d |  |
| 1365 | 1.2.13.8.5 | نصب چارچوبهای در و پنجره | 5d | 2016-02-26 | 2016-03-01 | 1361SS | 183d |  |
| 1366 | 1.2.13.8.6 | اجرای قرنیز و سنگ و پلاک فضای داخلی دیوارها | 10d | 2016-03-03 | 2016-03-12 | 1362 | 103d | 0d |
| 1367 | 1.2.13.8.7 | اجرای گچ سفید دیوارها | 15d | 2016-03-13 | 2016-03-27 | 1366 | 157d |  |
| 1368 | 1.2.13.8.8 | اجرای کاشی دیوار سرویسها | 20d | 2016-03-03 | 2016-03-22 | 1362 | 157d | 0d |
| 1369 | 1.2.13.8.9 | اجرای سرامیک کف | 5d | 2016-03-23 | 2016-03-27 | 1368 | 157d |  |
| 1370 | 1.2.13.8.10 | اجرای سنگ گرانیت و چینی و موزائیک کف | 10d | 2016-03-13 | 2016-03-22 | 1366 | 103d | 0d |
| 1371 | 1.2.13.8.11 | اجرای سقف کاذب ( کناف فضای داخلی ) | 10d | 2016-03-23 | 2016-04-01 | 1370 | 103d | 0d |
| 1372 | 1.2.13.8.12 | اجرای سقف کاذب ( سرویس بهداشتی ) | 4d | 2016-03-23 | 2016-03-26 | 1368 | 158d |  |
| 1373 | 1.2.13.8.13 | **نصبیات و تکمیلی نازک کاری** | 18d | 2016-03-23 | 2016-04-09 |  | 144d |  |
| 1374 | 1.2.13.8.13.1 | نصب در و پنجره های جوبی ، فولادی و UPVC | 3d | 2016-03-23 | 2016-03-25 | 1371SS | 144d | 0d |
| 1375 | 1.2.13.8.13.2 | نصب شیشه ها | 3d | 2016-03-26 | 2016-03-28 | 1374 | 144d | 0d |
| 1376 | 1.2.13.8.13.3 | رنگ آمیزی سقف و دیوار | 12d | 2016-03-29 | 2016-04-09 | 1375 | 144d |  |

| ID | WBS | Task | Duration | Start | Finish | Predecessors | Baseline start | Baseline finish | Baseline duration | Total slack | Free slack | Constraint | Work | Text1 | Text4 | Text5 | Text22 | Text3 |
| --- | --- | --- | --- | --- | --- | --- | --- | --- | --- | --- | --- | --- | --- | --- | --- | --- | --- | --- |
| 1377 | 1.2.13.9 | **تاسیسات الکتریکی ( مرحله دوم )** | 41d | 2016-03-23 | 2016-05-02 |  | 2016-01-05 | 2016-08-04 | 0d | 103d |  |  | 72h | 7% | 170 | 170 | 73 |  |
| 1378 | 1.2.13.9.1 | اجرای سیم کشی و کابل کشی ساختمان | 20d | 2016-03-23 | 2016-04-11 | 1371SS |  |  |  | 103d | 0d |  |  |  |  |  |  |  |
| 1379 | 1.2.13.9.2 | کابل کشی مخابرات و تجهیزات مربوطه | 5d | 2016-04-12 | 2016-04-16 | 1378 |  |  |  | 132d | 0d |  |  |  |  |  |  |  |
| 1380 | 1.2.13.9.3 | اجرا و نصب تابلو برق و جریان ضعیف | 5d | 2016-04-17 | 2016-04-21 | 1379 |  |  |  | 132d |  |  |  |  |  |  |  |  |
| 1381 | 1.2.13.9.4 | کلید و پریز | 5d | 2016-04-12 | 2016-04-16 | 1378 |  |  |  | 103d | 0d |  |  |  |  |  |  |  |
| 1382 | 1.2.13.9.5 | چراغ های ایندور | 5d | 2016-04-17 | 2016-04-21 | 1381 |  |  |  | 103d | 0d |  |  |  |  |  |  |  |
| 1383 | 1.2.13.9.6 | سیستم اعلام حریق | 5d | 2016-04-22 | 2016-04-26 | 1382 |  |  |  | 103d | 0d |  |  |  |  |  |  |  |
| 1384 | 1.2.13.9.7 | سیستم آنتن مرکزی | 3d | 2016-04-27 | 2016-04-29 | 1383 |  |  |  | 103d | 0d |  |  |  |  |  |  |  |
| 1385 | 1.2.13.9.8 | ارت سازی | 3d | 2016-04-30 | 2016-05-02 | 1384 | 2016-01-05 | 2016-01-14 | 0d | 103d | 0d |  | 72h | 60% | 9 روز | 9 روز | 10 |  |
| 1386 | 1.2.13.10 | **تاسیسات مکانیکی ( مرحله دوم )** | 18d | 2016-05-03 | 2016-05-20 |  |  |  |  | 103d |  |  | 360h |  |  |  |  |  |
| 1387 | 1.2.13.10.1 | شیر آلات بهداشتی | 5d | 2016-05-03 | 2016-05-07 | 1385 | 2016-01-28 | 2016-02-11 | 0d | 103d | 0d |  | 104h | 100% | 13 روز | 13 روز | 10 |  |
| 1388 | 1.2.13.10.2 | تجهیزات آتش نشانی | 4d | 2016-05-08 | 2016-05-11 | 1387 |  |  |  | 103d | 0d |  |  |  |  |  |  |  |
| 1389 | 1.2.13.10.3 | نصب رادیاتور | 6d | 2016-05-12 | 2016-05-17 | 1388 | 2016-02-13 | 2016-02-23 | 0d | 103d | 0d |  | 80h | 0% | 10 روز | 10 روز |  |  |
| 1390 | 1.2.13.10.4 | نصب دریچه های هوا و کولر | 3d | 2016-05-18 | 2016-05-20 | 1389 | 2016-02-24 | 2016-04-03 | 0d | 103d |  |  | 176h | 0% | 22 روز | 22 روز | 12 |  |
| 1391 | 1.2.14 | **ساختمان موتورخانه** | 229d | 2015-11-18 | 2016-07-03 |  |  |  |  | 59d |  |  | 1071.5h |  |  |  |  |  |
| 1392 | 1.2.14.1 | ابلاغ ساخت موتورخانه از طرف نظارت | 1d | 2015-11-18 | 2015-11-18 |  |  |  |  | 59d | 0d | start no earlier than 2015-11-18 |  |  |  |  |  |  |
| 1393 | 1.2.14.2 | **آماده سازی زمین** | 5d | 2015-11-19 | 2015-11-23 |  |  |  |  | 59d |  |  | 39.5h | 100% | 105 روز |  |  |  |
| 1394 | 1.2.14.2.1 | نقشه برداري | 1d | 2015-11-19 | 2015-11-19 | 1392 |  |  |  | 59d | 0d | start no earlier than 2015-04-23 | 8h | 100% | 1 روز |  |  |  |
| 1395 | 1.2.14.2.2 | پياده كردن كروكي ساختمان | 1d | 2015-11-20 | 2015-11-20 | 1394 |  |  |  | 59d | 0d |  | 7.5h | 100% | 1 روز |  |  |  |
| 1396 | 1.2.14.2.3 | پی کنی | 3d | 2015-11-21 | 2015-11-23 | 1395 |  |  |  | 59d | 0d |  | 24h | 100% | 3 روز |  |  |  |
| 1397 | 1.2.14.3 | **اجرای فونداسیون** | 70d | 2015-11-24 | 2016-02-01 |  |  |  |  | 59d |  |  | 424h | 100% | 25 روز |  | 43 |  |
| 1398 | 1.2.14.3.1 | پیاده سازی ، رگلاژ و تسطیح | 5d | 2015-11-24 | 2015-11-28 | 1396 |  |  |  | 59d | 0d |  | 32h | 100% | 4 روز |  |  |  |
| 1399 | 1.2.14.3.2 | اجرای سنگ چینی به ارتفاع 1.60 | 35d | 2015-11-29 | 2016-01-02 | 1398 |  |  |  | 59d | 0d |  |  |  |  |  |  |  |
| 1400 | 1.2.14.3.3 | بتن مگر | 5d | 2016-01-03 | 2016-01-07 | 1399 |  |  |  | 59d | 0d |  | 40h | 100% | 3 روز |  |  |  |
| 1401 | 1.2.14.3.4 | آرماتور بندی فونداسیون و نصب صفحه ستون ها | 12d | 2016-01-08 | 2016-01-19 | 1400 |  |  |  | 59d | 0d |  | 200h | 100% | 10 روز |  | 22 | 10 |
| 1402 | 1.2.14.3.5 | قالب بندی | 5d | 2016-01-20 | 2016-01-24 | 1401 |  |  |  | 59d | 0d |  | 112h | 100% | 5 روز |  | 10 |  |
| 1403 | 1.2.14.3.6 | بتن ریزی | 1d | 2016-01-25 | 2016-01-25 | 1402 |  |  |  | 59d | 0d |  | 40h | 100% | 3 روز |  |  |  |
| 1404 | 1.2.14.3.7 | قلوه ریزی بین چشمه های فونداسیون | 7d | 2016-01-26 | 2016-02-01 | 1403 |  |  |  | 59d | 0d |  |  |  |  |  |  |  |

Notes:
- 1403: به دلی نبود نقشه و دیا , و نی به دلی اهمی بالای ای سازه، در ابتداری پروژه پیانکار با ریک پذیی و مسدولی خود ای فعالی را آغاز نموده است

| ID | WBS | Task | Duration | Start | Finish | Predecessors | Baseline start | Baseline finish | Baseline duration | Total slack | Free slack | Constraint | Work | Text1 | Text4 | Text5 |
| --- | --- | --- | --- | --- | --- | --- | --- | --- | --- | --- | --- | --- | --- | --- | --- | --- |
| 1405 | 1.2.14.4 | **اجرای اسکلت فلزی** | 27d | 2016-02-16 | 2016-03-13 |  |  |  |  | 59d |  |  |  |  |  |  |
| 1406 | 1.2.14.4.1 | ساخت و مونتاژ ستون ها | 7d | 2016-02-16 | 2016-02-22 | 1404FS+14d |  |  |  | 59d | 0d |  |  |  |  |  |
| 1407 | 1.2.14.4.2 | ساخت و مونتاژ تیرهای حمال و تودلی | 12d | 2016-02-23 | 2016-03-05 | 1406 |  |  |  | 59d | 0d |  |  |  |  |  |
| 1408 | 1.2.14.4.3 | نصب ستون ها | 4d | 2016-03-06 | 2016-03-09 | 1407 |  |  |  | 59d | 0d |  |  |  |  |  |
| 1409 | 1.2.14.4.4 | نصب تیر های حمال و تودلی سقف همکف | 4d | 2016-03-10 | 2016-03-13 | 1408 |  |  |  | 59d | 0d |  |  |  |  |  |
| 1410 | 1.2.14.5 | **سفت کاری** | 30d | 2016-03-14 | 2016-04-12 |  | 2015-12-27 | 2016-06-22 | 0d | 59d |  |  | 176h | 48% | 142 روز | 142 روز |
| 1411 | 1.2.14.5.1 | کرسی چینی و ایزوگام | 5d | 2016-03-14 | 2016-03-18 | 1409 |  |  |  | 59d | 0d |  |  |  |  |  |
| 1412 | 1.2.14.5.2 | اجرای بلوکاژ (قلوه ریزی و شن نقلی ) | 3d | 2016-03-19 | 2016-03-21 | 1411 |  |  |  | 59d | 0d |  |  |  |  |  |
| 1413 | 1.2.14.5.3 | اجرای دیوارهای پیرامونی | 5d | 2016-03-22 | 2016-03-26 | 1412 |  |  |  | 59d | 0d |  |  |  |  |  |
| 1414 | 1.2.14.5.4 | ساخت و نصب نعل درگاه های پیرامونی | 2d | 2016-03-27 | 2016-03-28 | 1413 | 2015-12-27 | 2016-01-05 | 0d | 59d | 0d |  | 72h | 100% | 9 روز | 9 روز |
| 1415 | 1.2.14.5.5 | اجرای دیوار جداکننده داخلی | 10d | 2016-03-27 | 2016-04-05 | 1414SS | 2015-12-27 | 2016-01-05 | 0d | 59d | 0d |  | 104h | 69% | 9 روز | 9 روز |
| 1416 | 1.2.14.5.6 | ساخت و نصب نعل درگاه های داخلی | 2d | 2016-04-06 | 2016-04-07 | 1415 |  |  |  | 59d | 0d |  |  |  |  |  |
| 1417 | 1.2.14.5.7 | اجرای گچ و خاک دیوارها | 5d | 2016-04-08 | 2016-04-12 | 1416 |  |  |  | 141d |  |  |  |  |  |  |
| 1418 | 1.2.14.6 | **بام ( مرحله اول )** | 19d | 2016-04-08 | 2016-04-26 |  |  |  |  | 59d |  |  |  |  |  |  |
| 1419 | 1.2.14.6.1 | اجرای دیوار جان پناه پشت بام و خرپشته | 6d | 2016-04-08 | 2016-04-13 | 1416 |  |  |  | 59d | 0d |  |  |  |  |  |
| 1420 | 1.2.14.6.2 | سیمانکاری دیوار جانپناه | 3d | 2016-04-14 | 2016-04-16 | 1419 |  |  |  | 59d | 0d |  |  |  |  |  |
| 1421 | 1.2.14.6.3 | رابیتس بندی | 10d | 2016-04-17 | 2016-04-26 | 1420 |  |  |  | 67d | 0d |  |  |  |  |  |
| 1422 | 1.2.14.7 | **اجرای نمای بیرونی** | 60d | 2016-04-27 | 2016-06-25 |  |  |  |  | 67d |  |  |  |  |  |  |
| 1423 | 1.2.14.7.1 | اجرای سنگ پلاک نما به همراه فتیله | 5d | 2016-04-27 | 2016-05-01 | 1421 |  |  |  | 67d | 0d | start no earlier than 2016-01-21 |  |  |  |  |
| 1424 | 1.2.14.7.2 | اجرای سنگ پیش آمدگی ها | 10d | 2016-05-02 | 2016-05-11 | 1423 |  |  |  | 67d | 0d |  |  |  |  |  |
| 1425 | 1.2.14.7.3 | اجرای آستر سیمان سیاه دیوار جهت زیر سازی نمای شسته | 20d | 2016-05-12 | 2016-05-31 | 1424 |  |  |  | 67d | 0d |  |  |  |  |  |
| 1426 | 1.2.14.7.4 | اجرای نمای شسته | 25d | 2016-05-22 | 2016-06-15 | 1425SS+10d |  |  |  | 67d | 0d |  |  |  |  |  |
| 1427 | 1.2.14.7.5 | اجرای درپوش بتنی جانپناه و کف پنجره ها | 10d | 2016-06-16 | 2016-06-25 | 1426 |  |  |  | 67d |  |  |  |  |  |  |
| 1428 | 1.2.14.8 | **تاسیسات مکانیکی ( مرحله اول )** | 17d | 2016-04-17 | 2016-05-03 |  |  |  |  | 59d |  |  |  |  |  |  |
| 1429 | 1.2.14.8.1 | سوراخکاری و شیارزنی و کنده کاری داکت | 1d | 2016-04-17 | 2016-04-17 | 1420 |  |  |  | 59d | 0d | start no earlier than 2016-01-21 |  |  |  |  |
| 1430 | 1.2.14.8.2 | کانال کنی تاسیسات | 1d | 2016-04-17 | 2016-04-17 | 1429SS |  |  |  | 59d | 0d |  |  |  |  |  |
| 1431 | 1.2.14.8.3 | لوله کشی پلی اتیلن فاضلاب و آب باران | 5d | 2016-04-18 | 2016-04-22 | 1430 |  |  |  | 59d | 0d |  |  |  |  |  |
| 1432 | 1.2.14.8.4 | ساپورتهای لوله کشی تاسیسات | 1d | 2016-04-18 | 2016-04-18 | 1431SS |  |  |  | 130d | 0d |  |  |  |  |  |
| 1433 | 1.2.14.8.5 | لوله کشی گالوانیزه آب سرد و گرم | 5d | 2016-04-19 | 2016-04-23 | 1432 |  |  |  | 130d |  |  |  |  |  |  |
| 1434 | 1.2.14.8.6 | لوله کشی لوله های گرمایشی و پنج لایه | 4d | 2016-04-23 | 2016-04-26 | 1431 |  |  |  | 126d | 0d |  |  |  |  |  |
| 1435 | 1.2.14.8.7 | اجرای ساپورتهای کانال کولر | 1d | 2016-04-23 | 2016-04-23 | 1431 |  |  |  | 59d | 0d |  |  |  |  |  |
| 1436 | 1.2.14.8.8 | اجرای کانال کولر | 10d | 2016-04-24 | 2016-05-03 | 1435 |  |  |  | 59d | 0d |  |  |  |  |  |
| 1437 | 1.2.14.8.9 | اجرای کانال اگزاست | 10d | 2016-04-24 | 2016-05-03 | 1436SS |  |  |  | 59d | 0d |  |  |  |  |  |
| 1438 | 1.2.14.8.10 | عایق پشم شیشه و تست | 1d | 2016-04-27 | 2016-04-27 | 1434 |  |  |  | 126d |  |  |  |  |  |  |
| 1439 | 1.2.14.8.11 | اجرای لوله هایPVC | 1d | 2016-04-18 | 2016-04-18 | 1431SS |  |  |  | 118d | 0d |  |  |  |  |  |

| ID | WBS | Task | Duration | Start | Finish | Predecessors | Total slack | Free slack | Constraint |
| --- | --- | --- | --- | --- | --- | --- | --- | --- | --- |
| 1440 | 1.2.14.9 | **تاسیسات الکتریکی ( مرحله اول )** | 8d | 2016-04-17 | 2016-04-24 |  | 129d |  |  |
| 1441 | 1.2.14.9.1 | شیارزنی | 1d | 2016-04-17 | 2016-04-17 | 1429SS | 131d | 0d |  |
| 1442 | 1.2.14.9.2 | اجرای لوله های PVC . PG13/5 | 5d | 2016-04-18 | 2016-04-22 | 1441 | 131d | 0d |  |
| 1443 | 1.2.14.9.3 | اجرای لوله های PVC . PG16-42 | 5d | 2016-04-18 | 2016-04-22 | 1442SS | 131d | 0d |  |
| 1444 | 1.2.14.9.4 | تهیه ساخت و سفارش تابلو برق | 5d | 2016-04-17 | 2016-04-21 | 1441SS | 131d | 0d |  |
| 1445 | 1.2.14.9.5 | غلاف گزاری | 1d | 2016-04-18 | 2016-04-18 | 1443SS | 135d |  |  |
| 1446 | 1.2.14.9.6 | سینی کابل | 1d | 2016-04-24 | 2016-04-24 | 1437SS | 129d |  |  |
| 1447 | 1.2.14.9.7 | نصب تابلو | 1d | 2016-04-22 | 2016-04-22 | 1444 | 131d |  |  |
| 1448 | 1.2.14.10 | **بام ( مرحله دوم )** | 17d | 2016-04-19 | 2016-05-05 |  | 118d |  |  |
| 1449 | 1.2.14.10.1 | شیب بندی و اجرای بتن سبک بام | 2d | 2016-04-19 | 2016-04-20 | 1439 | 118d | 0d | start no earlier than 2016-02-04 |
| 1450 | 1.2.14.10.2 | اجرای سیمانکاری لیسه ای زیر عایق | 1d | 2016-04-21 | 2016-04-21 | 1449 | 118d | 0d |  |
| 1451 | 1.2.14.10.3 | اجرای عایق پشت بام | 1d | 2016-04-22 | 2016-04-22 | 1450 | 118d | 0d |  |
| 1452 | 1.2.14.10.4 | نصب تور مرغی قبل از سنگ اندود | 1d | 2016-04-23 | 2016-04-23 | 1451 | 118d | 0d |  |
| 1453 | 1.2.14.10.5 | اجرای سنگ قرنیز لاشتر | 1d | 2016-04-24 | 2016-04-24 | 1452 | 118d | 0d |  |
| 1454 | 1.2.14.10.6 | اجرای آستر سیمان سیاه و سفید بام | 5d | 2016-04-25 | 2016-04-29 | 1453 | 118d | 0d |  |
| 1455 | 1.2.14.10.7 | شیب بندی و اجرای موزاییک بام | 5d | 2016-04-30 | 2016-05-04 | 1454 | 118d | 0d |  |
| 1456 | 1.2.14.10.8 | نصب قرنیز گالوانیزه بام | 1d | 2016-05-05 | 2016-05-05 | 1455 | 118d |  |  |
| 1457 | 1.2.14.11 | **نازک کاری** | 23d | 2016-04-24 | 2016-05-16 |  | 59d |  |  |
| 1458 | 1.2.14.11.1 | اجرای کرم بندی و شیب بندی سرویسها | 3d | 2016-04-24 | 2016-04-26 | 1437SS | 59d | 0d |  |
| 1459 | 1.2.14.11.2 | اجرای عایق رطوبتی | 1d | 2016-04-27 | 2016-04-27 | 1458 | 59d | 0d |  |
| 1460 | 1.2.14.11.3 | اجرای سیمان محافظ روی عایق | 1d | 2016-04-28 | 2016-04-28 | 1459 | 125d |  |  |
| 1461 | 1.2.14.11.4 | چیدن دیوارهای داکت | 1d | 2016-04-24 | 2016-04-24 | 1458SS | 129d |  |  |
| 1462 | 1.2.14.11.5 | نصب چارچوبهای در و پنجره | 1d | 2016-04-24 | 2016-04-24 | 1458SS | 129d |  |  |
| 1463 | 1.2.14.11.6 | اجرای قرنیز و سنگ و پلاک فضای داخلی دیوارها | 3d | 2016-04-28 | 2016-04-30 | 1459 | 59d | 0d |  |
| 1464 | 1.2.14.11.7 | اجرای گچ سفید دیوارها | 4d | 2016-05-01 | 2016-05-04 | 1463 | 119d |  |  |
| 1465 | 1.2.14.11.8 | اجرای کاشی دیوار سرویسها | 10d | 2016-04-28 | 2016-05-07 | 1459 | 114d | 0d |  |
| 1466 | 1.2.14.11.9 | اجرای سرامیک کف | 2d | 2016-05-08 | 2016-05-09 | 1465 | 114d |  |  |
| 1467 | 1.2.14.11.10 | اجرای سنگ گرانیت و چینی و موزائیک کف | 2d | 2016-05-01 | 2016-05-02 | 1463 | 59d | 0d |  |
| 1468 | 1.2.14.11.11 | اجرای سقف کاذب ( کناف فضای داخلی ) | 4d | 2016-05-03 | 2016-05-06 | 1467 | 59d | 0d |  |

| ID | WBS | Task | Duration | Start | Finish | Predecessors | Baseline start | Baseline finish | Baseline duration | Total slack | Free slack | Constraint | Work | Text1 | Text4 | Text5 | Text22 | Text20 |
| --- | --- | --- | --- | --- | --- | --- | --- | --- | --- | --- | --- | --- | --- | --- | --- | --- | --- | --- |
| 1469 | 1.2.14.11.12 | **نصبیات و تکمیلی نازک کاری** | 14d | 2016-05-03 | 2016-05-16 |  |  |  |  | 107d |  |  |  |  |  |  |  |  |
| 1470 | 1.2.14.11.12.1 | نصب در و پنجره های جوبی ، فولادی و UPVC | 3d | 2016-05-03 | 2016-05-05 | 1468SS |  |  |  | 107d | 0d |  |  |  |  |  |  |  |
| 1471 | 1.2.14.11.12.2 | نصب شیشه ها | 1d | 2016-05-06 | 2016-05-06 | 1470 |  |  |  | 107d | 0d |  |  |  |  |  |  |  |
| 1472 | 1.2.14.11.12.3 | رنگ آمیزی سقف و دیوار | 10d | 2016-05-07 | 2016-05-16 | 1471 |  |  |  | 107d |  |  |  |  |  |  |  |  |
| 1473 | 1.2.14.12 | **تاسیسات الکتریکی ( مرحله دوم )** | 10d | 2016-05-07 | 2016-05-16 |  | 2016-01-05 | 2016-08-04 | 0d | 59d |  |  | 72h | 7% | 170 | 170 | 73 |  |
| 1474 | 1.2.14.12.1 | اجرای سیم کشی و کابل کشی ساختمان | 5d | 2016-05-07 | 2016-05-11 | 1468 |  |  |  | 59d | 0d |  |  |  |  |  |  |  |
| 1475 | 1.2.14.12.2 | کابل کشی مخابرات و تجهیزات مربوطه | 2d | 2016-05-12 | 2016-05-13 | 1474 |  |  |  | 107d | 0d |  |  |  |  |  |  |  |
| 1476 | 1.2.14.12.3 | اجرا و نصب تابلو برق و جریان ضعیف | 3d | 2016-05-14 | 2016-05-16 | 1475 |  |  |  | 107d |  |  |  |  |  |  |  |  |
| 1477 | 1.2.14.12.4 | کلید و پریز | 1d | 2016-05-12 | 2016-05-12 | 1474 |  |  |  | 108d | 0d |  |  |  |  |  |  |  |
| 1478 | 1.2.14.12.5 | چراغ های ایندور | 1d | 2016-05-13 | 2016-05-13 | 1477 |  |  |  | 108d | 0d |  |  |  |  |  |  |  |
| 1479 | 1.2.14.12.6 | سیستم اعلام حریق | 1d | 2016-05-14 | 2016-05-14 | 1478 |  |  |  | 108d | 0d |  |  |  |  |  |  |  |
| 1480 | 1.2.14.12.7 | ارت سازی | 1d | 2016-05-15 | 2016-05-15 | 1479 | 2016-01-05 | 2016-01-14 | 0d | 108d |  |  | 72h | 60% | 9 روز | 9 روز | 10 |  |
| 1481 | 1.2.14.13 | **تاسیسات مکانیکی ( مرحله دوم )** | 1d | 2016-05-14 | 2016-05-14 |  |  |  |  | 109d |  |  | 360h |  |  |  |  |  |
| 1482 | 1.2.14.13.1 | شیر آلات بهداشتی | 1d | 2016-05-14 | 2016-05-14 | 1475 | 2016-01-28 | 2016-02-11 | 0d | 109d | 0d |  | 104h | 100% | 13 روز | 13 روز | 10 |  |
| 1483 | 1.2.14.13.2 | نصب رادیاتور | 1d | 2016-05-14 | 2016-05-14 | 1482SS | 2016-02-13 | 2016-02-23 | 0d | 109d | 0d |  | 80h | 0% | 10 روز | 10 روز |  |  |
| 1484 | 1.2.14.13.3 | نصب دریچه های هوا و کولر | 1d | 2016-05-14 | 2016-05-14 | 1483SS | 2016-02-24 | 2016-04-03 | 0d | 109d |  |  | 176h | 0% | 22 روز | 22 روز | 12 |  |
| 1485 | 1.2.14.14 | **تجهیزات موتورخانه** | 53d | 2016-05-12 | 2016-07-03 |  |  |  |  | 59d |  |  |  |  |  |  |  |  |
| 1486 | 1.2.14.14.1 | تهیه متریال ، قطعات وتجهیزات | 20d | 2016-05-12 | 2016-05-31 | 1474 |  |  |  | 59d | 0d |  |  |  |  |  |  |  |
| 1487 | 1.2.14.14.2 | نصب و مونتاژ کامل تجهیزات | 45d | 2016-05-18 | 2016-07-01 | 1486SS+6d |  |  |  | 59d | 0d |  |  |  |  |  |  |  |
| 1488 | 1.2.14.14.3 | تست اولیه | 2d | 2016-07-02 | 2016-07-03 | 1487 |  |  |  | 59d |  |  |  |  |  |  |  |  |
| 1489 | 1.2.15 | **محوطه سازی** | 408d | 2015-07-01 | 2016-08-11 |  |  |  |  | 20d |  |  | 1935.5h | 3% | 499 روز |  | 481 | 481 |
| 1490 | 1.2.15.1 | **آماده سازی زمین** | 30d | 2015-07-01 | 2015-07-30 |  |  |  |  | 20.75d |  |  | 97.5h |  | 33 روز |  |  |  |
| 1491 | 1.2.15.1.1 | نقشه برداری و پیاده سازی | 12d | 2015-07-01 | 2015-07-12 |  |  |  |  | 20.75d | 0d | start no earlier than 2015-07-01 | 90h | 0% | 11 روز |  | 12 |  |
| 1492 | 1.2.15.1.2 | تهیه فصل مشترک (برداشت از خاک های دپو شده) و حمل خاکها | 18d | 2015-07-13 | 2015-07-30 | 1491 |  |  |  | 20.75d | 0d | start no earlier than 2015-03-17 | 7.5h | 0% | 20 روز |  |  |  |

| ID | WBS | Task | Duration | Start | Finish | Predecessors | Total slack | Free slack | Constraint | Work | Text1 | Text4 | Text22 | Text20 | Text3 |
| --- | --- | --- | --- | --- | --- | --- | --- | --- | --- | --- | --- | --- | --- | --- | --- |
| 1493 | 1.2.15.2 | **زیرسازی و ابنیه** | 388d | 2015-07-21 | 2016-08-11 |  | 20d |  |  | 480h | 5% | 438 روز | 424 |  |  |
| 1494 | 1.2.15.2.1 | خاکبرداری | 240d | 2015-07-21 | 2016-03-17 | 1492FS-10d | 20.75d | 0d | start no earlier than 2015-04-21 | 480h | 80% | 60 روز | 63 |  |  |
| 1495 | 1.2.15.2.2 | کانال کنی و اجرای منهولها | 25d | 2016-03-10 | 2016-04-04 | 1494FS-7d | 20.75d | 0d | start no earlier than 2016-03-08 |  |  |  |  |  |  |
| 1496 | 1.2.15.2.3 | اجرای زیر اساس و اساس خیابانها | 55d | 2016-03-10 | 2016-05-04 | 1495SS | 20.75d | 0d |  |  |  |  |  |  |  |
| 1497 | 1.2.15.2.4 | اجرای دیوارهای سنگی مالون | 30d | 2016-04-19 | 2016-05-19 | 1496FS-15d | 20.75d | 0d | start no earlier than 2016-03-06 |  |  |  |  |  |  |
| 1498 | 1.2.15.2.5 | اجرای کانال گربه رو تاسیسات | 30d | 2016-04-29 | 2016-05-29 | 1497SS+10d | 20.75d | 0.75d |  |  |  |  |  |  |  |
| 1499 | 1.2.15.2.6 | اجرای جدول کاری و کانیوو | 31d | 2016-05-30 | 2016-06-29 | 1498 | 20d | 0d | start no earlier than 2016-05-30 |  |  |  |  |  |  |
| 1500 | 1.2.15.2.7 | اجرای پیادرو سازی و محوطه جلو ساختمانها | 30d | 2016-06-14 | 2016-07-13 | 1499SS+15d | 49d |  |  |  |  |  |  |  |  |
| 1501 | 1.2.15.2.8 | اجرای پی کنی تاسیسات برق | 10d | 2016-06-30 | 2016-07-09 | 1499 | 20d | 0d |  |  |  |  |  |  |  |
| 1502 | 1.2.15.2.9 | اجرای پی کنی تاسیسات گاز | 10d | 2016-06-30 | 2016-07-09 | 1501SS | 20d | 0d |  |  |  |  |  |  |  |
| 1503 | 1.2.15.2.10 | اجرای پریمکت | 12d | 2016-07-05 | 2016-07-16 | 1502FS-5d | 20d | 0d |  |  |  |  |  |  |  |
| 1504 | 1.2.15.2.11 | اجرای آسفالت | 35d | 2016-07-08 | 2016-08-11 | 1503SS+3d | 20d |  |  |  |  |  |  |  |  |
| 1505 | 1.2.15.3 | **تاسیسات الکتریکی** | 37d | 2016-03-17 | 2016-04-23 |  | 130.75d |  |  | 1358h | 0% | 233 روز | 227 |  |  |
| 1506 | 1.2.15.3.1 | ساخت تابلو های برق محوطه | 15d | 2016-03-17 | 2016-04-01 | 1494 | 130.75d | 0d | start no earlier than 2015-10-30 | 300h | 0% | 38 روز | 40 |  |  |
| 1507 | 1.2.15.3.2 | نصب تابلو های برق محوطه | 5d | 2016-04-01 | 2016-04-06 | 1506 | 132.75d | 0d |  | 22.5h | 0% | 4 روز |  |  |  |
| 1508 | 1.2.15.3.3 | کابل کشی برق و مخابرات و ارت ساختمان ها و تابلو های اصلی و روشنایی محوطه | 20d | 2016-04-01 | 2016-04-21 | 1507SS | 132.75d |  |  | 365.5h | 0% | 47 روز | 35 |  |  |
| 1509 | 1.2.15.3.4 | ساخت پایه بتنی پایه های چراغ های محوطه | 12d | 2016-03-17 | 2016-03-29 | 1506SS | 130.75d | 0d |  | 407.5h | 0% | 52 روز | 40 |  |  |
| 1510 | 1.2.15.3.5 | نصب پایه های بتنی چراغهای محوطه | 10d | 2016-03-22 | 2016-04-01 | 1509SS+5d | 130.75d | 0d |  | 90h | 0% | 13 روز | 12 |  |  |
| 1511 | 1.2.15.3.6 | نصب چراغ های محوطه | 10d | 2016-04-01 | 2016-04-11 | 1510 | 130.75d | 0d |  | 120h | 0% | 15 روز | 16 |  |  |
| 1512 | 1.2.15.3.7 | احداث سیستم چاه ارت | 10d | 2016-04-11 | 2016-04-21 | 1511 | 130.75d | 0d |  | 52.5h | 0% | 8 روز |  |  |  |
| 1513 | 1.2.15.3.8 | تست و راه اندازی موقت | 2d | 2016-04-21 | 2016-04-23 | 1512 | 130.75d |  |  |  |  |  |  |  |  |
| 1514 | 1.2.16 | **ساختمان سر درب** | 400d | 2015-07-01 | 2016-08-03 |  | 28d |  |  | 5020.5h | 39% | 325 روز | 333 | 333 |  |
| 1515 | 1.2.16.1 | **آماده سازی زمین** | 26d | 2015-07-01 | 2015-07-26 |  | 28d |  |  | 999.5h | 100% | 105 روز |  |  |  |
| 1516 | 1.2.16.1.1 | توقف تا ابلاغ بنچ مارک | 20d | 2015-07-01 | 2015-07-20 |  | 28d | 0d | start no earlier than 2015-07-01 | 960h | 100% | 100 روز |  |  | 101 |
| 1517 | 1.2.16.1.2 | نقشه برداري | 1d | 2015-07-21 | 2015-07-21 | 1516 | 28d | 0d | start no earlier than 2015-04-23 | 8h | 100% | 1 روز |  |  |  |
| 1518 | 1.2.16.1.3 | پياده كردن كروكي ساختمان | 2d | 2015-07-22 | 2015-07-23 | 1517 | 28d | 0d |  | 7.5h | 100% | 1 روز |  |  |  |
| 1519 | 1.2.16.1.4 | پی کنی | 3d | 2015-07-24 | 2015-07-26 | 1518 | 28d | 0d |  | 24h | 100% | 3 روز |  |  |  |

Notes:
- 1494: به دلی مشخص نبودن تراز های مربوطه خاکبرداری به مدت 10 روز متوقف شد

| ID | WBS | Task | Duration | Start | Finish | Predecessors | Total slack | Free slack | Constraint | Work | Text1 | Text4 | Text22 | Text3 |
| --- | --- | --- | --- | --- | --- | --- | --- | --- | --- | --- | --- | --- | --- | --- |
| 1520 | 1.2.16.2 | **اجرای فونداسیون** | 43d | 2015-07-27 | 2015-09-07 |  | 28d |  |  | 424h | 100% | 25 روز | 43 |  |
| 1521 | 1.2.16.2.1 | رگلاژ و تسطیح | 10d | 2015-07-27 | 2015-08-05 | 1519 | 28d | 0d |  | 32h | 100% | 4 روز |  |  |
| 1522 | 1.2.16.2.2 | ریختن بتن مگر | 5d | 2015-08-06 | 2015-08-10 | 1521 | 28d | 0d |  | 40h | 100% | 3 روز |  |  |
| 1523 | 1.2.16.2.3 | اجرای آرماتور ها | 15d | 2015-08-11 | 2015-08-25 | 1522 | 28d | 0d |  | 200h | 100% | 10 روز | 22 | 10 |
| 1524 | 1.2.16.2.4 | قالب بندی | 10d | 2015-08-26 | 2015-09-04 | 1523 | 28d | 0d |  | 112h | 100% | 5 روز | 10 |  |
| 1525 | 1.2.16.2.5 | بتن ریزی | 3d | 2015-09-05 | 2015-09-07 | 1524 | 28d | 0d |  | 40h | 100% | 3 روز |  |  |
| 1526 | 1.2.16.3 | **اجرای سازه** | 257d | 2015-09-08 | 2016-05-21 |  | 28d |  |  | 2473.5h | 23% | 215 روز | 277 |  |
| 1527 | 1.2.16.3.1 | **اجرای دیوارهای بتنی پایه های سردرب** | 240d | 2015-09-08 | 2016-05-04 |  | 28d |  |  | 1955.5h | 43% | 147 روز | 188 |  |
| 1528 | 1.2.16.3.1.1 | **اجرا تراز +3.60** | 97d | 2015-09-08 | 2015-12-13 |  | 28d |  |  | 444.5h | 100% | 61 روز | 47 |  |
| 1529 | 1.2.16.3.1.1.1 | آرماتوربندی به همراه (توقف تا بلاغ زاویه کاهش دیوارها) | 16d | 2015-09-08 | 2015-09-23 | 1525 | 28d | 0d |  | 124.5h | 100% | 21 روز | 16 | 21 |
| 1530 | 1.2.16.3.1.1.2 | نصب تمامی بیس پلیت ها و انتظارها | 4d | 2015-11-23 | 2015-11-26 | 1529FS+60d | 28d | 0d | start no earlier than 2015-07-28 | 48h | 100% | 4 روز |  |  |
| 1531 | 1.2.16.3.1.1.3 | قالب بندی | 14d | 2015-11-27 | 2015-12-10 | 1530 | 28d | 0d |  | 232h | 100% | 14 روز | 22 | 14 |
| 1532 | 1.2.16.3.1.1.4 | بتن ریزی | 3d | 2015-12-11 | 2015-12-13 | 1531 | 28d | 0d |  | 40h | 100% | 3 روز |  |  |
| 1533 | 1.2.16.3.1.2 | **اجرا تراز +6.60** | 71d | 2015-12-14 | 2016-02-22 |  | 28d |  |  | 517.5h | 72% | 29 روز | 47 |  |
| 1534 | 1.2.16.3.1.2.1 | توقف بدلیل نصب صفحات بیس پلیتهای دیوار | 35d | 2015-12-14 | 2016-01-17 | 1532 | 28d | 0d |  |  |  |  |  |  |
| 1535 | 1.2.16.3.1.2.2 | آرماتوربندی | 15d | 2016-01-18 | 2016-02-01 | 1534 | 28d | 0d |  | 163h | 100% | 10 روز | 16 | 10 |
| 1536 | 1.2.16.3.1.2.3 | نصب تمامی بیس پلیت ها و انتظارها | 5d | 2016-02-02 | 2016-02-06 | 1535 | 28d | 0d |  | 62h | 100% | 4 روز |  |  |
| 1537 | 1.2.16.3.1.2.4 | قالب بندی | 15d | 2016-02-07 | 2016-02-21 | 1536 | 28d | 0d | start no earlier than 2015-09-04 | 239h | 50% | 12 روز | 22 | 12 |
| 1538 | 1.2.16.3.1.2.5 | بتن ریزی | 1d | 2016-02-22 | 2016-02-22 | 1537 | 28d | 0d |  | 53.5h | 50% | 3 روز |  |  |
| 1539 | 1.2.16.3.1.3 | **اجرای تراز +10** | 36d | 2016-02-23 | 2016-03-29 |  | 28d |  |  | 500.5h | 0% | 28 روز | 47 |  |
| 1540 | 1.2.16.3.1.3.1 | آرماتوربندی | 15d | 2016-02-23 | 2016-03-08 | 1538 | 28d | 0d |  | 166h | 0% | 10 روز | 16 | 10 |
| 1541 | 1.2.16.3.1.3.2 | نصب تمامی بیس پلیت ها و انتظارها | 5d | 2016-03-09 | 2016-03-13 | 1540 | 28d | 0d |  | 56.5h | 0% | 4 روز |  |  |
| 1542 | 1.2.16.3.1.3.3 | قالب بندی | 15d | 2016-03-14 | 2016-03-28 | 1541 | 28d | 0d |  | 225h | 0% | 12 روز | 22 | 12 |
| 1543 | 1.2.16.3.1.3.4 | بتن ریزی | 1d | 2016-03-29 | 2016-03-29 | 1542 | 28d | 0d |  | 53h | 0% | 2 روز |  |  |

Notes:
- 1525: به دلی نبود نقشه و دیا , و نی به دلی اهمی بالای ای سازه، در ابتداری پروژه پیانکار با ریک پذیی و مسدولی خود ای فعالی را آغاز نموده است
- 1529: توقف 25 روزه به دلی ابلاغ زاوی کاهش دیار

| ID | WBS | Task | Duration | Start | Finish | Predecessors | Baseline start | Baseline finish | Baseline duration | Total slack | Free slack | Constraint | Work | Text1 | Text4 | Text22 | Text3 |
| --- | --- | --- | --- | --- | --- | --- | --- | --- | --- | --- | --- | --- | --- | --- | --- | --- | --- |
| 1544 | 1.2.16.3.1.4 | **اجرای تراز +14** | 36d | 2016-03-30 | 2016-05-04 |  |  |  |  | 28d |  |  | 493h | 0% | 29 روز | 47 |  |
| 1545 | 1.2.16.3.1.4.1 | آرماتوربندی | 15d | 2016-03-30 | 2016-04-13 | 1543 |  |  |  | 28d | 0d |  | 177h | 0% | 10 روز | 16 | 10 |
| 1546 | 1.2.16.3.1.4.2 | نصب تمامی بیس پلیت ها و انتظارها | 5d | 2016-04-14 | 2016-04-18 | 1545 |  |  |  | 28d | 0d |  | 47.5h | 0% | 4 روز |  |  |
| 1547 | 1.2.16.3.1.4.3 | قالب بندی | 15d | 2016-04-19 | 2016-05-03 | 1546 |  |  |  | 119d | 0d | start no earlier than 2015-11-06 | 227h | 0% | 12 روز | 22 | 12 |
| 1548 | 1.2.16.3.1.4.4 | بتن ریزی | 1d | 2016-05-04 | 2016-05-04 | 1547 |  |  |  | 119d |  |  | 41.5h | 0% | 3 روز |  |  |
| 1549 | 1.2.16.3.2 | **تیر ریزی و نصب خرپاها** | 33d | 2016-04-19 | 2016-05-21 |  |  |  |  | 28d |  |  | 518h | 0% | 38 روز | 36 |  |
| 1550 | 1.2.16.3.2.1 | ساخت و نصب تیر ریزی تراز 10.50 | 7d | 2016-04-19 | 2016-04-25 | 1546 |  |  |  | 28d | 0d |  | 227h | 0% | 10 روز | 22 | 15 |
| 1551 | 1.2.16.3.2.2 | ساخت خرپا | 20d | 2016-04-19 | 2016-05-08 | 1550SS |  |  |  | 28d | 0d |  | 165h | 0% | 25 روز | 22 | 30 |
| 1552 | 1.2.16.3.2.3 | نصب خرپاها | 5d | 2016-05-09 | 2016-05-13 | 1551 |  |  |  | 28d | 0d |  | 22.5h | 0% | 5 روز |  |  |
| 1553 | 1.2.16.3.2.4 | تیر ریزی اتاق ها | 3d | 2016-05-14 | 2016-05-16 | 1552 |  |  |  | 28d | 0d |  | 58.5h | 0% | 3 روز |  |  |
| 1554 | 1.2.16.3.2.5 | نصب پایه ها و اسکلت اتاقک انتظامات | 5d | 2016-05-17 | 2016-05-21 | 1553 |  |  |  | 28d | 0d |  | 45h | 0% | 5 روز |  |  |
| 1555 | 1.2.16.4 | **سفت کاری** | 19d | 2016-05-17 | 2016-06-04 |  | 2016-06-27 | 2016-08-15 | 42.38d | 33d |  |  | 548.5h | 0% |  | 35 |  |
| 1556 | 1.2.16.4.1 | پخش و نصب ورق ها | 3d | 2016-05-22 | 2016-05-24 | 1554 | 2016-06-27 | 2016-07-03 | 5.75d | 28d | 0d |  | 46h | 0% |  |  |  |
| 1557 | 1.2.16.4.2 | جوش دادن گل میخ ها | 2d | 2016-05-25 | 2016-05-26 | 1556 | 2016-07-03 | 2016-07-06 | 2.81d | 28d | 0d |  | 22.5h | 0% |  |  |  |
| 1558 | 1.2.16.4.3 | آرماتوربندی سقف | 4d | 2016-05-27 | 2016-05-30 | 1557 | 2016-07-06 | 2016-07-12 | 4.94d | 28d | 0d |  | 39.5h | 0% |  |  |  |
| 1559 | 1.2.16.4.4 | بتن ریزی سقف | 1d | 2016-05-31 | 2016-05-31 | 1558 | 2016-07-12 | 2016-07-16 | 3.38d | 28d | 0d |  | 27h | 0% |  |  |  |
| 1560 | 1.2.16.4.5 | اجرا دیوار های جان پناه | 3d | 2016-06-01 | 2016-06-03 | 1559 | 2016-07-17 | 2016-08-02 | 14.12d | 28d | 0d |  | 113h | 0% |  |  |  |
| 1561 | 1.2.16.4.6 | ساخت در اصلی و نرده ها | 15d | 2016-05-17 | 2016-05-31 | 1554SS | 2016-07-09 | 2016-08-10 | 28.5d | 88d | 0d |  | 228h | 0% |  | 22 | 15 |
| 1562 | 1.2.16.4.7 | اجرای سقف اتاقک نگهبانی | 3d | 2016-05-22 | 2016-05-24 | 1556SS | 2016-07-14 | 2016-07-21 | 5.31d | 99d |  |  | 42.5h | 0% |  |  |  |
| 1563 | 1.2.16.4.8 | نصب در اصلی و نرده ها | 4d | 2016-06-01 | 2016-06-04 | 1561 | 2016-08-10 | 2016-08-15 | 3.75d | 88d |  |  | 30h | 0% |  |  |  |
| 1564 | 1.2.16.5 | **نازک کاری** | 61d | 2016-06-04 | 2016-08-03 |  | 2016-08-02 | 2016-10-10 | 59d | 28d |  |  | 575h | 0% |  | 46 |  |
| 1565 | 1.2.16.5.1 | کروم بندی و شیب بندی بام | 3d | 2016-06-04 | 2016-06-06 | 1560 | 2016-08-02 | 2016-08-06 | 3.75d | 28d | 0d |  | 30h | 0% |  |  |  |
| 1566 | 1.2.16.5.2 | اجرای بتن سبک شیب بندی بام | 3d | 2016-06-07 | 2016-06-09 | 1565 | 2016-08-06 | 2016-08-21 | 12.94d | 28d | 0d |  | 103.5h | 0% |  | 10 |  |
| 1567 | 1.2.16.5.3 | اجرای سیمانکاری لیسه ای زیرعایق | 2d | 2016-06-10 | 2016-06-11 | 1566 | 2016-08-21 | 2016-08-22 | 1d | 28d | 0d |  | 8h | 0% |  |  |  |
| 1568 | 1.2.16.5.4 | اجرای عایق بام | 2d | 2016-06-12 | 2016-06-13 | 1567 | 2016-08-21 | 2016-08-22 | 1d | 28d | 0d |  | 8h | 0% |  |  |  |
| 1569 | 1.2.16.5.5 | اجرای موزاییک درجه یک ایرانی 4*30*30 بام | 4d | 2016-06-14 | 2016-06-17 | 1568 | 2016-08-22 | 2016-09-05 | 12d | 28d | 0d |  | 95h | 0% |  | 12 |  |
| 1570 | 1.2.16.5.6 | اجرای سنگ کف | 4d | 2016-07-11 | 2016-07-14 | 1574 | 2016-08-22 | 2016-08-29 | 5.62d | 28d | 0d |  | 45h | 0% |  |  |  |
| 1571 | 1.2.16.5.7 | اجرای قرنیز | 3d | 2016-06-18 | 2016-06-20 | 1569 | 2016-08-29 | 2016-09-04 | 4.62d | 28d | 0d |  | 37h | 0% |  |  |  |
| 1572 | 1.2.16.5.8 | اجرای اندود گچ و خاک | 10d | 2016-06-21 | 2016-06-30 | 1571 | 2016-09-04 | 2016-09-13 | 8.12d | 28d | 0d |  | 65h | 0% |  |  | 10 |
| 1573 | 1.2.16.5.9 | اجرای روکش دو گچه پرداختی | 6d | 2016-07-01 | 2016-07-06 | 1572 | 2016-09-13 | 2016-09-19 | 5.06d | 28d | 0d |  | 40.5h | 0% |  |  |  |
| 1574 | 1.2.16.5.10 | اجرای کناف اتاقها | 4d | 2016-07-07 | 2016-07-10 | 1572, 1573 | 2016-09-19 | 2016-09-26 | 5.88d | 28d | 0d |  | 47h | 0% |  |  |  |
| 1575 | 1.2.16.5.11 | نصب در و پنجره ها | 5d | 2016-07-15 | 2016-07-19 | 1570 | 2016-09-26 | 2016-09-28 | 2.81d | 28d | 0d |  | 22.5h | 0% |  |  |  |
| 1576 | 1.2.16.5.12 | اجرای رنگ روغن مات | 15d | 2016-07-20 | 2016-08-03 | 1575 | 2016-09-28 | 2016-10-10 | 9.19d | 28d |  |  | 73.5h | 0% |  |  | 10 |

| ID | WBS | Task | Duration | Start | Finish | Predecessors | Baseline start | Baseline finish | Baseline duration | Total slack | Free slack | Constraint | Work | Text1 | Text20 | Text22 | Text4 | Text5 |
| --- | --- | --- | --- | --- | --- | --- | --- | --- | --- | --- | --- | --- | --- | --- | --- | --- | --- | --- |
| 1577 | 1.2.17 | **ساختمان مهمانسرا** | 409d | 2015-07-01 | 2016-08-12 |  | 2015-06-29 | 2017-07-26 | 651d | 19d |  |  | 4102h | 4% | 471 | 471 |  |  |
| 1578 | 1.2.17.1 | ابلاغ نقشه های فصل مشترک | 1d | 2015-07-01 | 2015-07-01 |  | 2015-09-19 | 2015-09-19 | 0d | 25.38d | 0d | start no earlier than 2015-07-01 | 7.5h | 100% |  |  | 1 روز | 1 روز |
| 1579 | 1.2.17.2 | **آماده سازی زمین** | 12d | 2015-07-02 | 2015-07-13 |  | 2015-06-29 | 2015-07-12 | 12d | 25.38d |  |  | 96h | 100% |  | 12 |  |  |
| 1580 | 1.2.17.2.1 | نقشه برداري | 1d | 2015-07-02 | 2015-07-02 | 1578 | 2015-06-29 | 2015-06-29 | 1d | 25.38d | 0d |  | 8h | 100% |  |  |  |  |
| 1581 | 1.2.17.2.2 | پياده كردن كروكي ساختمان | 1d | 2015-07-03 | 2015-07-03 | 1580 | 2015-06-30 | 2015-06-30 | 1d | 25.38d | 0d | start no earlier than 2015-07-03 | 8h | 100% |  |  |  |  |
| 1582 | 1.2.17.2.3 | پی کنی | 10d | 2015-07-04 | 2015-07-13 | 1581 | 2015-07-01 | 2015-07-12 | 10d | 25.38d | 0d |  | 80h | 100% |  | 10 |  |  |
| 1583 | 1.2.17.3 | **اجرای سازه** | 282d | 2015-07-14 | 2016-04-20 |  | 2015-07-13 | 2016-07-16 | 316.31d | 25.38d |  |  | 3566.5h | 18% |  | 225 |  |  |
| 1584 | 1.2.17.3.1 | **اجرای فونداسیون** | 58d | 2015-07-14 | 2015-09-09 |  | 2015-07-13 | 2015-11-05 | 99.69d | 19d |  |  | 495.5h | 86% |  | 45 |  |  |
| 1585 | 1.2.17.3.1.1 | پیاده سازی ، رگلاژ و تسطیح به همراه (توقف تا تعیین تکلیف مشکلات چاله اسانسور) | 10d | 2015-07-14 | 2015-07-23 | 1582 | 2015-07-13 | 2015-09-02 | 10d | 25.38d | 0d |  | 80h | 100% |  | 10 |  |  |
| 1586 | 1.2.17.3.1.2 | بتن مگر | 5d | 2015-07-24 | 2015-07-28 | 1585 | 2015-09-03 | 2015-09-17 | 10.81d | 25.38d | 0d |  | 86.5h | 100% |  |  |  |  |
| 1587 | 1.2.17.3.1.3 | آرماتور بندی فونداسیون و نصب صفحه ستون ها | 20d | 2015-07-29 | 2015-08-18 | 1586 | 2015-09-17 | 2015-10-12 | 20.44d | 25.38d | 6.38d |  | 163.5h | 100% |  | 15 |  |  |
| 1588 | 1.2.17.3.1.4 | قالب بندی | 10d | 2015-08-25 | 2015-09-03 | 1587 | 2015-10-12 | 2015-10-19 | 6d | 19d | 0d | start no earlier than 2015-08-25 | 48h | 100% |  |  |  |  |
| 1589 | 1.2.17.3.1.5 | بتن ریزی | 3d | 2015-09-04 | 2015-09-06 | 1588 | 2015-10-19 | 2015-10-26 | 6.25d | 19d | 0d |  | 50h | 100% |  |  |  |  |
| 1590 | 1.2.17.3.1.6 | قلوه ریزی بین چشمه های فونداسیون | 3d | 2015-09-07 | 2015-09-09 | 1589 | 2015-10-26 | 2015-11-05 | 9d | 19d | 0d |  | 67.5h | 0% |  |  |  |  |
| 1591 | 1.2.17.3.2 | **اجرای اسکلت فلزی** | 107d | 2015-11-27 | 2016-03-12 |  | 2015-11-05 | 2016-06-07 | 183.75d | 19d |  |  | 2458h | 9% |  | 147 |  |  |
| 1592 | 1.2.17.3.2.1 | **اجرای ستون** | 95d | 2015-11-27 | 2016-02-29 |  | 2015-11-05 | 2016-03-06 | 103.56d | 19d |  |  | 828.5h | 27% |  | 87 |  |  |
| 1593 | 1.2.17.3.2.1.1 | ساخت ستون ها | 35d | 2015-11-27 | 2015-12-31 | 1590FS+78d | 2015-11-05 | 2015-12-22 | 40d | 19d | 0d |  | 320h | 70% |  | 40 |  |  |
| 1594 | 1.2.17.3.2.1.2 | جوشکاری و نصب اتصالات زیر سری تیر ها | 25d | 2016-01-01 | 2016-01-25 | 1593 | 2015-12-22 | 2016-01-17 | 21.56d | 19d | 0d |  | 172.5h | 0% |  | 14 |  |  |
| 1595 | 1.2.17.3.2.1.3 | جوشکاری اتصالات بادبند | 25d | 2016-01-26 | 2016-02-19 | 1594 | 2016-01-17 | 2016-02-09 | 20d | 19d | 0d |  | 160h | 0% |  | 10 |  |  |
| 1596 | 1.2.17.3.2.1.4 | نصب ستون ها | 10d | 2016-02-20 | 2016-02-29 | 1595 | 2016-02-09 | 2016-03-06 | 22d | 19d | 0d |  | 176h | 0% |  | 23 |  |  |
| 1597 | 1.2.17.3.2.2 | **تیر ریزی** | 72d | 2016-01-01 | 2016-03-12 |  | 2015-12-22 | 2016-06-07 | 143.75d | 79d |  |  | 1629.5h | 0% |  | 107 |  |  |
| 1598 | 1.2.17.3.2.2.1 | ساخت و مونتاژ تیر ورق ها | 30d | 2016-01-01 | 2016-01-30 | 1593 | 2015-12-22 | 2016-03-26 | 80.06d | 197d | 0d |  | 640.5h | 0% |  | 62 |  |  |
| 1599 | 1.2.17.3.2.2.2 | ساخت و مونتاژ تیر های حمال و تو دلی | 10d | 2016-01-31 | 2016-02-09 | 1598 | 2016-03-26 | 2016-05-01 | 30.69d | 197d | 0d |  | 245.5h | 0% |  | 23 |  |  |
| 1600 | 1.2.17.3.2.2.3 | ساخت و مونتاژ تیر های پله | 7d | 2016-02-10 | 2016-02-16 | 1599 | 2016-05-01 | 2016-05-18 | 14.5d | 197d |  |  | 116h | 0% |  | 10 |  |  |
| 1601 | 1.2.17.3.2.2.4 | تیر ریزی طبقه همکف | 2d | 2016-03-01 | 2016-03-02 | 1596 | 2016-03-06 | 2016-04-09 | 28.88d | 19d | 0d |  | 231h | 0% |  | 22 |  |  |
| 1602 | 1.2.17.3.2.2.5 | تیر ریزی طبقه اول | 3d | 2016-03-03 | 2016-03-05 | 1601 | 2016-04-09 | 2016-05-12 | 28.88d | 19d | 0d |  | 231h | 0% |  | 22 |  |  |
| 1603 | 1.2.17.3.2.2.6 | تیر ریزی بام | 4d | 2016-03-06 | 2016-03-09 | 1602 | 2016-05-14 | 2016-05-31 | 15.06d | 19d | 0d |  | 120.5h | 0% |  | 12 |  |  |
| 1604 | 1.2.17.3.2.2.7 | نصب تیر های پله | 3d | 2016-03-10 | 2016-03-12 | 1603 | 2016-05-31 | 2016-06-07 | 5.62d | 19d | 0d |  | 45h | 0% |  |  |  |  |

Notes:
- 1585: به دلی فقدان جزییت چاله آسانسور و تغییات اعمالی مشاور در نقشه ها ، 34 روز پروژه متوقف شده است
- 1594: ( توقف 10 روزه تا تعیی تکلی ایادات کلی در اتصالات اسکلت ساختمان مهمانسرا ) که با توجه به زمان شروع آیم تاثیی در روند پروژه نداشته است

| ID | WBS | Task | Duration | Start | Finish | Predecessors | Baseline start | Baseline finish | Baseline duration | Total slack | Free slack | Constraint | Work | Text1 | Text22 | Text4 | Text5 |
| --- | --- | --- | --- | --- | --- | --- | --- | --- | --- | --- | --- | --- | --- | --- | --- | --- | --- |
| 1605 | 1.2.17.3.3 | **اجرای سقف** | 39d | 2016-03-13 | 2016-04-20 |  | 2016-06-07 | 2016-07-16 | 32.88d | 19d |  |  | 613h | 0% | 18 |  |  |
| 1606 | 1.2.17.3.3.1 | **سقف طبقه همکف** | 5d | 2016-03-13 | 2016-03-17 |  | 2016-06-07 | 2016-07-06 | 24.88d | 19d |  |  | 199h | 0% | 14 |  |  |
| 1607 | 1.2.17.3.3.1.1 | برش کاری و نصب و پانچ ورقهای متال | 2d | 2016-03-13 | 2016-03-14 | 1604 | 2016-06-07 | 2016-06-15 | 6.88d | 19d | 0d | start no earlier than 2015-11-22 | 55h | 0% |  |  |  |
| 1608 | 1.2.17.3.3.1.2 | جوشکاری گل میخ ها | 1d | 2016-03-15 | 2016-03-15 | 1607 | 2016-06-15 | 2016-06-22 | 6d | 19d | 0d | start no earlier than 2015-11-28 | 48h | 0% |  |  |  |
| 1609 | 1.2.17.3.3.1.3 | آرماتور بندی | 1d | 2016-03-16 | 2016-03-16 | 1608 | 2016-06-22 | 2016-06-29 | 6d | 19d | 0d | start no earlier than 2015-12-04 | 48h | 0% |  |  |  |
| 1610 | 1.2.17.3.3.1.4 | بتن ریزی | 1d | 2016-03-17 | 2016-03-17 | 1609 | 2016-06-29 | 2016-07-06 | 6d | 19d | 0d |  | 48h | 0% |  |  |  |
| 1611 | 1.2.17.3.3.2 | **سقف طبقه اول** | 5d | 2016-03-28 | 2016-04-01 |  | 2016-06-07 | 2016-07-11 | 28.88d | 19d |  |  | 183h | 0% | 16 |  |  |
| 1612 | 1.2.17.3.3.2.1 | برش کاری و نصب و پانچ ورقهای متال | 2d | 2016-03-28 | 2016-03-29 | 1610FS+10d | 2016-06-07 | 2016-06-15 | 6.88d | 19d | 0d | start no earlier than 2015-11-22 | 55h | 0% |  |  |  |
| 1613 | 1.2.17.3.3.2.2 | جوشکاری گل میخ ها | 1d | 2016-03-30 | 2016-03-30 | 1612 | 2016-06-15 | 2016-06-22 | 6d | 19d | 0d |  | 48h | 0% |  |  |  |
| 1614 | 1.2.17.3.3.2.3 | آرماتور بندی | 1d | 2016-03-31 | 2016-03-31 | 1613 | 2016-06-22 | 2016-06-29 | 6d | 19d | 0d |  | 48h | 0% |  |  |  |
| 1615 | 1.2.17.3.3.2.4 | بتن ریزی | 1d | 2016-04-01 | 2016-04-01 | 1614 | 2016-07-06 | 2016-07-11 | 4d | 19d | 0d | start no earlier than 2015-12-11 | 32h | 0% |  |  |  |
| 1616 | 1.2.17.3.3.3 | **سقف طبقه دوم** | 5d | 2016-04-12 | 2016-04-16 |  | 2016-06-07 | 2016-07-16 | 32.88d | 43d |  |  | 183h | 0% | 18 |  |  |
| 1617 | 1.2.17.3.3.3.1 | برش کاری و نصب و پانچ ورقهای متال | 2d | 2016-04-12 | 2016-04-13 | 1615FS+10d | 2016-06-07 | 2016-06-15 | 6.88d | 43d | 0d | start no earlier than 2015-11-22 | 55h | 0% |  |  |  |
| 1618 | 1.2.17.3.3.3.2 | جوشکاری گل میخ ها | 1d | 2016-04-14 | 2016-04-14 | 1617 | 2016-06-15 | 2016-06-22 | 6d | 43d | 0d | start no earlier than 2015-11-30 | 48h | 0% |  |  |  |
| 1619 | 1.2.17.3.3.3.3 | آرماتور بندی | 1d | 2016-04-15 | 2016-04-15 | 1618 | 2016-06-22 | 2016-06-29 | 6d | 43d | 0d |  | 48h | 0% |  |  |  |
| 1620 | 1.2.17.3.3.3.4 | بتن ریزی | 1d | 2016-04-16 | 2016-04-16 | 1619 | 2016-07-11 | 2016-07-16 | 4d | 137d |  | start no earlier than 2015-12-14 | 32h | 0% |  |  |  |
| 1621 | 1.2.17.3.3.4 | **خرپشته** | 5d | 2016-04-16 | 2016-04-20 |  | 2016-06-07 | 2016-06-14 | 6d | 43d |  |  | 48h | 0% |  |  |  |
| 1622 | 1.2.17.3.3.4.1 | برش کاری و نصب و پانچ ورقهای متال | 2d | 2016-04-16 | 2016-04-17 | 1619 | 2016-06-07 | 2016-06-11 | 3d | 43d | 0d |  | 24h | 0% |  |  |  |
| 1623 | 1.2.17.3.3.4.2 | جوشکاری گل میخ ها | 1d | 2016-04-18 | 2016-04-18 | 1622 | 2016-06-11 | 2016-06-12 | 1d | 43d | 0d |  | 8h | 0% |  |  |  |
| 1624 | 1.2.17.3.3.4.3 | آرماتور بندی | 1d | 2016-04-19 | 2016-04-19 | 1623 | 2016-06-12 | 2016-06-13 | 1d | 43d | 0d | start no earlier than 2015-11-26 | 8h | 0% |  |  |  |
| 1625 | 1.2.17.3.3.4.4 | بتن ریزی | 1d | 2016-04-20 | 2016-04-20 | 1624 | 2016-06-13 | 2016-06-14 | 1d | 43d | 0d | start no earlier than 2015-11-27 | 8h | 0% |  |  |  |
| 1626 | 1.2.17.4 | **سفت کاری** | 41d | 2016-04-02 | 2016-05-12 |  | 2015-12-27 | 2016-06-22 | 0d | 19d |  |  |  | 48% |  | 142 روز | 142 روز |
| 1627 | 1.2.17.4.1 | **طبقه همکف** | 25d | 2016-04-02 | 2016-04-26 |  | 2015-12-27 | 2016-01-25 | 0d | 127d |  |  |  | 60% |  | 26 روز | 26 روز |
| 1628 | 1.2.17.4.1.1 | اجرای دیوارهای پیرامونی | 10d | 2016-04-02 | 2016-04-11 | 1615 |  |  |  | 127d | 0d |  |  |  |  |  |  |
| 1629 | 1.2.17.4.1.2 | ساخت و نصب نعل درگاه های پیرامونی | 10d | 2016-04-02 | 2016-04-11 | 1628SS |  |  |  | 137d | 0d |  |  |  |  |  |  |
| 1630 | 1.2.17.4.1.3 | ساخت فریم و چارچوب در و پنجره ها | 5d | 2016-04-02 | 2016-04-06 | 1629SS |  |  |  | 137d | 0d |  |  |  |  |  |  |
| 1631 | 1.2.17.4.1.4 | ساخت درهای فولادی | 10d | 2016-04-07 | 2016-04-16 | 1630 |  |  |  | 137d |  |  |  |  |  |  |  |
| 1632 | 1.2.17.4.1.5 | اجرای بلوکاژ | 5d | 2016-04-12 | 2016-04-16 | 1629 |  |  |  | 137d |  |  |  |  |  |  |  |
| 1633 | 1.2.17.4.1.6 | اجرای دیوار جداکننده داخلی | 5d | 2016-04-12 | 2016-04-16 | 1628 |  |  |  | 127d | 0d |  |  |  |  |  |  |
| 1634 | 1.2.17.4.1.7 | ساخت و نصب نعل درگاه های داخلی | 5d | 2016-04-12 | 2016-04-16 | 1633SS |  |  |  | 137d |  |  |  |  |  |  |  |
| 1635 | 1.2.17.4.1.8 | اجرای گچ و خاک دیوارها | 10d | 2016-04-17 | 2016-04-26 | 1633 |  |  |  | 127d |  |  |  |  |  |  |  |

| ID | WBS | Task | Duration | Start | Finish | Predecessors | Total slack | Free slack |
| --- | --- | --- | --- | --- | --- | --- | --- | --- |
| 1636 | 1.2.17.4.2 | **طبقه اول** | 22d | 2016-04-02 | 2016-04-23 |  | 19d |  |
| 1637 | 1.2.17.4.2.1 | اجرای دیوارهای پیرامونی | 5d | 2016-04-02 | 2016-04-06 | 1615 | 19d | 0d |
| 1638 | 1.2.17.4.2.2 | ساخت و نصب نعل درگاه های پیرامونی | 2d | 2016-04-02 | 2016-04-03 | 1637SS | 130d | 0d |
| 1639 | 1.2.17.4.2.3 | اجرای دیوار جداکننده داخلی | 5d | 2016-04-04 | 2016-04-08 | 1638 | 130d | 0d |
| 1640 | 1.2.17.4.2.4 | ساخت و نصب نعل درگاه های داخلی | 2d | 2016-04-04 | 2016-04-05 | 1639SS | 148d |  |
| 1641 | 1.2.17.4.2.5 | اجرای گچ و خاک دیوارها | 15d | 2016-04-09 | 2016-04-23 | 1639 | 130d |  |
| 1642 | 1.2.17.4.3 | **طبقه دوم** | 22d | 2016-04-21 | 2016-05-12 |  | 43d |  |
| 1643 | 1.2.17.4.3.1 | اجرای دیوارهای پیرامونی | 5d | 2016-04-21 | 2016-04-25 | 1625 | 43d | 0d |
| 1644 | 1.2.17.4.3.2 | ساخت و نصب نعل درگاه های پیرامونی | 2d | 2016-04-21 | 2016-04-22 | 1643SS | 43d | 0d |
| 1645 | 1.2.17.4.3.3 | اجرای دیوار جداکننده داخلی | 5d | 2016-04-23 | 2016-04-27 | 1644 | 111d | 0d |
| 1646 | 1.2.17.4.3.4 | ساخت و نصب نعل درگاه های داخلی | 2d | 2016-04-21 | 2016-04-22 | 1644SS | 43d | 0d |
| 1647 | 1.2.17.4.3.5 | اجرای گچ و خاک دیوارها | 15d | 2016-04-28 | 2016-05-12 | 1645 | 111d |  |
| 1648 | 1.2.17.5 | **بام ( مرحله اول )** | 20d | 2016-04-23 | 2016-05-12 |  | 43d |  |
| 1649 | 1.2.17.5.1 | اجرای دیوار جان پناه پشت بام و خرپشته | 6d | 2016-04-23 | 2016-04-28 | 1646 | 43d | 0d |
| 1650 | 1.2.17.5.2 | سیمانکاری دیوار جانپناه | 4d | 2016-04-29 | 2016-05-02 | 1649 | 111d | 0d |
| 1651 | 1.2.17.5.3 | رابیتس بندی | 10d | 2016-05-03 | 2016-05-12 | 1650 | 111d |  |
| 1652 | 1.2.17.6 | **اجرای نمای بیرونی** | 82d | 2016-04-29 | 2016-07-19 |  | 43d |  |
| 1653 | 1.2.17.6.1 | اجرای سنگ پلاک نما به همراه فتیله | 7d | 2016-04-29 | 2016-05-05 | 1649 | 43d | 0d |
| 1654 | 1.2.17.6.2 | اجرای سنگ باکس تیر ها و ستون ها | 45d | 2016-05-06 | 2016-06-19 | 1653 | 43d | 0d |
| 1655 | 1.2.17.6.3 | اجرای سنگ پیش آمدگی ها | 30d | 2016-06-20 | 2016-07-19 | 1654 | 43d |  |
| 1656 | 1.2.17.6.4 | اجرای آستر سیمان سیاه دیوار جهت زیر سازی نمای شسته | 40d | 2016-04-29 | 2016-06-07 | 1653SS | 45d | 0d |
| 1657 | 1.2.17.6.5 | اجرای نمای شسته | 60d | 2016-05-09 | 2016-07-07 | 1656SS+10d | 45d | 0d |
| 1658 | 1.2.17.6.6 | اجرای درپوش بتنی جانپناه و کف پنجره ها | 10d | 2016-07-08 | 2016-07-17 | 1657 | 45d |  |
| 1659 | 1.2.17.7 | **تاسیسات مکانیکی ( مرحله اول )** | 50d | 2016-04-02 | 2016-05-21 |  | 19d |  |
| 1660 | 1.2.17.7.1 | سوراخکاری و شیارزنی و کنده کاری داکت | 4d | 2016-04-02 | 2016-04-05 | 1637SS | 19d | 0d |
| 1661 | 1.2.17.7.2 | کانال کنی تاسیسات | 5d | 2016-04-02 | 2016-04-06 | 1660SS | 19d | 0d |
| 1662 | 1.2.17.7.3 | لوله کشی پلی اتیلن فاضلاب و آب باران | 10d | 2016-04-07 | 2016-04-16 | 1661 | 19d | 0d |
| 1663 | 1.2.17.7.4 | ساپورتهای لوله کشی تاسیسات | 5d | 2016-04-07 | 2016-04-11 | 1662SS | 132d | 0d |
| 1664 | 1.2.17.7.5 | لوله کشی گالوانیزه آب سرد و گرم | 10d | 2016-04-12 | 2016-04-21 | 1663 | 132d |  |
| 1665 | 1.2.17.7.6 | لوله کشی لوله های گرمایشی و پنج لایه | 20d | 2016-04-17 | 2016-05-06 | 1662 | 68d | 0d |
| 1666 | 1.2.17.7.7 | اجرای ساپورتهای کانال کولر | 5d | 2016-04-17 | 2016-04-21 | 1662 | 102d | 0d |
| 1667 | 1.2.17.7.8 | اجرای کانال کولر | 30d | 2016-04-22 | 2016-05-21 | 1666 | 102d | 0d |
| 1668 | 1.2.17.7.9 | اجرای کانال اگزاست | 20d | 2016-04-22 | 2016-05-11 | 1667SS | 105d | 0d |
| 1669 | 1.2.17.7.10 | عایق پشم شیشه و تست | 5d | 2016-05-07 | 2016-05-11 | 1665 | 112d |  |
| 1670 | 1.2.17.7.11 | اجرای لوله هایPVC | 2d | 2016-04-07 | 2016-04-08 | 1662SS | 19d | 0d |
| 1671 | 1.2.17.7.12 | عملیات شاسی کشی و آهن کاری آسانسور | 7d | 2016-05-12 | 2016-05-18 | 1668 | 105d |  |

| ID | WBS | Task | Duration | Start | Finish | Predecessors | Total slack | Free slack |
| --- | --- | --- | --- | --- | --- | --- | --- | --- |
| 1672 | 1.2.17.8 | **تاسیسات الکتریکی ( مرحله اول )** | 35d | 2016-04-02 | 2016-05-06 |  | 117d |  |
| 1673 | 1.2.17.8.1 | شیارزنی | 20d | 2016-04-02 | 2016-04-21 | 1637SS | 117d | 0d |
| 1674 | 1.2.17.8.2 | اجرای لوله های PVC . PG13/5 | 15d | 2016-04-22 | 2016-05-06 | 1673 | 117d | 0d |
| 1675 | 1.2.17.8.3 | اجرای لوله های PVC . PG16-42 | 15d | 2016-04-22 | 2016-05-06 | 1674SS | 117d | 0d |
| 1676 | 1.2.17.8.4 | تهیه ساخت و سفارش تابلو برق | 10d | 2016-04-02 | 2016-04-11 | 1673SS | 141d | 0d |
| 1677 | 1.2.17.8.5 | غلاف گزاری | 3d | 2016-04-22 | 2016-04-24 | 1675SS | 129d |  |
| 1678 | 1.2.17.8.6 | سینی کابل | 5d | 2016-04-22 | 2016-04-26 | 1668SS | 127d |  |
| 1679 | 1.2.17.8.7 | نصب تابلو | 1d | 2016-04-12 | 2016-04-12 | 1676 | 141d |  |
| 1680 | 1.2.17.9 | **بام ( مرحله دوم )** | 42d | 2016-04-09 | 2016-05-20 |  | 103d |  |
| 1681 | 1.2.17.9.1 | شیب بندی و اجرای بتن سبک بام | 5d | 2016-04-09 | 2016-04-13 | 1670 | 103d | 0d |
| 1682 | 1.2.17.9.2 | اجرای سیمانکاری لیسه ای زیر عایق | 2d | 2016-04-14 | 2016-04-15 | 1681 | 103d | 0d |
| 1683 | 1.2.17.9.3 | اجرای عایق پشت بام | 2d | 2016-04-16 | 2016-04-17 | 1682 | 103d | 0d |
| 1684 | 1.2.17.9.4 | نصب تور مرغی قبل از سنگ اندود | 1d | 2016-04-18 | 2016-04-18 | 1683 | 103d | 0d |
| 1685 | 1.2.17.9.5 | اجرای سنگ قرنیز لاشتر | 4d | 2016-04-19 | 2016-04-22 | 1684 | 103d | 0d |
| 1686 | 1.2.17.9.6 | اجرای آستر سیمان سیاه و سفید بام | 10d | 2016-04-23 | 2016-05-02 | 1685 | 103d | 0d |
| 1687 | 1.2.17.9.7 | شیب بندی و اجرای موزاییک بام | 15d | 2016-05-03 | 2016-05-17 | 1686 | 103d | 0d |
| 1688 | 1.2.17.9.8 | نصب قرنیز گالوانیزه بام | 3d | 2016-05-18 | 2016-05-20 | 1687 | 103d |  |
| 1689 | 1.2.17.10 | **نازک کاری** | 77d | 2016-04-09 | 2016-06-24 |  | 19d |  |
| 1690 | 1.2.17.10.1 | **طبقه همکف** | 36d | 2016-04-09 | 2016-05-14 |  | 19d |  |
| 1691 | 1.2.17.10.1.1 | اجرای کرم بندی و شیب بندی سرویسها و سالن غذاخوری | 4d | 2016-04-09 | 2016-04-12 | 1670 | 19d | 0d |
| 1692 | 1.2.17.10.1.2 | اجرای عایق رطوبتی سالن غذاخوری و سرویسها | 2d | 2016-04-13 | 2016-04-14 | 1691 | 109d | 0d |
| 1693 | 1.2.17.10.1.3 | اجرای سیمان محافظ روی عایق | 2d | 2016-04-15 | 2016-04-16 | 1692 | 137d |  |
| 1694 | 1.2.17.10.1.4 | چیدن دیوارهای داکت | 2d | 2016-04-09 | 2016-04-10 | 1691SS | 143d |  |
| 1695 | 1.2.17.10.1.5 | نصب چارچوبهای در و پنجره | 5d | 2016-04-09 | 2016-04-13 | 1691SS | 140d |  |
| 1696 | 1.2.17.10.1.6 | اجرای قرنیز و سنگ و پلاک فضای داخلی دیوارها | 10d | 2016-04-15 | 2016-04-24 | 1692 | 109d | 0d |
| 1697 | 1.2.17.10.1.7 | اجرای گچ سفید دیوارها | 15d | 2016-04-25 | 2016-05-09 | 1696 | 114d |  |
| 1698 | 1.2.17.10.1.8 | اجرای کاشی دیوار سرویسها | 20d | 2016-04-15 | 2016-05-04 | 1692 | 114d | 0d |
| 1699 | 1.2.17.10.1.9 | اجرای سرامیک کف | 5d | 2016-05-05 | 2016-05-09 | 1698 | 114d |  |
| 1700 | 1.2.17.10.1.10 | اجرای سنگ گرانیت و چینی و موزائیک کف | 10d | 2016-04-25 | 2016-05-04 | 1696 | 109d | 0d |
| 1701 | 1.2.17.10.1.11 | اجرای سقف کاذب ( کناف فضای داخلی ) | 10d | 2016-05-05 | 2016-05-14 | 1700 | 109d |  |
| 1702 | 1.2.17.10.1.12 | اجرای سقف کاذب ( سرویس بهداشتی ) | 4d | 2016-05-05 | 2016-05-08 | 1698 | 115d |  |

| ID | WBS | Task | Duration | Start | Finish | Predecessors | Baseline start | Baseline finish | Baseline duration | Total slack | Free slack | Work | Text1 | Text4 | Text5 | Text22 |
| --- | --- | --- | --- | --- | --- | --- | --- | --- | --- | --- | --- | --- | --- | --- | --- | --- |
| 1703 | 1.2.17.10.2 | **طبقه اول** | 33d | 2016-05-07 | 2016-06-08 |  |  |  |  | 68d |  |  |  |  |  |  |
| 1704 | 1.2.17.10.2.1 | نصب چارچوبهای در و پنجره | 3d | 2016-05-07 | 2016-05-09 | 1665 |  |  |  | 68d | 0d |  |  |  |  |  |
| 1705 | 1.2.17.10.2.2 | اجرای قرنیز و سنگ و پلاک فضای داخلی دیوارها | 10d | 2016-05-10 | 2016-05-19 | 1704 |  |  |  | 68d | 0d |  |  |  |  |  |
| 1706 | 1.2.17.10.2.3 | اجرای سنگ گرانیت کف | 5d | 2016-05-20 | 2016-05-24 | 1705 |  |  |  | 68d | 0d |  |  |  |  |  |
| 1707 | 1.2.17.10.2.4 | اجرای گچ سفید | 3d | 2016-05-20 | 2016-05-22 | 1705 |  |  |  | 101d |  |  |  |  |  |  |
| 1708 | 1.2.17.10.2.5 | اجرای سقف کاذب ( کناف فضای داخلی ) | 15d | 2016-05-25 | 2016-06-08 | 1706 |  |  |  | 84d |  |  |  |  |  |  |
| 1709 | 1.2.17.10.3 | **طبقه دوم** | 31d | 2016-05-25 | 2016-06-24 |  |  |  |  | 68d |  |  |  |  |  |  |
| 1710 | 1.2.17.10.3.1 | نصب چارچوبهای در و پنجره | 3d | 2016-05-25 | 2016-05-27 | 1706 |  |  |  | 68d | 0d |  |  |  |  |  |
| 1711 | 1.2.17.10.3.2 | اجرای قرنیز و سنگ و پلاک فضای داخلی دیوارها | 10d | 2016-05-28 | 2016-06-06 | 1710 |  |  |  | 68d | 0d |  |  |  |  |  |
| 1712 | 1.2.17.10.3.3 | اجرای سنگ گرانیت کف | 5d | 2016-06-07 | 2016-06-11 | 1711 |  |  |  | 68d | 0d |  |  |  |  |  |
| 1713 | 1.2.17.10.3.4 | اجرای گچ سفید | 3d | 2016-06-12 | 2016-06-14 | 1712 |  |  |  | 68d | 0d |  |  |  |  |  |
| 1714 | 1.2.17.10.3.5 | اجرای سقف کاذب ( کناف فضای داخلی ) | 10d | 2016-06-15 | 2016-06-24 | 1713 |  |  |  | 68d |  |  |  |  |  |  |
| 1715 | 1.2.17.10.4 | **راه پله** | 56d | 2016-04-09 | 2016-06-03 |  |  |  |  | 19d |  |  |  |  |  |  |
| 1716 | 1.2.17.10.4.1 | اجرای سنگ بدنه | 10d | 2016-04-09 | 2016-04-18 | 1691SS |  |  |  | 19d | 0d |  |  |  |  |  |
| 1717 | 1.2.17.10.4.2 | اجرای سنگ پله ها | 15d | 2016-04-19 | 2016-05-03 | 1716 |  |  |  | 19d | 0d |  |  |  |  |  |
| 1718 | 1.2.17.10.4.3 | اجرای رابتس زیر پله | 5d | 2016-05-04 | 2016-05-08 | 1717 |  |  |  | 19d | 0d |  |  |  |  |  |
| 1719 | 1.2.17.10.4.4 | اجرای گچ و خاک پله ها | 10d | 2016-05-09 | 2016-05-18 | 1718 |  |  |  | 19d | 0d |  |  |  |  |  |
| 1720 | 1.2.17.10.4.5 | اجرای گچ سفید | 10d | 2016-05-19 | 2016-05-28 | 1719 |  |  |  | 19d | 0d |  |  |  |  |  |
| 1721 | 1.2.17.10.4.6 | اجرای لگه گیری گچ سفید زیر و بغل پله | 6d | 2016-05-29 | 2016-06-03 | 1720 |  |  |  | 89d |  |  |  |  |  |  |
| 1722 | 1.2.17.10.5 | **نصبیات و تکمیلی نازک کاری** | 36d | 2016-05-19 | 2016-06-23 |  |  |  |  | 69d |  |  |  |  |  |  |
| 1723 | 1.2.17.10.5.1 | نصب در و پنجره های جوبی ، فولادی و UPVC | 8d | 2016-05-19 | 2016-05-26 | 1719 |  |  |  | 69d | 0d |  |  |  |  |  |
| 1724 | 1.2.17.10.5.2 | نصب شیشه ها | 8d | 2016-05-27 | 2016-06-03 | 1723 |  |  |  | 69d | 0d |  |  |  |  |  |
| 1725 | 1.2.17.10.5.3 | رنگ آمیزی سقف و دیوار | 20d | 2016-06-04 | 2016-06-23 | 1724 |  |  |  | 69d |  |  |  |  |  |  |
| 1726 | 1.2.17.11 | **تاسیسات الکتریکی ( مرحله دوم )** | 41d | 2016-05-29 | 2016-07-08 |  | 2016-01-05 | 2016-08-04 | 0d | 19d |  | 72h | 7% | 170 | 170 | 73 |
| 1727 | 1.2.17.11.1 | اجرای سیم کشی و کابل کشی ساختمان | 20d | 2016-05-29 | 2016-06-17 | 1720 |  |  |  | 19d | 0d |  |  |  |  |  |
| 1728 | 1.2.17.11.2 | کابل کشی مخابرات و تجهیزات مربوطه | 5d | 2016-06-18 | 2016-06-22 | 1727 |  |  |  | 65d | 0d |  |  |  |  |  |
| 1729 | 1.2.17.11.3 | اجرا و نصب تابلو برق و جریان ضعیف | 5d | 2016-06-23 | 2016-06-27 | 1728 |  |  |  | 65d |  |  |  |  |  |  |
| 1730 | 1.2.17.11.4 | کلید و پریز | 5d | 2016-06-18 | 2016-06-22 | 1727 |  |  |  | 19d | 0d |  |  |  |  |  |
| 1731 | 1.2.17.11.5 | چراغ های ایندور | 5d | 2016-06-23 | 2016-06-27 | 1730 |  |  |  | 19d | 0d |  |  |  |  |  |
| 1732 | 1.2.17.11.6 | سیستم اعلام حریق | 5d | 2016-06-28 | 2016-07-02 | 1731 |  |  |  | 19d | 0d |  |  |  |  |  |
| 1733 | 1.2.17.11.7 | سیستم آنتن مرکزی | 3d | 2016-07-03 | 2016-07-05 | 1732 |  |  |  | 19d | 0d |  |  |  |  |  |
| 1734 | 1.2.17.11.8 | ارت سازی | 3d | 2016-07-06 | 2016-07-08 | 1733 | 2016-01-05 | 2016-01-14 | 0d | 19d | 0d | 72h | 60% | 9 روز | 9 روز | 10 |

| ID | WBS | Task | Duration | Start | Finish | Predecessors | Baseline start | Baseline finish | Baseline duration | Total slack | Free slack | Constraint | Work | Text1 | Text4 | Text5 | Text22 | Text20 |
| --- | --- | --- | --- | --- | --- | --- | --- | --- | --- | --- | --- | --- | --- | --- | --- | --- | --- | --- |
| 1735 | 1.2.17.12 | **تاسیسات مکانیکی ( مرحله دوم )** | 35d | 2016-07-09 | 2016-08-12 |  |  |  |  | 19d |  |  | 360h |  |  |  |  |  |
| 1736 | 1.2.17.12.1 | شیر آلات بهداشتی | 5d | 2016-07-09 | 2016-07-13 | 1734 | 2016-01-28 | 2016-02-11 | 0d | 19d | 0d |  | 104h | 100% | 13 روز | 13 روز | 10 |  |
| 1737 | 1.2.17.12.2 | تجهیزات آتش نشانی | 4d | 2016-07-09 | 2016-07-12 | 1736SS |  |  |  | 50d |  |  |  |  |  |  |  |  |
| 1738 | 1.2.17.12.3 | نصب رادیاتور | 10d | 2016-07-09 | 2016-07-18 | 1736SS | 2016-02-13 | 2016-02-23 | 0d | 44d | 0d |  | 80h | 0% | 10 روز | 10 روز |  |  |
| 1739 | 1.2.17.12.4 | نصب دریچه های هوا و کولر | 3d | 2016-07-09 | 2016-07-11 | 1738SS | 2016-02-24 | 2016-04-03 | 0d | 51d |  |  | 176h | 0% | 22 روز | 22 روز | 12 |  |
| 1740 | 1.2.17.12.5 | عملیات نصبیات آسانسور ( کابین و سایر تجهیزات ) به همراه تست | 15d | 2016-07-09 | 2016-07-23 | 1736SS |  |  |  | 19d | 0d |  |  |  |  |  |  |  |
| 1741 | 1.2.17.12.6 | نصبیات موتورخانه | 35d | 2016-07-09 | 2016-08-12 | 1740SS |  |  |  | 19d |  |  |  |  |  |  |  |  |
| 1742 | 1.2.18 | **ساختمان ستاد فرماندهی** | 423d | 2015-07-01 | 2016-08-26 |  | 2015-05-20 | 2016-10-01 | 0d | 5d |  |  | 3028h | 37% | 349 روز | 417 روز | 296 | 296 |
| 1743 | 1.2.18.1 | ابلاغ نقشه های فصل مشترک | 1d | 2015-07-01 | 2015-07-01 |  |  |  |  | 380d | 0d | start no earlier than 2015-07-01 |  |  |  |  |  |  |
| 1744 | 1.2.18.2 | خاکبرداری | 5d | 2015-07-02 | 2015-07-06 | 1743 |  |  |  | 380d | 0d |  |  |  |  |  |  |  |
| 1745 | 1.2.18.3 | **اجرای سازه** | 397d | 2015-07-07 | 2016-08-06 |  | 2015-07-07 | 2016-10-18 | 0d | 25d |  |  | 2596h | 21% | 393 روز | 393 روز | 259 |  |
| 1746 | 1.2.18.3.1 | **اجرای فونداسیون** | 45d | 2015-07-07 | 2015-08-20 |  | 2015-07-07 | 2015-10-07 | 0d | 377d |  |  | 342.5h | 86% | 79 روز | 79 روز | 28 |  |
| 1747 | 1.2.18.3.1.1 | رگلاژ و تسطیح دستی | 2d | 2015-07-07 | 2015-07-08 | 1744 | 2015-07-07 | 2015-07-12 | 0d | 380d | 0d |  | 24h | 100% | 5 روز | 5 روز |  |  |
| 1748 | 1.2.18.3.1.2 | بتن مگر | 2d | 2015-07-09 | 2015-07-10 | 1747 | 2015-07-13 | 2015-07-16 | 0d | 380d | 0d | start no earlier than 2015-07-09 | 48h | 100% | 4 روز | 4 روز |  |  |
| 1749 | 1.2.18.3.1.3 | آرماتور بندی فونداسیون و اجرای ریشه های دیوار های برشی و ستون ها | 7d | 2015-07-11 | 2015-07-17 | 1748 | 2015-08-18 | 2015-09-10 | 0d | 380d | 0d |  | 104h | 100% | 20 روز | 20 روز | 10 |  |
| 1750 | 1.2.18.3.1.4 | توقف بدلیل تعیین تکلیف رمپ کناری ساختمان | 8d | 2015-07-18 | 2015-07-25 | 1749 | 2015-08-12 | 2015-08-18 | 0d | 380d | 0d |  | 40h | 100% | 5 روز | 5 روز |  |  |
| 1751 | 1.2.18.3.1.5 | قالب بندی | 15d | 2015-07-26 | 2015-08-09 | 1750 | 2015-09-10 | 2015-09-22 | 0d | 380d | 3d |  | 48h | 100% | 10 روز | 10 روز |  |  |
| 1752 | 1.2.18.3.1.6 | بتن ریزی | 3d | 2015-08-13 | 2015-08-15 | 1751 | 2015-09-22 | 2015-09-28 | 0d | 377d | 0d | start no earlier than 2015-08-13 | 24h | 100% | 5 روز | 5 روز |  |  |
| 1753 | 1.2.18.3.1.7 | قلوه ریزی بین چشمه های فونداسیون | 5d | 2015-08-16 | 2015-08-20 | 1752 | 2015-09-28 | 2015-10-07 | 0d | 377d |  | start no earlier than 2015-05-04 | 54.5h | 20% | 8 روز | 8 روز |  |  |
| 1754 | 1.2.18.3.2 | **اجرای اسکلت بتنی** | 345d | 2015-08-28 | 2016-08-06 |  | 2015-10-07 | 2016-10-18 | 0d | 25d |  |  | 2253.5h | 13% | 313 روز | 313 روز | 226 |  |
| 1755 | 1.2.18.3.2.1 | **زیر زمین** | 179d | 2015-08-28 | 2016-02-22 |  | 2015-10-07 | 2016-01-26 | 0d | 191d |  |  | 604.58h | 47% | 97 روز | 97 روز | 67 |  |
| 1756 | 1.2.18.3.2.1.1 | **اجرای ستون ها و دیوار های برشی زیر زمین** | 24d | 2015-08-28 | 2015-09-20 |  | 2015-10-07 | 2015-12-10 | 0d | 346d |  |  | 282.02h | 100% | 58 روز | 58 روز | 26 |  |
| 1757 | 1.2.18.3.2.1.1.1 | رفع ایرادات در نقشه ستونها و دیوارها | 10d | 2015-08-28 | 2015-09-06 |  | 2015-10-07 | 2015-10-13 | 0d | 346d | 0d | start no earlier than 2015-08-28 | 7.5h | 100% | 5 روز | 5 روز |  |  |
| 1758 | 1.2.18.3.2.1.1.2 | آرماتور بندی | 10d | 2015-09-07 | 2015-09-16 | 1757 | 2015-10-13 | 2015-11-05 | 0d | 346d | 0d | start no earlier than 2015-09-07 | 108.52h | 100% | 20 روز | 20 روز | 10 |  |
| 1759 | 1.2.18.3.2.1.1.3 | قالب بندی | 10d | 2015-09-07 | 2015-09-16 | 1758FS-10d | 2015-11-05 | 2015-11-23 | 0d | 346d | 0d |  | 105.02h | 100% | 15 روز | 15 روز | 10 |  |
| 1760 | 1.2.18.3.2.1.1.4 | بتن ریزی | 2d | 2015-09-17 | 2015-09-18 | 1759 | 2015-11-23 | 2015-12-03 | 0d | 346d | 0d | start no earlier than 2015-06-16 | 38.48h | 100% | 9 روز | 9 روز |  |  |
| 1761 | 1.2.18.3.2.1.1.5 | دکفراژ (قالب برداری) | 2d | 2015-09-19 | 2015-09-20 | 1760 | 2015-12-03 | 2015-12-10 | 0d | 346d |  |  | 22.5h | 100% | 6 روز | 6 روز |  |  |

| ID | WBS | Task | Duration | Start | Finish | Predecessors | Baseline start | Baseline finish | Baseline duration | Total slack | Free slack | Constraint | Work | Text1 | Text4 | Text5 | Text22 |
| --- | --- | --- | --- | --- | --- | --- | --- | --- | --- | --- | --- | --- | --- | --- | --- | --- | --- |
| 1762 | 1.2.18.3.2.1.2 | **اجرای سقف بتنی زیر زمین** | 18d | 2016-01-30 | 2016-02-16 |  | 2015-12-10 | 2016-01-14 | 0d | 34d |  |  | 205.02h | 0% | 31 روز | 31 روز | 27 |
| 1763 | 1.2.18.3.2.1.2.1 | آرماتور بندی | 8d | 2016-01-30 | 2016-02-06 |  | 2015-12-10 | 2015-12-22 | 0d | 37.94d | 0d | start no earlier than 2016-01-30 | 60h | 0% | 10 روز | 10 روز |  |
| 1764 | 1.2.18.3.2.1.2.2 | قالب بندی | 8d | 2016-02-02 | 2016-02-10 | 1763SS+3d | 2015-12-22 | 2016-01-02 | 0d | 37.94d | 3.94d | start no earlier than 2016-02-02 | 68h | 0% | 9 روز | 9 روز |  |
| 1765 | 1.2.18.3.2.1.2.3 | بتن ریزی | 1d | 2016-02-14 | 2016-02-14 | 1764 | 2016-01-02 | 2016-01-09 | 0d | 34d | 0d | start no earlier than 2016-02-14 | 47.02h | 0% | 5 روز | 5 روز |  |
| 1766 | 1.2.18.3.2.1.2.4 | دکفراژ (قالب برداری) | 2d | 2016-02-15 | 2016-02-16 | 1765 | 2016-01-09 | 2016-01-14 | 0d | 34d | 0d | start no earlier than 2015-10-07 | 30h | 0% | 5 روز | 5 روز |  |
| 1767 | 1.2.18.3.2.1.3 | **اجرای پله زیر زمین** | 6d | 2016-02-17 | 2016-02-22 |  | 2016-01-14 | 2016-01-26 | 0d | 34d |  |  | 117.54h | 0% | 10 روز | 10 روز | 14 |
| 1768 | 1.2.18.3.2.1.3.1 | آرماتور بندی | 3d | 2016-02-17 | 2016-02-19 | 1766 | 2016-01-14 | 2016-01-19 | 0d | 34d | 0d |  | 33.5h | 0% | 4 روز | 4 روز |  |
| 1769 | 1.2.18.3.2.1.3.2 | قالب بندی | 3d | 2016-02-18 | 2016-02-20 | 1768FS-2d | 2016-01-19 | 2016-01-23 | 0d | 34d | 0d | start no earlier than 2015-08-03 | 25h | 0% | 3 روز | 3 روز |  |
| 1770 | 1.2.18.3.2.1.3.3 | بتن ریزی | 1d | 2016-02-21 | 2016-02-21 | 1769 | 2016-01-23 | 2016-01-24 | 0d | 34d | 0d |  | 30h | 0% | 1 روز | 1 روز |  |
| 1771 | 1.2.18.3.2.1.3.4 | دکفراژ (قالب برداری) | 1d | 2016-02-22 | 2016-02-22 | 1770 | 2016-01-24 | 2016-01-26 | 0d | 34d | 0d |  | 29.04h | 0% | 2 روز | 2 روز |  |
| 1772 | 1.2.18.3.2.2 | **طبقه همکف** | 44d | 2016-02-23 | 2016-04-06 |  | 2016-01-14 | 2016-04-12 | 0d | 34d |  |  | 576.34h | 0% | 66روز | 66روز | 48 |
| 1773 | 1.2.18.3.2.2.1 | **اجرای ستون ها و دیوار های برشی طبقه همکف** | 19d | 2016-02-23 | 2016-03-12 |  | 2016-01-14 | 2016-02-24 | 0d | 34d |  |  | 277.92h | 0% | 37 روز | 37 روز | 26 |
| 1774 | 1.2.18.3.2.2.1.1 | قالب بندی | 10d | 2016-02-23 | 2016-03-03 | 1771 | 2016-01-14 | 2016-02-01 | 0d | 34d | 0d |  | 107.02h | 0% | 14 روز | 14 روز | 10 |
| 1775 | 1.2.18.3.2.2.1.2 | آرماتور بندی | 10d | 2016-02-28 | 2016-03-08 | 1774FS-5d | 2016-02-01 | 2016-02-13 | 0d | 34d | 0d | start no earlier than 2016-02-24 | 112.44h | 0% | 10 روز | 10 روز | 10 |
| 1776 | 1.2.18.3.2.2.1.3 | بتن ریزی | 2d | 2016-03-09 | 2016-03-10 | 1775 | 2016-02-13 | 2016-02-20 | 0d | 34d | 0d | start no earlier than 2015-09-16 | 35.96h | 0% | 6 روز | 6 روز |  |
| 1777 | 1.2.18.3.2.2.1.4 | دکفراژ (قالب برداری) | 2d | 2016-03-11 | 2016-03-12 | 1776 | 2016-02-20 | 2016-02-24 | 0d | 34d | 0d |  | 22.5h | 0% | 4 روز | 4 روز |  |
| 1778 | 1.2.18.3.2.2.2 | **اجرای سقف بتنی طبقه همکف** | 18d | 2016-03-13 | 2016-03-30 |  | 2016-02-24 | 2016-04-12 | 0d | 34d |  |  | 191.4h | 0% | 29 روز | 29 روز | 22 |
| 1779 | 1.2.18.3.2.2.2.1 | آرماتور بندی | 10d | 2016-03-13 | 2016-03-22 | 1777 | 2016-02-24 | 2016-03-07 | 0d | 34d | 0d |  | 75.48h | 0% | 10 روز | 10 روز |  |
| 1780 | 1.2.18.3.2.2.2.2 | قالب بندی | 10d | 2016-03-18 | 2016-03-27 | 1779FS-5d | 2016-03-07 | 2016-03-17 | 0d | 34d | 0d |  | 64.96h | 0% | 9 روز | 9 روز |  |
| 1781 | 1.2.18.3.2.2.2.3 | بتن ریزی | 1d | 2016-03-28 | 2016-03-28 | 1780 | 2016-03-17 | 2016-04-06 | 0d | 34d | 0d |  | 30h | 0% | 5 روز | 5 روز |  |
| 1782 | 1.2.18.3.2.2.2.4 | دکفراژ (قالب برداری) | 2d | 2016-03-29 | 2016-03-30 | 1781 | 2016-04-06 | 2016-04-12 | 0d | 34d | 0d |  | 20.96h | 0% | 5 روز | 5 روز |  |
| 1783 | 1.2.18.3.2.2.3 | **اجرای پله طبقه همکف** | 7d | 2016-03-31 | 2016-04-06 |  | 2016-02-24 | 2016-03-07 | 0d | 34d |  |  | 107.02h | 0% | 10 روز | 10 روز | 15 |
| 1784 | 1.2.18.3.2.2.3.1 | آرماتور بندی | 3d | 2016-03-31 | 2016-04-02 | 1782 | 2016-02-24 | 2016-02-29 | 0d | 34d | 0d |  | 47.52h | 0% | 4 روز | 4 روز |  |
| 1785 | 1.2.18.3.2.2.3.2 | قالب بندی | 3d | 2016-04-02 | 2016-04-04 | 1784FS-1d | 2016-02-29 | 2016-03-03 | 0d | 34d | 0d |  | 17h | 0% | 3 روز | 3 روز |  |
| 1786 | 1.2.18.3.2.2.3.3 | بتن ریزی | 1d | 2016-04-05 | 2016-04-05 | 1785 | 2016-03-03 | 2016-03-05 | 0d | 34d | 0d |  | 17h | 0% | 1 روز | 1 روز |  |
| 1787 | 1.2.18.3.2.2.3.4 | دکفراژ (قالب برداری) | 1d | 2016-04-06 | 2016-04-06 | 1786 | 2016-03-05 | 2016-03-07 | 0d | 34d | 0d |  | 25.5h | 0% | 2 روز | 2 روز |  |

| ID | WBS | Task | Duration | Start | Finish | Predecessors | Baseline start | Baseline finish | Baseline duration | Total slack | Free slack | Constraint | Work | Text1 | Text4 | Text5 | Text22 |
| --- | --- | --- | --- | --- | --- | --- | --- | --- | --- | --- | --- | --- | --- | --- | --- | --- | --- |
| 1788 | 1.2.18.3.2.3 | **طبقه اول** | 62d | 2016-04-07 | 2016-06-07 |  | 2016-04-12 | 2016-07-06 | 0d | 34d |  |  | 530.06h | 0% | 74 روز | 74 روز | 48 |
| 1789 | 1.2.18.3.2.3.1 | **اجرای ستون ها و دیوار های برشی طبقه اول** | 40d | 2016-04-07 | 2016-05-16 |  | 2016-04-12 | 2016-05-29 | 0d | 34d |  |  | 295.02h | 0% | 41 روز | 41 روز | 26 |
| 1790 | 1.2.18.3.2.3.1.1 | آرماتور بندی | 15d | 2016-04-07 | 2016-04-21 | 1787 | 2016-04-12 | 2016-05-01 | 0d | 34d | 16d |  | 105h | 0% | 15 روز | 15 روز | 10 |
| 1791 | 1.2.18.3.2.3.1.2 | قالب بندی | 15d | 2016-04-28 | 2016-05-12 | 1790FS-10d | 2016-05-01 | 2016-05-15 | 0d | 18d | 0d | start no earlier than 2016-04-28 | 112h | 0% | 11 روز | 11 روز | 10 |
| 1792 | 1.2.18.3.2.3.1.3 | بتن ریزی | 2d | 2016-05-13 | 2016-05-14 | 1791 | 2016-05-15 | 2016-05-23 | 0d | 18d | 0d | start no earlier than 2016-01-26 | 39.5h | 0% | 7 روز | 7 روز |  |
| 1793 | 1.2.18.3.2.3.1.4 | دکفراژ (قالب برداری) | 2d | 2016-05-15 | 2016-05-16 | 1792 | 2016-05-23 | 2016-05-29 | 0d | 107d |  |  | 38.52h | 0% | 5 روز | 5 روز |  |
| 1794 | 1.2.18.3.2.3.2 | **اجرای سقف بتنی طبقه اول** | 17d | 2016-05-15 | 2016-05-31 |  | 2016-05-29 | 2016-07-06 | 0d | 18d |  |  | 173.04h | 0% | 33 روز | 33 روز | 22 |
| 1795 | 1.2.18.3.2.3.2.1 | آرماتور بندی | 10d | 2016-05-15 | 2016-05-24 | 1792 | 2016-05-29 | 2016-06-11 | 0d | 18d | 0d |  | 72.02h | 0% | 11 روز | 11 روز |  |
| 1796 | 1.2.18.3.2.3.2.2 | قالب بندی | 10d | 2016-05-19 | 2016-05-28 | 1795SS+4d | 2016-06-11 | 2016-06-22 | 0d | 18d | 0d |  | 47.02h | 0% | 10 روز | 10 روز |  |
| 1797 | 1.2.18.3.2.3.2.3 | بتن ریزی | 1d | 2016-05-29 | 2016-05-29 | 1796 | 2016-06-22 | 2016-06-29 | 0d | 18d | 0d |  | 31.5h | 0% | 6 روز | 6 روز |  |
| 1798 | 1.2.18.3.2.3.2.4 | دکفراژ (قالب برداری) | 2d | 2016-05-30 | 2016-05-31 | 1797 | 2016-06-29 | 2016-07-06 | 0d | 18d | 0d |  | 22.5h | 0% | 6 روز | 6 روز |  |
| 1799 | 1.2.18.3.2.3.3 | **اجرای پله طبقه اول** | 7d | 2016-06-01 | 2016-06-07 |  | 2016-05-29 | 2016-06-09 | 0d | 18d |  |  | 62h | 0% | 10 روز | 10 روز | 11 |
| 1800 | 1.2.18.3.2.3.3.1 | آرماتور بندی | 3d | 2016-06-01 | 2016-06-03 | 1798 | 2016-05-29 | 2016-06-02 | 0d | 18d | 0d |  | 36.5h | 0% | 4 روز | 4 روز |  |
| 1801 | 1.2.18.3.2.3.3.2 | قالب بندی | 3d | 2016-06-03 | 2016-06-05 | 1800FS-1d | 2016-06-02 | 2016-06-06 | 0d | 18d | 0d |  | 8.5h | 0% | 3 روز | 3 روز |  |
| 1802 | 1.2.18.3.2.3.3.3 | بتن ریزی | 1d | 2016-06-06 | 2016-06-06 | 1801 | 2016-06-06 | 2016-06-07 | 0d | 18d | 0d |  | 8.5h | 0% | 1 روز | 1 روز |  |
| 1803 | 1.2.18.3.2.3.3.4 | دکفراژ (قالب برداری) | 1d | 2016-06-07 | 2016-06-07 | 1802 | 2016-06-07 | 2016-06-09 | 0d | 18d | 0d |  | 8.5h | 0% | 2 روز | 2 روز |  |
| 1804 | 1.2.18.3.2.4 | **طبقه دوم** | 60d | 2016-06-08 | 2016-08-06 |  | 2016-07-11 | 2016-10-18 | 0d | 8d |  |  | 542.52h | 0% | 86 روز | 86 روز | 48 |
| 1805 | 1.2.18.3.2.4.1 | **اجرای ستون ها و دیوار های برشی طبقه دوم** | 35d | 2016-06-08 | 2016-07-12 |  | 2016-07-11 | 2016-08-30 | 0d | 8d |  |  | 272.5h | 0% | 45 روز | 45 روز | 26 |
| 1806 | 1.2.18.3.2.4.1.1 | آرماتور بندی | 15d | 2016-06-08 | 2016-06-22 | 1803 | 2016-07-11 | 2016-07-30 | 0d | 19d | 11d |  | 104.46h | 0% | 16 روز | 16 روز | 10 |
| 1807 | 1.2.18.3.2.4.1.2 | قالب بندی | 15d | 2016-06-24 | 2016-07-08 | 1806FS-10d | 2016-07-30 | 2016-08-14 | 0d | 8d | 0d | start no earlier than 2016-06-24 | 107.02h | 0% | 12 روز | 12 روز | 10 |
| 1808 | 1.2.18.3.2.4.1.3 | بتن ریزی | 2d | 2016-07-09 | 2016-07-10 | 1807 | 2016-08-14 | 2016-08-23 | 0d | 8d | 0d | start no earlier than 2016-02-09 | 38.52h | 0% | 8 روز | 8 روز |  |
| 1809 | 1.2.18.3.2.4.1.4 | دکفراژ (قالب برداری) | 2d | 2016-07-11 | 2016-07-12 | 1808 | 2016-08-23 | 2016-08-30 | 0d | 8d | 0d |  | 22.5h | 0% | 6 روز | 6 روز |  |
| 1810 | 1.2.18.3.2.4.2 | **اجرای سقف بتنی طبقه دوم** | 18d | 2016-07-13 | 2016-07-30 |  | 2016-08-30 | 2016-10-18 | 0d | 8d |  |  | 185.04h | 0% | 44 روز | 44 روز | 22 |
| 1811 | 1.2.18.3.2.4.2.1 | آرماتور بندی | 10d | 2016-07-13 | 2016-07-22 | 1809 | 2016-08-30 | 2016-09-13 | 0d | 8d | 0d |  | 75.52h | 0% | 12 روز | 12 روز |  |
| 1812 | 1.2.18.3.2.4.2.2 | قالب بندی | 10d | 2016-07-18 | 2016-07-27 | 1811FS-5d | 2016-09-19 | 2016-10-02 | 0d | 8d | 0d |  | 48.5h | 0% | 11 روز | 11 روز |  |
| 1813 | 1.2.18.3.2.4.2.3 | بتن ریزی | 1d | 2016-07-28 | 2016-07-28 | 1812 | 2016-10-02 | 2016-10-10 | 0d | 8d | 0d |  | 38.52h | 0% | 7 روز | 7 روز |  |
| 1814 | 1.2.18.3.2.4.2.4 | قالب برداری | 2d | 2016-07-29 | 2016-07-30 | 1813 | 2016-10-10 | 2016-10-18 | 0d | 8d | 0d |  | 22.5h | 0% | 7 روز | 7 روز |  |

| ID | WBS | Task | Duration | Start | Finish | Predecessors | Baseline start | Baseline finish | Baseline duration | Total slack | Free slack | Work | Text1 | Text4 | Text5 | Text22 |
| --- | --- | --- | --- | --- | --- | --- | --- | --- | --- | --- | --- | --- | --- | --- | --- | --- |
| 1815 | 1.2.18.3.2.4.3 | **اجرای پله طبقه دوم** | 7d | 2016-07-31 | 2016-08-06 |  | 2016-08-30 | 2016-09-15 | 0d | 8d |  | 84.98h | 0% | 16 روز | 16 روز | 15 |
| 1816 | 1.2.18.3.2.4.3.1 | آرماتور بندی | 3d | 2016-07-31 | 2016-08-02 | 1814 | 2016-08-30 | 2016-09-04 | 0d | 8d | 0d | 24.98h | 0% | 4 روز | 4 روز |  |
| 1817 | 1.2.18.3.2.4.3.2 | قالب بندی | 3d | 2016-08-02 | 2016-08-04 | 1816FS-1d | 2016-09-08 | 2016-09-12 | 0d | 8d | 0d | 28h | 0% | 3 روز | 3 روز |  |
| 1818 | 1.2.18.3.2.4.3.3 | بتن ریزی | 1d | 2016-08-05 | 2016-08-05 | 1817 | 2016-09-12 | 2016-09-13 | 0d | 8d | 0d | 17h | 0% | 1 روز | 1 روز |  |
| 1819 | 1.2.18.3.2.4.3.4 | قالب برداری | 1d | 2016-08-06 | 2016-08-06 | 1818 | 2016-09-13 | 2016-09-15 | 0d | 8d | 0d | 15h | 0% | 2 روز | 2 روز |  |
| 1820 | 1.2.18.4 | **سفت کاری** | 182d | 2016-02-23 | 2016-08-22 |  | 2015-12-27 | 2016-06-22 | 0d | 9d |  |  | 48% | 142 روز | 142 روز |  |
| 1821 | 1.2.18.4.1 | **زیر زمین** | 25d | 2016-02-23 | 2016-03-18 |  | 2015-12-27 | 2016-01-25 | 0d | 166d |  |  | 60% | 26 روز | 26 روز |  |
| 1822 | 1.2.18.4.1.1 | اجرای دیوارهای پیرامونی | 10d | 2016-02-23 | 2016-03-03 | 1771 |  |  |  | 166d | 0d |  |  |  |  |  |
| 1823 | 1.2.18.4.1.2 | ساخت و نصب نعل درگاه های پیرامونی | 10d | 2016-02-23 | 2016-03-03 | 1822SS |  |  |  | 176d | 0d |  |  |  |  |  |
| 1824 | 1.2.18.4.1.3 | ساخت فریم و چارچوب در و پنجره ها | 5d | 2016-02-23 | 2016-02-27 | 1823SS |  |  |  | 176d | 0d |  |  |  |  |  |
| 1825 | 1.2.18.4.1.4 | ساخت درهای فولادی | 10d | 2016-02-28 | 2016-03-08 | 1824 |  |  |  | 176d |  |  |  |  |  |  |
| 1826 | 1.2.18.4.1.5 | اجرای بلوکاژ | 5d | 2016-03-04 | 2016-03-08 | 1823 |  |  |  | 176d |  |  |  |  |  |  |
| 1827 | 1.2.18.4.1.6 | اجرای دیوار جداکننده داخلی | 5d | 2016-03-04 | 2016-03-08 | 1822 |  |  |  | 166d | 0d |  |  |  |  |  |
| 1828 | 1.2.18.4.1.7 | ساخت و نصب نعل درگاه های داخلی | 3d | 2016-03-09 | 2016-03-11 | 1827 |  |  |  | 173d |  |  |  |  |  |  |
| 1829 | 1.2.18.4.1.8 | اجرای گچ و خاک دیوارها | 10d | 2016-03-09 | 2016-03-18 | 1827 |  |  |  | 166d |  |  |  |  |  |  |
| 1830 | 1.2.18.4.2 | **همکف** | 20d | 2016-04-07 | 2016-04-26 |  |  |  |  | 127d |  |  |  |  |  |  |
| 1831 | 1.2.18.4.2.1 | اجرای دیوارهای پیرامونی | 5d | 2016-04-07 | 2016-04-11 | 1787 |  |  |  | 127d | 0d |  |  |  |  |  |
| 1832 | 1.2.18.4.2.2 | ساخت و نصب نعل درگاه های پیرامونی | 5d | 2016-04-07 | 2016-04-11 | 1831SS |  |  |  | 127d | 0d |  |  |  |  |  |
| 1833 | 1.2.18.4.2.3 | اجرای دیوار جداکننده داخلی | 5d | 2016-04-12 | 2016-04-16 | 1832 |  |  |  | 127d | 0d |  |  |  |  |  |
| 1834 | 1.2.18.4.2.4 | ساخت و نصب نعل درگاه های داخلی | 5d | 2016-04-12 | 2016-04-16 | 1833SS |  |  |  | 137d |  |  |  |  |  |  |
| 1835 | 1.2.18.4.2.5 | اجرای گچ و خاک دیوارها | 10d | 2016-04-17 | 2016-04-26 | 1833 |  |  |  | 127d |  |  |  |  |  |  |
| 1836 | 1.2.18.4.3 | **طبقه اول** | 17d | 2016-06-08 | 2016-06-24 |  |  |  |  | 18d |  |  |  |  |  |  |
| 1837 | 1.2.18.4.3.1 | اجرای دیوارهای پیرامونی | 5d | 2016-06-08 | 2016-06-12 | 1803 |  |  |  | 18d | 0d |  |  |  |  |  |
| 1838 | 1.2.18.4.3.2 | ساخت و نصب نعل درگاه های پیرامونی | 5d | 2016-06-08 | 2016-06-12 | 1837SS |  |  |  | 18d | 0d |  |  |  |  |  |
| 1839 | 1.2.18.4.3.3 | اجرای دیوار جداکننده داخلی | 5d | 2016-06-13 | 2016-06-17 | 1838 |  |  |  | 18d | 0d |  |  |  |  |  |
| 1840 | 1.2.18.4.3.4 | ساخت و نصب نعل درگاه های داخلی | 5d | 2016-06-08 | 2016-06-12 | 1838SS |  |  |  | 80d |  |  |  |  |  |  |
| 1841 | 1.2.18.4.3.5 | اجرای گچ و خاک دیوارها | 7d | 2016-06-18 | 2016-06-24 | 1839 |  |  |  | 18d | 0d |  |  |  |  |  |

| ID | WBS | Task | Duration | Start | Finish | Predecessors | Total slack | Free slack | Constraint |
| --- | --- | --- | --- | --- | --- | --- | --- | --- | --- |
| 1842 | 1.2.18.4.4 | **طبقه دوم** | 16d | 2016-08-07 | 2016-08-22 |  | 8d |  |  |
| 1843 | 1.2.18.4.4.1 | اجرای دیوارهای پیرامونی | 4d | 2016-08-07 | 2016-08-10 | 1819 | 8d | 0d |  |
| 1844 | 1.2.18.4.4.2 | ساخت و نصب نعل درگاه های پیرامونی | 4d | 2016-08-07 | 2016-08-10 | 1843SS | 9d | 0d |  |
| 1845 | 1.2.18.4.4.3 | اجرای دیوار جداکننده داخلی | 4d | 2016-08-11 | 2016-08-14 | 1844 | 9d | 0d |  |
| 1846 | 1.2.18.4.4.4 | ساخت و نصب نعل درگاه های داخلی | 4d | 2016-08-11 | 2016-08-14 | 1845SS | 17d |  |  |
| 1847 | 1.2.18.4.4.5 | اجرای گچ و خاک دیوارها | 8d | 2016-08-15 | 2016-08-22 | 1845 | 9d |  |  |
| 1848 | 1.2.18.5 | **بام ( مرحله اول )** | 9d | 2016-08-07 | 2016-08-15 |  | 8d |  |  |
| 1849 | 1.2.18.5.1 | اجرای دیوار جان پناه پشت بام و خرپشته | 3d | 2016-08-07 | 2016-08-09 | 1843SS | 8d | 0d |  |
| 1850 | 1.2.18.5.2 | سیمانکاری دیوار جانپناه | 2d | 2016-08-10 | 2016-08-11 | 1849 | 16d | 0d |  |
| 1851 | 1.2.18.5.3 | رابیتس بندی | 4d | 2016-08-12 | 2016-08-15 | 1850 | 16d |  |  |
| 1852 | 1.2.18.6 | **اجرای نمای بیرونی** | 17d | 2016-08-07 | 2016-08-23 |  | 8d |  |  |
| 1853 | 1.2.18.6.1 | اجرای سنگ پلاک نما به همراه فتیله | 6d | 2016-08-07 | 2016-08-12 | 1849SS | 8d | 0d | start no earlier than 2016-01-21 |
| 1854 | 1.2.18.6.2 | اجرای سنگ باکس تیر ها و ستون ها | 8d | 2016-08-07 | 2016-08-14 | 1853SS | 17d | 0d |  |
| 1855 | 1.2.18.6.3 | اجرای سنگ پیش آمدگی ها | 8d | 2016-08-07 | 2016-08-14 | 1854SS | 17d |  |  |
| 1856 | 1.2.18.6.4 | اجرای آستر سیمان سیاه دیوار جهت زیر سازی نمای شسته | 8d | 2016-08-07 | 2016-08-14 | 1853SS | 8d | 0d |  |
| 1857 | 1.2.18.6.5 | اجرای نمای شسته | 8d | 2016-08-12 | 2016-08-19 | 1856SS+5d | 8d | 0d |  |
| 1858 | 1.2.18.6.6 | اجرای درپوش بتنی جانپناه و کف پنجره ها | 4d | 2016-08-20 | 2016-08-23 | 1857 | 8d |  |  |
| 1859 | 1.2.18.7 | **تاسیسات مکانیکی ( مرحله اول )** | 44d | 2016-06-25 | 2016-08-07 |  | 18d |  |  |
| 1860 | 1.2.18.7.1 | سوراخکاری و شیارزنی و کنده کاری داکت | 7d | 2016-06-25 | 2016-07-01 | 1841 | 18d | 0d | start no earlier than 2016-01-21 |
| 1861 | 1.2.18.7.2 | کانال کنی تاسیسات | 5d | 2016-06-25 | 2016-06-29 | 1860SS | 18d | 0d |  |
| 1862 | 1.2.18.7.3 | لوله کشی پلی اتیلن فاضلاب و آب باران | 14d | 2016-06-30 | 2016-07-13 | 1861 | 24d | 0d |  |
| 1863 | 1.2.18.7.4 | ساپورتهای لوله کشی تاسیسات | 5d | 2016-06-30 | 2016-07-04 | 1862SS | 46d | 0d |  |
| 1864 | 1.2.18.7.5 | لوله کشی گالوانیزه آب سرد و گرم | 12d | 2016-07-05 | 2016-07-16 | 1863 | 46d |  |  |
| 1865 | 1.2.18.7.6 | لوله کشی لوله های گرمایشی و پنج لایه | 15d | 2016-07-14 | 2016-07-28 | 1862 | 29d | 0d |  |
| 1866 | 1.2.18.7.7 | اجرای ساپورتهای کانال کولر | 5d | 2016-07-14 | 2016-07-18 | 1862 | 24d | 0d |  |
| 1867 | 1.2.18.7.8 | اجرای کانال کولر | 12d | 2016-07-19 | 2016-07-30 | 1866 | 24d | 0d |  |
| 1868 | 1.2.18.7.9 | اجرای کانال اگزاست | 10d | 2016-07-19 | 2016-07-28 | 1867SS | 24d | 0d |  |
| 1869 | 1.2.18.7.10 | عایق پشم شیشه و تست | 5d | 2016-07-29 | 2016-08-02 | 1865 | 29d |  |  |
| 1870 | 1.2.18.7.11 | اجرای لوله هایPVC | 2d | 2016-06-30 | 2016-07-01 | 1862SS | 24d | 0d |  |
| 1871 | 1.2.18.7.12 | عملیات شاسی کشی و آهن کاری آسانسور | 10d | 2016-07-29 | 2016-08-07 | 1868 | 24d |  |  |

| ID | WBS | Task | Duration | Start | Finish | Predecessors | Total slack | Free slack | Constraint |
| --- | --- | --- | --- | --- | --- | --- | --- | --- | --- |
| 1872 | 1.2.18.8 | **تاسیسات الکتریکی ( مرحله اول )** | 29d | 2016-06-25 | 2016-07-23 |  | 39d |  |  |
| 1873 | 1.2.18.8.1 | شیارزنی | 10d | 2016-06-25 | 2016-07-04 | 1860SS | 43d | 0d |  |
| 1874 | 1.2.18.8.2 | اجرای لوله های PVC . PG13/5 | 15d | 2016-07-05 | 2016-07-19 | 1873 | 43d | 0d |  |
| 1875 | 1.2.18.8.3 | اجرای لوله های PVC . PG16-42 | 15d | 2016-07-05 | 2016-07-19 | 1874SS | 43d | 0d |  |
| 1876 | 1.2.18.8.4 | تهیه ساخت و سفارش تابلو برق | 10d | 2016-06-25 | 2016-07-04 | 1873SS | 57d | 0d |  |
| 1877 | 1.2.18.8.5 | غلاف گزاری | 3d | 2016-07-05 | 2016-07-07 | 1875SS | 55d |  |  |
| 1878 | 1.2.18.8.6 | سینی کابل | 5d | 2016-07-19 | 2016-07-23 | 1868SS | 39d |  |  |
| 1879 | 1.2.18.8.7 | نصب تابلو | 1d | 2016-07-05 | 2016-07-05 | 1876 | 57d |  |  |
| 1880 | 1.2.18.9 | **بام ( مرحله دوم )** | 50d | 2016-07-02 | 2016-08-20 |  | 11d |  |  |
| 1881 | 1.2.18.9.1 | شیب بندی و اجرای بتن سبک بام | 5d | 2016-07-02 | 2016-07-06 | 1870 | 24d | 0d | start no earlier than 2016-02-04 |
| 1882 | 1.2.18.9.2 | اجرای سیمانکاری لیسه ای زیر عایق | 2d | 2016-07-07 | 2016-07-08 | 1881 | 24d | 0d |  |
| 1883 | 1.2.18.9.3 | اجرای عایق پشت بام | 2d | 2016-07-09 | 2016-07-10 | 1882 | 24d | 0d |  |
| 1884 | 1.2.18.9.4 | نصب تور مرغی قبل از سنگ اندود | 1d | 2016-07-11 | 2016-07-11 | 1883 | 24d | 0d |  |
| 1885 | 1.2.18.9.5 | اجرای سنگ قرنیز لاشتر | 4d | 2016-07-12 | 2016-07-15 | 1884 | 24d | 13d |  |
| 1886 | 1.2.18.9.6 | اجرای آستر سیمان سیاه و سفید بام | 10d | 2016-07-29 | 2016-08-07 | 1885 | 11d | 0d | start no earlier than 2016-07-29 |
| 1887 | 1.2.18.9.7 | شیب بندی و اجرای موزاییک بام | 10d | 2016-08-08 | 2016-08-17 | 1886 | 11d | 0d |  |
| 1888 | 1.2.18.9.8 | نصب قرنیز گالوانیزه بام | 3d | 2016-08-18 | 2016-08-20 | 1887 | 11d |  |  |
| 1889 | 1.2.18.10 | **نازک کاری** | 63d | 2016-06-25 | 2016-08-26 |  | 5d |  |  |
| 1890 | 1.2.18.10.1 | **زیر زمین** | 29d | 2016-06-25 | 2016-07-23 |  | 18d |  |  |
| 1891 | 1.2.18.10.1.1 | اجرای کرم بندی و شیب بندی سرویسها و سالن غذاخوری | 4d | 2016-06-25 | 2016-06-28 | 1861SS | 18d | 0d |  |
| 1892 | 1.2.18.10.1.2 | اجرای عایق رطوبتی سالن غذاخوری و سرویسها | 2d | 2016-06-29 | 2016-06-30 | 1891 | 18d | 0d |  |
| 1893 | 1.2.18.10.1.3 | اجرای سیمان محافظ روی عایق | 2d | 2016-07-01 | 2016-07-02 | 1892 | 60d |  |  |
| 1894 | 1.2.18.10.1.4 | چیدن دیوارهای داکت | 2d | 2016-06-25 | 2016-06-26 | 1891SS | 66d |  |  |
| 1895 | 1.2.18.10.1.5 | نصب چارچوبهای در و پنجره | 3d | 2016-06-25 | 2016-06-27 | 1891SS | 65d |  |  |
| 1896 | 1.2.18.10.1.6 | اجرای قرنیز و سنگ و پلاک فضای داخلی دیوارها | 3d | 2016-07-01 | 2016-07-03 | 1892 | 18d | 0d |  |
| 1897 | 1.2.18.10.1.7 | اجرای گچ سفید دیوارها | 10d | 2016-07-04 | 2016-07-13 | 1896 | 49d |  |  |
| 1898 | 1.2.18.10.1.8 | اجرای کاشی دیوار سرویسها | 10d | 2016-07-01 | 2016-07-10 | 1892 | 47d | 0d |  |
| 1899 | 1.2.18.10.1.9 | اجرای سرامیک کف | 5d | 2016-07-11 | 2016-07-15 | 1898 | 47d |  |  |
| 1900 | 1.2.18.10.1.10 | اجرای سنگ گرانیت و چینی و موزائیک کف | 10d | 2016-07-04 | 2016-07-13 | 1896 | 39d | 0d |  |
| 1901 | 1.2.18.10.1.11 | اجرای سقف کاذب ( کناف فضای داخلی ) | 10d | 2016-07-14 | 2016-07-23 | 1900 | 39d |  |  |
| 1902 | 1.2.18.10.1.12 | اجرای سقف کاذب ( سرویس بهداشتی ) | 4d | 2016-07-11 | 2016-07-14 | 1898 | 48d |  |  |

| ID | WBS | Task | Duration | Start | Finish | Predecessors | Total slack | Free slack | Constraint |
| --- | --- | --- | --- | --- | --- | --- | --- | --- | --- |
| 1903 | 1.2.18.10.2 | **همکف** | 28d | 2016-06-30 | 2016-07-27 |  | 19d |  |  |
| 1904 | 1.2.18.10.2.1 | نصب چارچوبهای در و پنجره | 3d | 2016-06-30 | 2016-07-02 | 1861 | 19d | 0d |  |
| 1905 | 1.2.18.10.2.2 | اجرای قرنیز و سنگ و پلاک فضای داخلی دیوارها | 5d | 2016-07-03 | 2016-07-07 | 1904 | 19d | 0d |  |
| 1906 | 1.2.18.10.2.3 | اجرای سنگ گرانیت کف | 5d | 2016-07-08 | 2016-07-12 | 1905 | 19d | 0d |  |
| 1907 | 1.2.18.10.2.4 | اجرای گچ سفید | 3d | 2016-07-08 | 2016-07-10 | 1905 | 52d |  |  |
| 1908 | 1.2.18.10.2.5 | اجرای سقف کاذب ( کناف فضای داخلی ) | 15d | 2016-07-13 | 2016-07-27 | 1906 | 35d |  |  |
| 1909 | 1.2.18.10.3 | **طبقه اول** | 36d | 2016-07-13 | 2016-08-17 |  | 14d |  |  |
| 1910 | 1.2.18.10.3.1 | نصب چارچوبهای در و پنجره | 2d | 2016-07-13 | 2016-07-14 | 1906 | 19d | 0d |  |
| 1911 | 1.2.18.10.3.2 | اجرای قرنیز و سنگ و پلاک فضای داخلی دیوارها | 4d | 2016-07-15 | 2016-07-18 | 1910 | 19d | 0d |  |
| 1912 | 1.2.18.10.3.3 | اجرای سنگ گرانیت کف | 4d | 2016-07-19 | 2016-07-22 | 1911 | 19d | 0d |  |
| 1913 | 1.2.18.10.3.4 | اجرای گچ سفید | 3d | 2016-08-05 | 2016-08-07 | 1912 | 6d | 0d | start no earlier than 2016-08-05 |
| 1914 | 1.2.18.10.3.5 | اجرای سقف کاذب ( کناف فضای داخلی ) | 10d | 2016-08-08 | 2016-08-17 | 1913 | 14d |  |  |
| 1915 | 1.2.18.10.4 | **طبقه دوم** | 20d | 2016-07-20 | 2016-08-08 |  | 23d |  |  |
| 1916 | 1.2.18.10.4.1 | نصب چارچوبهای در و پنجره | 2d | 2016-07-20 | 2016-07-21 | 1912FS-3d | 23d | 0d |  |
| 1917 | 1.2.18.10.4.2 | اجرای قرنیز و سنگ و پلاک فضای داخلی دیوارها | 4d | 2016-07-22 | 2016-07-25 | 1916 | 23d | 0d |  |
| 1918 | 1.2.18.10.4.3 | اجرای سنگ گرانیت کف | 4d | 2016-07-26 | 2016-07-29 | 1917 | 23d | 0d |  |
| 1919 | 1.2.18.10.4.4 | اجرای گچ سفید | 3d | 2016-07-30 | 2016-08-01 | 1918 | 23d | 0d |  |
| 1920 | 1.2.18.10.4.5 | اجرای سقف کاذب ( کناف فضای داخلی ) | 7d | 2016-08-02 | 2016-08-08 | 1919 | 23d |  |  |
| 1921 | 1.2.18.10.5 | **راه پله** | 47d | 2016-07-01 | 2016-08-16 |  | 15d |  |  |
| 1922 | 1.2.18.10.5.1 | اجرای سنگ بدنه | 7d | 2016-07-01 | 2016-07-07 | 1896FS-3d | 18d | 0d |  |
| 1923 | 1.2.18.10.5.2 | اجرای سنگ پله ها | 8d | 2016-07-08 | 2016-07-15 | 1922 | 18d | 0d |  |
| 1924 | 1.2.18.10.5.3 | اجرای رابتس زیر پله | 3d | 2016-07-16 | 2016-07-18 | 1923 | 18d | 13d |  |
| 1925 | 1.2.18.10.5.4 | اجرای گچ و خاک پله ها | 6d | 2016-08-01 | 2016-08-06 | 1924 | 5d | 0d | start no earlier than 2016-08-01 |
| 1926 | 1.2.18.10.5.5 | اجرای گچ سفید | 6d | 2016-08-07 | 2016-08-12 | 1925 | 15d | 0d |  |
| 1927 | 1.2.18.10.5.6 | اجرای لگه گیری گچ سفید زیر و بغل پله | 4d | 2016-08-13 | 2016-08-16 | 1926 | 15d |  |  |

| ID | WBS | Task | Type | Duration | Start | Finish | Predecessors | Baseline start | Baseline finish | Baseline duration | Total slack | Free slack | Constraint | Work | Text1 | Text4 | Text5 | Text22 |
| --- | --- | --- | --- | --- | --- | --- | --- | --- | --- | --- | --- | --- | --- | --- | --- | --- | --- | --- |
| 1928 | 1.2.18.10.6 | **نصبیات و تکمیلی نازک کاری** |  | 20d | 2016-08-07 | 2016-08-26 |  |  |  |  | 5d |  |  |  |  |  |  |  |
| 1929 | 1.2.18.10.6.1 | نصب در و پنجره های جوبی ، فولادی و UPVC |  | 7d | 2016-08-07 | 2016-08-13 | 1925 |  |  |  | 5d | 0d |  |  |  |  |  |  |
| 1930 | 1.2.18.10.6.2 | نصب شیشه ها |  | 3d | 2016-08-14 | 2016-08-16 | 1929 |  |  |  | 5d | 0d |  |  |  |  |  |  |
| 1931 | 1.2.18.10.6.3 | رنگ آمیزی سقف و دیوار |  | 10d | 2016-08-17 | 2016-08-26 | 1930 |  |  |  | 5d |  |  |  |  |  |  |  |
| 1932 | 1.2.18.11 | **تاسیسات الکتریکی ( مرحله دوم )** |  | 14d | 2016-08-08 | 2016-08-21 |  | 2016-01-05 | 2016-08-04 | 0d | 6d |  |  | 72h | 7% | 170 | 170 | 73 |
| 1933 | 1.2.18.11.1 | اجرای سیم کشی و کابل کشی ساختمان |  | 8d | 2016-08-08 | 2016-08-15 | 1913 |  |  |  | 6d | 0d |  |  |  |  |  |  |
| 1934 | 1.2.18.11.2 | کابل کشی مخابرات و تجهیزات مربوطه |  | 3d | 2016-08-16 | 2016-08-18 | 1933 |  |  |  | 12d | 0d |  |  |  |  |  |  |
| 1935 | 1.2.18.11.3 | اجرا و نصب تابلو برق و جریان ضعیف |  | 1d | 2016-08-19 | 2016-08-19 | 1934 |  |  |  | 12d |  |  |  |  |  |  |  |
| 1936 | 1.2.18.11.4 | کلید و پریز |  | 3d | 2016-08-16 | 2016-08-18 | 1933 |  |  |  | 10d | 0d |  |  |  |  |  |  |
| 1937 | 1.2.18.11.5 | چراغ های ایندور |  | 3d | 2016-08-19 | 2016-08-21 | 1936 |  |  |  | 10d | 0d |  |  |  |  |  |  |
| 1938 | 1.2.18.11.6 | سیستم اعلام حریق |  | 3d | 2016-08-19 | 2016-08-21 | 1937SS |  |  |  | 10d | 0d |  |  |  |  |  |  |
| 1939 | 1.2.18.11.7 | سیستم آنتن مرکزی |  | 2d | 2016-08-19 | 2016-08-20 | 1938SS |  |  |  | 11d | 0d |  |  |  |  |  |  |
| 1940 | 1.2.18.11.8 | ارت سازی |  | 2d | 2016-08-19 | 2016-08-20 | 1939SS | 2016-01-05 | 2016-01-14 | 0d | 11d |  |  | 72h | 60% | 9 روز | 9 روز | 10 |
| 1941 | 1.2.18.12 | **تاسیسات مکانیکی ( مرحله دوم )** |  | 10d | 2016-08-16 | 2016-08-25 |  |  |  |  | 6d |  |  | 360h |  |  |  |  |
| 1942 | 1.2.18.12.1 | شیر آلات بهداشتی |  | 5d | 2016-08-16 | 2016-08-20 | 1933 | 2016-01-28 | 2016-02-11 | 0d | 6d | 0d |  | 104h | 100% | 13 روز | 13 روز | 10 |
| 1943 | 1.2.18.12.2 | تجهیزات آتش نشانی |  | 4d | 2016-08-16 | 2016-08-19 | 1942SS |  |  |  | 12d |  |  |  |  |  |  |  |
| 1944 | 1.2.18.12.3 | نصب رادیاتور |  | 3d | 2016-08-16 | 2016-08-18 | 1942SS | 2016-02-13 | 2016-02-23 | 0d | 13d | 0d |  | 80h | 0% | 10 روز | 10 روز |  |
| 1945 | 1.2.18.12.4 | نصب دریچه های هوا و کولر |  | 3d | 2016-08-16 | 2016-08-18 | 1944SS | 2016-02-24 | 2016-04-03 | 0d | 13d |  |  | 176h | 0% | 22 روز | 22 روز | 12 |
| 1946 | 1.2.18.12.5 | عملیات نصبیات آسانسور ( کابین و سایر تجهیزات ) به همراه تست |  | 7d | 2016-08-16 | 2016-08-22 | 1942SS |  |  |  | 9d |  |  |  |  |  |  |  |
| 1947 | 1.2.18.12.6 | اجرای نصبیات موتورخانه |  | 10d | 2016-08-16 | 2016-08-25 | 1942SS |  |  |  | 6d |  |  |  |  |  |  |  |
| 1948 | 1.2.19 | **ساختمان مسجد و عقیدتی سیاسی** |  | 418d | 2015-07-01 | 2016-08-21 |  |  |  |  | 10d |  |  | 2722.5h |  |  |  |  |
| 1949 | 1.2.19.1 | ابلاغ نقشه های فصل مشترک |  | 1d | 2015-07-01 | 2015-07-01 |  |  |  |  | 24d | 0d | start no earlier than 2015-07-01 |  |  |  |  |  |
| 1950 | 1.2.19.2 | **آماده سازی زمین** |  | 70d | 2015-07-02 | 2015-09-09 |  | 2015-05-02 | 2015-08-06 | 0d | 24d |  |  | 339.5h | 100% | 84 روز | 84 روز | 38 |
| 1951 | 1.2.19.2.1 | نقشه برداری |  | 2d | 2015-07-02 | 2015-07-03 | 1949 | 2015-05-02 | 2015-05-03 | 0d | 24d | 0d | start no earlier than 2015-05-02 | 16h | 100% | 2 روز | 2 روز |  |
| 1952 | 1.2.19.2.2 | تهیه فصل مشترک و برداشت از خاکها و معارضین |  | 10d | 2015-07-04 | 2015-07-13 | 1951 | 2015-05-04 | 2015-05-14 | 0d | 24d | 0d |  | 7.5h | 100% | 10 روز | 10 روز |  |
| 1953 | 1.2.19.2.3 | جمع اوری خاک ها و بتن های توده شده |  | 6d | 2015-07-14 | 2015-07-19 | 1952 | 2015-05-16 | 2015-05-21 | 0d | 24d | 0d |  | 7.5h | 100% | 6 روز | 6 روز |  |
| 1954 | 1.2.19.2.4 | جمع اوری و ریشه کنی درختان موجود |  | 10d | 2015-07-20 | 2015-07-29 | 1953 | 2015-05-23 | 2015-06-02 | 0d | 24d | 0d |  | 7.5h | 100% | 10 روز | 10 روز |  |
| 1955 | 1.2.19.2.5 | جمع اوری و اجرای مجدد شاه لوله اب |  | 10d | 2015-07-30 | 2015-08-08 | 1954 | 2015-06-03 | 2015-06-14 | 0d | 24d | 0d |  | 7.5h | 100% | 10 روز | 10 روز |  |
| 1956 | 1.2.19.2.6 | جمع اوری لوله گاز و اجرای مجدد |  | 12d | 2015-08-09 | 2015-08-20 | 1955 | 2015-06-15 | 2015-06-28 | 0d | 377d |  |  | 7.5h | 100% | 12 روز | 12 روز |  |
| 1957 | 1.2.19.2.7 | جمع اوری کابل ها و خطوط تلفن |  | 12d | 2015-08-09 | 2015-08-20 | 1955 | 2015-06-15 | 2015-06-28 | 0d | 377d |  |  | 7.5h | 100% | 12 روز | 12 روز |  |
| 1958 | 1.2.19.2.8 | جمع اوری تیرهای فشار قوی و انتقال و اجرای مجدد |  | 12d | 2015-08-09 | 2015-08-20 | 1955 | 2015-06-15 | 2015-06-28 | 0d | 24d | 0d |  | 7.5h | 100% | 12 روز | 12 روز |  |
| 1959 | 1.2.19.2.9 | پياده كردن كروكي ساختمان | milestone | 5d | 2015-08-21 | 2015-08-25 | 1958 | 2015-06-29 | 2015-06-30 | 0d | 24d | 0d |  | 15h | 100% | 2 روز | 2 روز |  |
| 1960 | 1.2.19.2.10 | پی کنی کل ساختمان |  | 15d | 2015-08-26 | 2015-09-09 | 1959 | 2015-07-01 | 2015-08-06 | 0d | 24d | 0d |  | 256h | 100% | 32 روز | 32 روز | 34 |

| ID | WBS | Task | Duration | Start | Finish | Predecessors | Baseline start | Baseline finish | Baseline duration | Total slack | Free slack | Constraint | Work | Text1 | Text4 | Text5 | Text22 |
| --- | --- | --- | --- | --- | --- | --- | --- | --- | --- | --- | --- | --- | --- | --- | --- | --- | --- |
| 1961 | 1.2.19.3 | **اجرای سازه** | 217d | 2015-09-10 | 2016-04-13 |  | 2015-07-06 | 2016-06-04 | 0d | 24d |  |  | 1407h | 38% | 275 روز | 275 روز | 199 |
| 1962 | 1.2.19.3.1 | **اجرای فونداسیون** | 137d | 2015-09-10 | 2016-01-24 |  | 2015-07-06 | 2015-12-26 | 0d | 24d |  |  | 1193h | 76% | 148 روز | 148 روز | 80 |
| 1963 | 1.2.19.3.1.1 | پیاده سازی ، رگلاژ و تسطیح | 14d | 2015-09-10 | 2015-09-23 | 1960 | 2015-08-08 | 2015-08-16 | 0d | 24d | 0d |  | 64h | 80% | 8 روز | 8 روز |  |
| 1964 | 1.2.19.3.1.2 | توقف عملیات تا ارائه گزارش ژئوتکنیک | 36d | 2015-09-24 | 2015-10-29 | 1963 | 2015-07-06 | 2015-08-16 | 0d | 24d | 0d |  | 7.5h | 100% | 36 روز | 36 روز |  |
| 1965 | 1.2.19.3.1.3 | بتن مگر | 20d | 2015-10-30 | 2015-11-18 | 1964 | 2015-08-17 | 2015-08-31 | 0d | 24d | 0d |  | 88h | 80% | 11 روز | 11 روز |  |
| 1966 | 1.2.19.3.1.4 | آرماتوربندی | 20d | 2015-11-19 | 2015-12-08 | 1965 | 2015-08-17 | 2015-10-01 | 0d | 24d | 0d | start no earlier than 2015-10-11 | 320h | 80% | 40 روز | 40 روز | 30 |
| 1967 | 1.2.19.3.1.5 | قالب بندی | 20d | 2015-12-09 | 2015-12-28 | 1966 | 2015-08-17 | 2015-10-01 | 0d | 24d | 0d |  | 312h | 80% | 39 روز | 39 روز | 30 |
| 1968 | 1.2.19.3.1.6 | اجرای صفحه ستون ها به همراه (توقف تا پاسخگویی به ابهامات در صفحه ستونهای راه پله) | 20d | 2015-12-25 | 2016-01-13 | 1967FS-4d | 2015-10-01 | 2015-11-04 | 0d | 24d | 0d | start no earlier than 2015-12-04 | 97.5h | 80% | 19 روز | 19 روز | 13 |
| 1969 | 1.2.19.3.1.7 | بتن ریزی | 5d | 2016-01-14 | 2016-01-18 | 1968 | 2015-11-04 | 2015-11-21 | 0d | 185d | 0d |  | 112h | 70% | 14 روز | 14 روز | 10 |
| 1970 | 1.2.19.3.1.8 | قلوه ریزی بین چشمه های فونداسیون | 7d | 2016-01-18 | 2016-01-24 | 1969SS+4d | 2015-11-21 | 2015-12-26 | 0d | 185d | 0d |  | 192h | 60% | 24 روز | 24 روز | 18 |
| 1971 | 1.2.19.3.2 | **ساخت ستون های اسکلت** | 66d | 2015-12-25 | 2016-02-28 |  |  |  |  | 24d |  |  |  |  |  |  |  |
| 1972 | 1.2.19.3.2.1 | ساخت ستون های ساختمان عقیدتی سیاسی | 35d | 2016-01-25 | 2016-02-28 | 1970 |  |  |  | 185d |  |  |  |  |  |  |  |
| 1973 | 1.2.19.3.2.2 | ساخت ستون های باکس مسجد به همراه (توقف تا پاسخگویی به ابهامات در اتصالات) | 15d | 2015-12-25 | 2016-01-08 | 1968SS |  |  |  | 24d | 0d |  |  |  |  |  |  |
| 1974 | 1.2.19.3.2.3 | ساخت ستون های دوبل با ورق تقویتی مسجد ( به همراه توقف تا تحویل گیری باکس ستون های آماده شده ) | 15d | 2015-12-25 | 2016-01-08 | 1973SS |  |  |  | 24d | 0d |  |  |  |  |  |  |
| 1975 | 1.2.19.3.2.4 | ساخت ستون های مناره مسجد | 20d | 2016-01-09 | 2016-01-28 | 1974 |  |  |  | 24d | 0d |  |  |  |  |  |  |
| 1976 | 1.2.19.3.2.5 | نصب ستون های باکس مسسجد | 6d | 2016-01-29 | 2016-02-03 | 1975 |  |  |  | 24d | 0d |  |  |  |  |  |  |
| 1977 | 1.2.19.3.2.6 | نصب ستون های دوبل با ورق تقویتی مسجد | 7d | 2016-02-04 | 2016-02-10 | 1976 |  |  |  | 24d | 0d |  |  |  |  |  |  |
| 1978 | 1.2.19.3.2.7 | نصب ستون های مناره مسجد | 4d | 2016-02-11 | 2016-02-14 | 1977 |  |  |  | 24d | 0d |  |  |  |  |  |  |
| 1979 | 1.2.19.3.2.8 | نصب ستون های ساختمان عقیدتی سیاسی | 5d | 2016-02-15 | 2016-02-19 | 1978 |  |  |  | 24d | 0d |  |  |  |  |  |  |
| 1980 | 1.2.19.3.3 | **ساخت اسکلت افقی تیرریزی** | 48d | 2016-02-20 | 2016-04-07 |  |  |  |  | 10d |  |  |  |  |  |  |  |
| 1981 | 1.2.19.3.3.1 | ساخت تیرورق ها ی اصلی مسجد | 7d | 2016-02-20 | 2016-02-26 | 1979 |  |  |  | 24d | 0d |  |  |  |  |  |  |
| 1982 | 1.2.19.3.3.2 | برش و ساخت تیر های فرعی مسجد | 7d | 2016-02-27 | 2016-03-04 | 1981 |  |  |  | 24d | 14d |  |  |  |  |  |  |
| 1983 | 1.2.19.3.3.3 | ساخت تیرورق ها ی اصلی عقیدتی سیاسی | 7d | 2016-03-19 | 2016-03-25 | 1982 |  |  |  | 10d | 0d | finish no earlier than 2016-03-25 |  |  |  |  |  |
| 1984 | 1.2.19.3.3.4 | برش و ساخت تیر های فرعی عقیدتی سیاسی | 4d | 2016-03-26 | 2016-03-29 | 1983 |  |  |  | 10d | 0d |  |  |  |  |  |  |
| 1985 | 1.2.19.3.3.5 | نصب تیرورق ها ی اصلی مسجد | 3d | 2016-03-30 | 2016-04-01 | 1984 |  |  |  | 10d | 0d |  |  |  |  |  |  |
| 1986 | 1.2.19.3.3.6 | نصب تیر های فرعی مسجد | 2d | 2016-04-02 | 2016-04-03 | 1985 |  |  |  | 10d | 0d |  |  |  |  |  |  |
| 1987 | 1.2.19.3.3.7 | نصب تیرورق ها ی اصلی عقیدتی سیاسی | 2d | 2016-04-04 | 2016-04-05 | 1986 |  |  |  | 10d | 0d |  |  |  |  |  |  |
| 1988 | 1.2.19.3.3.8 | نصب تیر های فرعی عقیدتی سیاسی | 2d | 2016-04-06 | 2016-04-07 | 1987 |  |  |  | 10d | 0d |  |  |  |  |  |  |

Notes:
- 1968: توقف 10 روزه به علت عدم پاسخگویی در رابطه با صفحه ستون های راه پله

| ID | WBS | Task | Duration | Start | Finish | Predecessors | Baseline start | Baseline finish | Baseline duration | Total slack | Free slack | Work | Text1 | Text4 | Text5 | Text22 |
| --- | --- | --- | --- | --- | --- | --- | --- | --- | --- | --- | --- | --- | --- | --- | --- | --- |
| 1989 | 1.2.19.3.4 | **اجرای سقف مسجد** | 5d | 2016-04-08 | 2016-04-12 |  |  |  |  | 140d |  |  |  |  |  |  |
| 1990 | 1.2.19.3.4.1 | برش کاری و نصب و پانچ ورقهای متال | 2d | 2016-04-08 | 2016-04-09 | 1988 |  |  |  | 140d | 0d |  |  |  |  |  |
| 1991 | 1.2.19.3.4.2 | جوشکاری گل میخ ها | 1d | 2016-04-10 | 2016-04-10 | 1990 |  |  |  | 140d | 0d |  |  |  |  |  |
| 1992 | 1.2.19.3.4.3 | آرماتور بندی | 1d | 2016-04-11 | 2016-04-11 | 1991 |  |  |  | 140d | 0d |  |  |  |  |  |
| 1993 | 1.2.19.3.4.4 | بتن ریزی | 1d | 2016-04-12 | 2016-04-12 | 1992 |  |  |  | 140d | 0d |  |  |  |  |  |
| 1994 | 1.2.19.3.5 | **اجرای سقف طبقه همکف ساختمان عقیدتی سیاسی** | 5d | 2016-04-08 | 2016-04-12 |  | 2016-04-13 | 2016-04-27 | 0d | 140d |  | 95h | 0% | 12 روز | 12 روز |  |
| 1995 | 1.2.19.3.5.1 | برش کاری و نصب و پانچ ورقهای متال | 1d | 2016-04-08 | 2016-04-08 | 1990SS | 2016-04-13 | 2016-04-18 | 0d | 141d | 0d | 32h | 0% | 4 روز | 4 روز |  |
| 1996 | 1.2.19.3.5.2 | جوشکاری گل میخ ها | 1d | 2016-04-10 | 2016-04-10 | 1991SS | 2016-04-18 | 2016-04-20 | 0d | 142d | 0d | 15h | 0% | 2 روز | 2 روز |  |
| 1997 | 1.2.19.3.5.3 | آرماتور بندی | 1d | 2016-04-11 | 2016-04-11 | 1992SS | 2016-04-20 | 2016-04-24 | 0d | 140d | 0d | 24h | 0% | 3 روز | 3 روز |  |
| 1998 | 1.2.19.3.5.4 | بتن ریزی | 1d | 2016-04-12 | 2016-04-12 | 1993SS | 2016-04-24 | 2016-04-27 | 0d | 140d | 0d | 24h | 0% | 3 روز | 3 روز |  |
| 1999 | 1.2.19.3.6 | **اجرای سقف طبقه اول و خرپشته عقیدتی سیاسی** | 6d | 2016-04-08 | 2016-04-13 |  | 2016-04-13 | 2016-05-03 | 0d | 140d |  | 119h | 0% | 17 روز | 17 روز | 11 |
| 2000 | 1.2.19.3.6.1 | برش کاری و نصب و پانچ ورقهای متال | 5d | 2016-04-08 | 2016-04-12 | 1995SS | 2016-04-13 | 2016-04-21 | 0d | 141d |  | 48h | 0% | 6 روز | 6 روز |  |
| 2001 | 1.2.19.3.6.2 | جوشکاری گل میخ ها | 2d | 2016-04-10 | 2016-04-11 | 1996SS | 2016-04-21 | 2016-04-24 | 0d | 142d |  | 15h | 0% | 2 روز | 2 روز |  |
| 2002 | 1.2.19.3.6.3 | آرماتور بندی | 3d | 2016-04-11 | 2016-04-13 | 1997SS | 2016-04-24 | 2016-04-27 | 0d | 140d |  | 24h | 0% | 3 روز | 3 روز |  |
| 2003 | 1.2.19.3.6.4 | بتن ریزی | 2d | 2016-04-12 | 2016-04-13 | 1998SS | 2016-04-27 | 2016-05-03 | 0d | 140d |  | 32h | 0% | 4 روز | 4 روز |  |
| 2004 | 1.2.19.4 | **سفت کاری** | 38d | 2016-04-08 | 2016-05-15 |  | 2015-12-27 | 2016-06-22 | 0d | 10d |  | 544h | 48% | 142 روز | 142 روز |  |
| 2005 | 1.2.19.4.1 | **همکف** | 31d | 2016-04-08 | 2016-05-08 |  | 2015-12-27 | 2016-01-25 | 0d | 10d |  | 360h | 60% | 26 روز | 26 روز |  |
| 2006 | 1.2.19.4.1.1 | اجرای کرسی چینی و عایق | 3d | 2016-04-08 | 2016-04-10 | 1988 |  |  |  | 10d | 0d |  |  |  |  |  |
| 2007 | 1.2.19.4.1.2 | اجرای دیوارهای پیرامونی | 10d | 2016-04-11 | 2016-04-20 | 2006 |  |  |  | 10d | 0d |  |  |  |  |  |
| 2008 | 1.2.19.4.1.3 | ساخت و نصب نعل درگاه های پیرامونی | 3d | 2016-04-21 | 2016-04-23 | 2007 |  |  |  | 115d | 0d |  |  |  |  |  |
| 2009 | 1.2.19.4.1.4 | ساخت فریم و چارچوب در و پنجره ها | 5d | 2016-04-24 | 2016-04-28 | 2008 | 2015-12-27 | 2016-01-05 | 0d | 115d | 0d | 72h | 100% | 9 روز | 9 روز |  |
| 2010 | 1.2.19.4.1.5 | ساخت درهای فولادی | 10d | 2016-04-24 | 2016-05-03 | 2009SS | 2015-12-27 | 2016-01-05 | 0d | 115d | 0d | 104h | 69% | 9 روز | 9 روز |  |
| 2011 | 1.2.19.4.1.6 | اجرای بلوکاژ | 5d | 2016-05-04 | 2016-05-08 | 2010 |  |  |  | 115d |  |  |  |  |  |  |
| 2012 | 1.2.19.4.1.7 | اجرای دیوار جداکننده داخلی | 5d | 2016-04-24 | 2016-04-28 | 2010SS |  |  |  | 115d | 0d |  |  |  |  |  |
| 2013 | 1.2.19.4.1.8 | ساخت و نصب نعل درگاه های داخلی | 5d | 2016-04-24 | 2016-04-28 | 2010SS |  |  |  | 125d |  |  |  |  |  |  |
| 2014 | 1.2.19.4.1.9 | اجرای گچ و خاک دیوارها | 10d | 2016-04-29 | 2016-05-08 | 2012 |  |  |  | 115d |  |  |  |  |  |  |
| 2015 | 1.2.19.4.1.10 | رابیتس بندی مرحله اول | 10d | 2016-04-29 | 2016-05-08 | 2012 | 2016-01-05 | 2016-01-25 | 0d | 115d |  | 184h | 0% | 18 روز | 18 روز |  |

| ID | WBS | Task | Duration | Start | Finish | Predecessors | Baseline start | Baseline finish | Baseline duration | Total slack | Free slack | Work | Text1 | Text4 | Text5 | Text22 |
| --- | --- | --- | --- | --- | --- | --- | --- | --- | --- | --- | --- | --- | --- | --- | --- | --- |
| 2016 | 1.2.19.4.2 | **طبقه اول** | 25d | 2016-04-21 | 2016-05-15 |  | 2016-01-06 | 2016-06-19 | 0d | 10d |  | 184h | 58% | 130 روز | 130 روز | 95 |
| 2017 | 1.2.19.4.2.1 | اجرای دیوارهای پیرامونی | 5d | 2016-04-21 | 2016-04-25 | 2007 | 2016-01-06 | 2016-01-18 | 0d | 10d | 0d | 128h | 100% | 11 روز | 11 روز | 12 |
| 2018 | 1.2.19.4.2.2 | ساخت و نصب نعل درگاه های پیرامونی | 5d | 2016-04-21 | 2016-04-25 | 2017SS | 2016-01-06 | 2016-01-18 | 0d | 10d | 0d | 56h | 14% | 11 روز | 11 روز |  |
| 2019 | 1.2.19.4.2.3 | اجرای دیوار جداکننده داخلی | 5d | 2016-04-26 | 2016-04-30 | 2018 |  |  |  | 10d | 0d |  |  |  |  |  |
| 2020 | 1.2.19.4.2.4 | ساخت و نصب نعل درگاه های داخلی | 5d | 2016-04-21 | 2016-04-25 | 2018SS |  |  |  | 57d | 0d |  |  |  |  |  |
| 2021 | 1.2.19.4.2.5 | اجرای گچ و خاک دیوارها | 15d | 2016-05-01 | 2016-05-15 | 2019 |  |  |  | 10d | 0d |  |  |  |  |  |
| 2022 | 1.2.19.5 | **بام ( مرحله اول )** | 19d | 2016-04-26 | 2016-05-14 |  |  |  |  | 57d |  |  |  |  |  |  |
| 2023 | 1.2.19.5.1 | اجرای دیوار جان پناه پشت بام و خرپشته | 6d | 2016-04-26 | 2016-05-01 | 2020 |  |  |  | 57d | 0d |  |  |  |  |  |
| 2024 | 1.2.19.5.2 | سیمانکاری دیوار جانپناه | 3d | 2016-05-02 | 2016-05-04 | 2023 |  |  |  | 109d | 0d |  |  |  |  |  |
| 2025 | 1.2.19.5.3 | رابیتس بندی | 10d | 2016-05-05 | 2016-05-14 | 2024 |  |  |  | 109d |  |  |  |  |  |  |
| 2026 | 1.2.19.6 | **اجرای نمای بیرونی** | 65d | 2016-05-02 | 2016-07-05 |  |  |  |  | 57d |  |  |  |  |  |  |
| 2027 | 1.2.19.6.1 | اجرای سنگ پلاک نما به همراه فتیله | 7d | 2016-05-02 | 2016-05-08 | 2023 |  |  |  | 57d | 0d |  |  |  |  |  |
| 2028 | 1.2.19.6.2 | اجرای سنگ باکس تیر ها و ستون ها | 30d | 2016-05-02 | 2016-05-31 | 2027SS |  |  |  | 92d | 0d |  |  |  |  |  |
| 2029 | 1.2.19.6.3 | اجرای سنگ پیش آمدگی ها | 30d | 2016-05-02 | 2016-05-31 | 2028SS |  |  |  | 92d |  |  |  |  |  |  |
| 2030 | 1.2.19.6.4 | اجرای آستر سیمان سیاه دیوار جهت زیر سازی نمای شسته | 35d | 2016-05-02 | 2016-06-05 | 2027SS |  |  |  | 57d | 0d |  |  |  |  |  |
| 2031 | 1.2.19.6.5 | اجرای نمای شسته | 45d | 2016-05-12 | 2016-06-25 | 2030SS+10d |  |  |  | 57d | 0d |  |  |  |  |  |
| 2032 | 1.2.19.6.6 | اجرای درپوش بتنی جانپناه و کف پنجره ها | 10d | 2016-06-26 | 2016-07-05 | 2031 |  |  |  | 57d |  |  |  |  |  |  |
| 2033 | 1.2.19.7 | **تاسیسات مکانیکی ( مرحله اول )** | 50d | 2016-05-16 | 2016-07-04 |  |  |  |  | 10d |  |  |  |  |  |  |
| 2034 | 1.2.19.7.1 | سوراخکاری و شیارزنی و کنده کاری داکت | 4d | 2016-05-16 | 2016-05-19 | 2021 |  |  |  | 10d | 0d |  |  |  |  |  |
| 2035 | 1.2.19.7.2 | کانال کنی تاسیسات | 5d | 2016-05-16 | 2016-05-20 | 2034SS |  |  |  | 10d | 0d |  |  |  |  |  |
| 2036 | 1.2.19.7.3 | لوله کشی پلی اتیلن فاضلاب و آب باران | 10d | 2016-05-21 | 2016-05-30 | 2035 |  |  |  | 10d | 0d |  |  |  |  |  |
| 2037 | 1.2.19.7.4 | ساپورتهای لوله کشی تاسیسات | 5d | 2016-05-21 | 2016-05-25 | 2036SS |  |  |  | 88d | 0d |  |  |  |  |  |
| 2038 | 1.2.19.7.5 | لوله کشی گالوانیزه آب سرد و گرم | 10d | 2016-05-26 | 2016-06-04 | 2037 |  |  |  | 88d |  |  |  |  |  |  |
| 2039 | 1.2.19.7.6 | لوله کشی لوله های گرمایشی و پنج لایه | 20d | 2016-05-31 | 2016-06-19 | 2036 |  |  |  | 68d | 0d |  |  |  |  |  |
| 2040 | 1.2.19.7.7 | اجرای ساپورتهای کانال کولر | 5d | 2016-05-31 | 2016-06-04 | 2036 |  |  |  | 10d | 0d |  |  |  |  |  |
| 2041 | 1.2.19.7.8 | اجرای کانال کولر | 30d | 2016-06-05 | 2016-07-04 | 2040 |  |  |  | 10d | 0d |  |  |  |  |  |
| 2042 | 1.2.19.7.9 | اجرای کانال اگزاست | 20d | 2016-06-05 | 2016-06-24 | 2041SS |  |  |  | 68d |  |  |  |  |  |  |
| 2043 | 1.2.19.7.10 | عایق پشم شیشه و تست | 5d | 2016-06-20 | 2016-06-24 | 2039 |  |  |  | 68d |  |  |  |  |  |  |
| 2044 | 1.2.19.7.11 | اجرای لوله هایPVC | 2d | 2016-05-21 | 2016-05-22 | 2036SS |  |  |  | 35d | 0d |  |  |  |  |  |

| ID | WBS | Task | Duration | Start | Finish | Predecessors | Total slack | Free slack |
| --- | --- | --- | --- | --- | --- | --- | --- | --- |
| 2045 | 1.2.19.8 | **تاسیسات الکتریکی ( مرحله اول )** | 25d | 2016-05-16 | 2016-06-09 |  | 83d |  |
| 2046 | 1.2.19.8.1 | شیارزنی | 10d | 2016-05-16 | 2016-05-25 | 2034SS | 83d | 0d |
| 2047 | 1.2.19.8.2 | اجرای لوله های PVC . PG13/5 | 15d | 2016-05-26 | 2016-06-09 | 2046 | 83d | 0d |
| 2048 | 1.2.19.8.3 | اجرای لوله های PVC . PG16-42 | 15d | 2016-05-26 | 2016-06-09 | 2047SS | 83d | 0d |
| 2049 | 1.2.19.8.4 | تهیه ساخت و سفارش تابلو برق | 10d | 2016-05-16 | 2016-05-25 | 2046SS | 97d | 0d |
| 2050 | 1.2.19.8.5 | غلاف گزاری | 3d | 2016-05-26 | 2016-05-28 | 2048SS | 90d | 0d |
| 2051 | 1.2.19.8.6 | سینی کابل | 5d | 2016-05-29 | 2016-06-02 | 2050 | 90d |  |
| 2052 | 1.2.19.8.7 | نصب تابلو | 1d | 2016-05-26 | 2016-05-26 | 2049 | 97d |  |
| 2053 | 1.2.19.9 | **بام ( مرحله دوم )** | 42d | 2016-05-23 | 2016-07-03 |  | 35d |  |
| 2054 | 1.2.19.9.1 | شیب بندی و اجرای بتن سبک بام | 5d | 2016-05-23 | 2016-05-27 | 2044 | 35d | 0d |
| 2055 | 1.2.19.9.2 | اجرای سیمانکاری لیسه ای زیر عایق | 2d | 2016-05-28 | 2016-05-29 | 2054 | 59d | 0d |
| 2056 | 1.2.19.9.3 | اجرای عایق پشت بام | 2d | 2016-05-30 | 2016-05-31 | 2055 | 59d | 0d |
| 2057 | 1.2.19.9.4 | نصب تور مرغی قبل از سنگ اندود | 1d | 2016-06-01 | 2016-06-01 | 2056 | 59d | 0d |
| 2058 | 1.2.19.9.5 | اجرای سنگ قرنیز لاشتر | 4d | 2016-06-02 | 2016-06-05 | 2057 | 59d | 0d |
| 2059 | 1.2.19.9.6 | اجرای آستر سیمان سیاه و سفید بام | 10d | 2016-06-06 | 2016-06-15 | 2058 | 59d | 0d |
| 2060 | 1.2.19.9.7 | شیب بندی و اجرای موزاییک بام | 15d | 2016-06-16 | 2016-06-30 | 2059 | 59d | 0d |
| 2061 | 1.2.19.9.8 | نصب قرنیز گالوانیزه بام | 3d | 2016-07-01 | 2016-07-03 | 2060 | 59d |  |
| 2062 | 1.2.19.10 | **نازک کاری** | 66d | 2016-05-23 | 2016-07-27 |  | 23d |  |
| 2063 | 1.2.19.10.1 | **طبقه همکف** | 31d | 2016-05-23 | 2016-06-22 |  | 35d |  |
| 2064 | 1.2.19.10.1.1 | اجرای کرم بندی و شیب بندی سرویسها و سالن غذاخوری | 4d | 2016-05-23 | 2016-05-26 | 2054SS | 35d | 0d |
| 2065 | 1.2.19.10.1.2 | اجرای عایق رطوبتی سالن غذاخوری و سرویسها | 2d | 2016-05-27 | 2016-05-28 | 2064 | 35d | 0d |
| 2066 | 1.2.19.10.1.3 | اجرای سیمان محافظ روی عایق | 2d | 2016-05-29 | 2016-05-30 | 2065 | 93d |  |
| 2067 | 1.2.19.10.1.4 | چیدن دیوارهای داکت | 2d | 2016-05-23 | 2016-05-24 | 2064SS | 99d |  |
| 2068 | 1.2.19.10.1.5 | نصب چارچوبهای در و پنجره | 5d | 2016-05-23 | 2016-05-27 | 2064SS | 96d |  |
| 2069 | 1.2.19.10.1.6 | اجرای قرنیز و سنگ و پلاک فضای داخلی دیوارها | 10d | 2016-05-29 | 2016-06-07 | 2065 | 35d | 0d |
| 2070 | 1.2.19.10.1.7 | اجرای گچ سفید دیوارها | 15d | 2016-06-08 | 2016-06-22 | 2069 | 70d |  |
| 2071 | 1.2.19.10.1.8 | اجرای کاشی دیوار سرویسها | 10d | 2016-05-29 | 2016-06-07 | 2065 | 80d | 0d |
| 2072 | 1.2.19.10.1.9 | اجرای سرامیک کف | 5d | 2016-06-08 | 2016-06-12 | 2071 | 80d |  |
| 2073 | 1.2.19.10.1.10 | اجرای سنگ گرانیت و چینی و موزائیک کف | 5d | 2016-06-08 | 2016-06-12 | 2069 | 70d | 0d |
| 2074 | 1.2.19.10.1.11 | اجرای سقف کاذب ( کناف فضای داخلی ) | 10d | 2016-06-13 | 2016-06-22 | 2073 | 70d |  |
| 2075 | 1.2.19.10.1.12 | اجرای سقف کاذب ( سرویس بهداشتی ) | 4d | 2016-06-08 | 2016-06-11 | 2071 | 81d |  |

| ID | WBS | Task | Duration | Start | Finish | Predecessors | Baseline start | Baseline finish | Baseline duration | Total slack | Free slack | Work | Text1 | Text4 | Text5 | Text22 |
| --- | --- | --- | --- | --- | --- | --- | --- | --- | --- | --- | --- | --- | --- | --- | --- | --- |
| 2076 | 1.2.19.10.2 | **طبقه اول** | 25d | 2016-06-05 | 2016-06-29 |  |  |  |  | 10d |  |  |  |  |  |  |
| 2077 | 1.2.19.10.2.1 | نصب چارچوبهای در و پنجره | 3d | 2016-06-05 | 2016-06-07 | 2041SS |  |  |  | 10d | 0d |  |  |  |  |  |
| 2078 | 1.2.19.10.2.2 | اجرای قرنیز و سنگ و پلاک فضای داخلی دیوارها | 7d | 2016-06-08 | 2016-06-14 | 2077 |  |  |  | 10d | 0d |  |  |  |  |  |
| 2079 | 1.2.19.10.2.3 | اجرای سنگ گرانیت کف | 5d | 2016-06-15 | 2016-06-19 | 2078 |  |  |  | 10d | 0d |  |  |  |  |  |
| 2080 | 1.2.19.10.2.4 | اجرای گچ سفید | 10d | 2016-06-15 | 2016-06-24 | 2078 |  |  |  | 68d |  |  |  |  |  |  |
| 2081 | 1.2.19.10.2.5 | اجرای سقف کاذب ( کناف فضای داخلی ) | 10d | 2016-06-20 | 2016-06-29 | 2079 |  |  |  | 10d | 0d |  |  |  |  |  |
| 2082 | 1.2.19.10.3 | **راه پله** | 34d | 2016-06-08 | 2016-07-11 |  |  |  |  | 35d |  |  |  |  |  |  |
| 2083 | 1.2.19.10.3.1 | اجرای سنگ بدنه | 8d | 2016-06-08 | 2016-06-15 | 2069 |  |  |  | 35d | 0d |  |  |  |  |  |
| 2084 | 1.2.19.10.3.2 | اجرای سنگ پله ها | 10d | 2016-06-08 | 2016-06-17 | 2083SS |  |  |  | 35d | 0d |  |  |  |  |  |
| 2085 | 1.2.19.10.3.3 | اجرای رابتس زیر پله | 5d | 2016-06-16 | 2016-06-20 | 2084FS-2d |  |  |  | 35d | 0d |  |  |  |  |  |
| 2086 | 1.2.19.10.3.4 | اجرای گچ و خاک پله ها | 8d | 2016-06-21 | 2016-06-28 | 2085 |  |  |  | 35d | 0d |  |  |  |  |  |
| 2087 | 1.2.19.10.3.5 | اجرای گچ سفید | 8d | 2016-06-29 | 2016-07-06 | 2086 |  |  |  | 51d | 0d |  |  |  |  |  |
| 2088 | 1.2.19.10.3.6 | اجرای لگه گیری گچ سفید زیر و بغل پله | 5d | 2016-07-07 | 2016-07-11 | 2087 |  |  |  | 51d |  |  |  |  |  |  |
| 2089 | 1.2.19.10.4 | **نصبیات و تکمیلی نازک کاری** | 29d | 2016-06-29 | 2016-07-27 |  |  |  |  | 35d |  |  |  |  |  |  |
| 2090 | 1.2.19.10.4.1 | نصب در و پنجره های جوبی ، فولادی و UPVC | 7d | 2016-06-29 | 2016-07-05 | 2086 |  |  |  | 35d | 0d |  |  |  |  |  |
| 2091 | 1.2.19.10.4.2 | نصب شیشه ها | 7d | 2016-07-06 | 2016-07-12 | 2090 |  |  |  | 35d | 0d |  |  |  |  |  |
| 2092 | 1.2.19.10.4.3 | رنگ آمیزی سقف و دیوار | 15d | 2016-07-13 | 2016-07-27 | 2091 |  |  |  | 35d |  |  |  |  |  |  |
| 2093 | 1.2.19.11 | **تاسیسات الکتریکی ( مرحله دوم )** | 36d | 2016-06-25 | 2016-07-30 |  | 2016-01-05 | 2016-08-04 | 0d | 10d |  | 72h | 7% | 170 | 170 | 73 |
| 2094 | 1.2.19.11.1 | اجرای سیم کشی و کابل کشی ساختمان | 15d | 2016-06-25 | 2016-07-09 | 2081SS+5d |  |  |  | 10d | 0d |  |  |  |  |  |
| 2095 | 1.2.19.11.2 | کابل کشی مخابرات و تجهیزات مربوطه | 5d | 2016-07-10 | 2016-07-14 | 2094 |  |  |  | 43d | 0d |  |  |  |  |  |
| 2096 | 1.2.19.11.3 | اجرا و نصب تابلو برق و جریان ضعیف | 5d | 2016-07-15 | 2016-07-19 | 2095 |  |  |  | 43d |  |  |  |  |  |  |
| 2097 | 1.2.19.11.4 | کلید و پریز | 5d | 2016-07-10 | 2016-07-14 | 2094 |  |  |  | 10d | 0d |  |  |  |  |  |
| 2098 | 1.2.19.11.5 | چراغ های ایندور | 5d | 2016-07-15 | 2016-07-19 | 2097 |  |  |  | 10d | 0d |  |  |  |  |  |
| 2099 | 1.2.19.11.6 | سیستم اعلام حریق | 5d | 2016-07-20 | 2016-07-24 | 2098 |  |  |  | 10d | 0d |  |  |  |  |  |
| 2100 | 1.2.19.11.7 | سیستم آنتن مرکزی | 3d | 2016-07-25 | 2016-07-27 | 2099 |  |  |  | 10d | 0d |  |  |  |  |  |
| 2101 | 1.2.19.11.8 | ارت سازی | 3d | 2016-07-28 | 2016-07-30 | 2100 | 2016-01-05 | 2016-01-14 | 0d | 10d | 0d | 72h | 60% | 9 روز | 9 روز | 10 |

| ID | WBS | Task | Duration | Start | Finish | Predecessors | Baseline start | Baseline finish | Baseline duration | Total slack | Free slack | Constraint | Work | Text1 | Text4 | Text5 | Text22 |
| --- | --- | --- | --- | --- | --- | --- | --- | --- | --- | --- | --- | --- | --- | --- | --- | --- | --- |
| 2102 | 1.2.19.12 | **تاسیسات مکانیکی ( مرحله دوم )** | 22d | 2016-07-31 | 2016-08-21 |  |  |  |  | 10d |  |  | 360h |  |  |  |  |
| 2103 | 1.2.19.12.1 | شیر آلات بهداشتی | 5d | 2016-07-31 | 2016-08-04 | 2101 | 2016-01-28 | 2016-02-11 | 0d | 10d | 0d |  | 104h | 100% | 13 روز | 13 روز | 10 |
| 2104 | 1.2.19.12.2 | تجهیزات آتش نشانی | 4d | 2016-08-05 | 2016-08-08 | 2103 |  |  |  | 10d | 0d |  |  |  |  |  |  |
| 2105 | 1.2.19.12.3 | نصب رادیاتور | 10d | 2016-08-09 | 2016-08-18 | 2104 | 2016-02-13 | 2016-02-23 | 0d | 10d | 0d |  | 80h | 0% | 10 روز | 10 روز |  |
| 2106 | 1.2.19.12.4 | نصب دریچه های هوا و کولر | 3d | 2016-08-19 | 2016-08-21 | 2105 | 2016-02-24 | 2016-04-03 | 0d | 10d |  |  | 176h | 0% | 22 روز | 22 روز | 12 |
| 2107 | 1.3 | **مجموع فعالیتهای پایانی** | 72d | 2016-06-21 | 2016-08-31 |  |  |  |  | 0d |  |  |  |  |  |  |  |
| 2108 | 1.3.1 | رفع نواقص و تکمیل جا افتادگیها | 65d | 2016-06-21 | 2016-08-24 |  |  |  |  | 0d |  | start no earlier than 2016-06-21 |  |  |  |  |  |
| 2109 | 1.3.2 | برچیدن کارگاه | 6d | 2016-08-25 | 2016-08-30 | 2108 |  |  |  | 0d |  |  |  |  |  |  |  |
| 2110 | 1.3.3 | تحویل پروژه | 1d | 2016-08-31 | 2016-08-31 | 2109 |  |  |  | 0d |  |  |  |  |  |  |  |
