# برنامه زمانبندی اهواز 95.02.28

Schedule from MS Project, 2016-01-16 to 2018-03-15, status date 2016-07-15, costs in ريال, A marks actual dates.

## Calendars

- Standard: Mon-Sun 08:00-12:00, 13:00-17:00.

## Schedule

| ID | WBS | Task | Type | Duration | Start | Finish | Predecessors | Complete | Remaining | Baseline start | Baseline finish | Baseline duration | Baseline 1 start | Baseline 1 finish | Total slack | Free slack | Cost | Baseline cost | Actual cost | وزن فعالیت | پايان | شروع | Text10 |
| --- | --- | --- | --- | --- | --- | --- | --- | --- | --- | --- | --- | --- | --- | --- | --- | --- | --- | --- | --- | --- | --- | --- | --- |
| 1 | 1 | **پروژه احداث ساختمان خدماتی و بهداشتی** |  | 790d | 2016-01-16 A | 2018-03-15 |  | 8% | 724.44d | 2016-01-16 | 2018-03-15 | 790d | 2016-01-16 | 2018-03-15 | 0d |  | 43,602,699,434 | 43,602,699,434 | 6,755,321,407 | 100 | '96 اسفند 24 | '94 دی 26 | 100 |
| 2 | 1.1 | شروع | milestone | 0d | 2016-01-16 A | 2016-01-16 A |  | 100% |  | 2016-01-16 | 2016-01-16 | 0d | 2016-01-16 | 2016-01-16 |  |  |  |  |  |  | '94 دی 26 | '94 دی 26 |  |
| 3 | 1.2 | تحویل زمین |  | 5d | 2016-01-16 A | 2016-01-20 A |  | 100% |  | 2016-01-16 | 2016-01-20 | 5d | 2016-01-16 | 2016-01-20 |  |  |  |  |  | 0.06 | '94 دی 30 | '94 دی 26 | 0.05 |
| 4 | 1.3 | **تجهیز کارگاه** |  | 30d | 2016-01-21 A | 2016-02-19 A |  | 100% |  | 2016-01-21 | 2016-02-19 | 30d | 2016-01-21 | 2016-02-19 |  |  | 2,320,000,000 | 2,320,000,000 | 2,320,000,000 | 2.13 | '94 بهمن 30 | '94 بهمن 01 | 2.11 |
| 5 | 1.3.1 | حمل تجهیزات به کارگاه |  | 5d | 2016-01-21 A | 2016-01-25 A | 3 | 100% |  | 2016-01-21 | 2016-01-25 | 5d | 2016-01-21 | 2016-01-25 |  |  | 1,300,000,000 | 1,300,000,000 | 1,300,000,000 | 1.07 | '94 بهمن 05 | '94 بهمن 01 | 1.04 |
| 6 | 1.3.2 | آماده سازی کارگاه |  | 30d | 2016-01-21 A | 2016-02-19 A | 5SS | 100% |  | 2016-01-21 | 2016-02-19 | 30d | 2016-01-21 | 2016-02-19 |  |  | 1,000,000,000 | 1,000,000,000 | 1,000,000,000 | 0.99 | '94 بهمن 30 | '94 بهمن 01 | 0.99 |
| 7 | 1.3.3 | نصب توری محافظ و تابلو مشخصات |  | 5d | 2016-02-14 A | 2016-02-18 A | 6SS+8% | 100% |  | 2016-02-14 | 2016-02-18 | 5d | 2016-02-14 | 2016-02-18 |  |  | 20,000,000 | 20,000,000 | 20,000,000 | 0.07 | '94 بهمن 29 | '94 بهمن 25 | 0.07 |
| 8 | 1.4 | **تخریب و حمل نخاله** |  | 90d | 2016-01-21 A | 2016-04-19 A |  | 100% |  | 2016-01-21 | 2016-04-19 | 90d | 2016-01-21 | 2016-04-19 |  |  | 700,000,000 | 700,000,000 | 700,000,000 | 1.96 | '95 فروردین 31 | '94 بهمن 01 | 1.83 |
| 9 | 1.4.1 | اجرای عملیات تخریب ساختمان های موجود و حمل نخاله حاصله |  | 90d | 2016-01-21 A | 2016-04-19 A | 5SS | 100% |  | 2016-01-21 | 2016-04-19 | 90d | 2016-01-21 | 2016-04-19 |  |  | 700,000,000 | 700,000,000 | 700,000,000 | 1.96 | '95 فروردین 31 | '94 بهمن 01 | 1.83 |
| 10 | 1.5 | **خاکبرداری** |  | 23d | 2016-04-20 A | 2016-05-12 A |  | 100% |  | 2016-04-20 | 2016-05-12 | 23d | 2016-04-20 | 2016-05-12 |  |  | 375,750,407 | 375,750,407 | 375,750,407 | 0.85 | '95 اردیبهشت 23 | '95 اردیبهشت 01 | 0.81 |
| 11 | 1.5.1 | خاک برداری با وسائل مکانیکی |  | 20d | 2016-04-20 A | 2016-05-09 A | 9 | 100% |  | 2016-04-20 | 2016-05-09 | 20d | 2016-04-20 | 2016-05-09 |  |  | 305,750,407 | 305,750,407 | 305,750,407 | 0.64 | '95 اردیبهشت 20 | '95 اردیبهشت 01 | 0.62 |
| 12 | 1.5.2 | تسطیح ورگلاز سطوح خاک برداری |  | 5d | 2016-05-06 A | 2016-05-10 A | 11SS+8% | 100% |  | 2016-05-06 | 2016-05-10 | 5d | 2016-05-06 | 2016-05-10 |  |  | 20,000,000 | 20,000,000 | 20,000,000 | 0.08 | '95 اردیبهشت 21 | '95 اردیبهشت 17 | 0.07 |
| 13 | 1.5.3 | حمل خاک اضافه |  | 5d | 2016-05-08 A | 2016-05-12 A | 12FS-3d | 100% |  | 2016-05-08 | 2016-05-12 | 5d | 2016-05-08 | 2016-05-12 |  |  | 50,000,000 | 50,000,000 | 50,000,000 | 0.12 | '95 اردیبهشت 23 | '95 اردیبهشت 19 | 0.12 |
| 14 | 1.6 | **اجرای فونداسیون** |  | 68d | 2016-05-13 A | 2016-07-19 |  | 95% | 3.4d | 2016-05-13 | 2016-07-19 | 68d | 2016-05-13 | 2016-07-19 | 604d |  | 2,360,355,000 | 2,360,355,000 | 1,528,071,000 | 4.14 | '95 تیر 29 | '95 اردیبهشت 24 | 4.1 |
| 15 | 1.6.1 | اجرای لاشه چینی واجرای بتن مگر |  | 20d | 2016-05-13 A | 2016-06-01 A | 13 | 100% |  | 2016-05-13 | 2016-06-01 | 20d | 2016-05-13 | 2016-06-01 |  |  | 450,000,000 | 450,000,000 | 450,000,000 | 0.84 | '95 خرداد 12 | '95 اردیبهشت 24 | 0.83 |
| 16 | 1.6.2 | اجرای قالب بندی آجری فونداسیون |  | 15d | 2016-06-02 A | 2016-06-16 A | 15 | 100% |  | 2016-06-02 | 2016-06-16 | 15d | 2016-06-02 | 2016-06-16 |  |  | 100,000,000 | 100,000,000 | 100,000,000 | 0.3 | '95 خرداد 27 | '95 خرداد 13 | 0.28 |
| 17 | 1.6.3 | خم وبرشکاری و اجرای آرماتور بندی و اتصالات |  | 25d | 2016-06-10 A | 2016-07-04 A | 15FS+8d | 100% |  | 2016-06-10 | 2016-07-04 | 25d | 2016-06-10 | 2016-07-04 |  |  | 730,000,000 | 730,000,000 | 730,000,000 | 1.28 | '95 تیر 14 | '95 خرداد 21 | 1.27 |
| 18 | 1.6.4 | قالب بندی چاله آسانسور ها |  | 5d | 2016-07-05 A | 2016-07-09 A | 17 | 100% |  | 2016-07-05 | 2016-07-09 | 5d | 2016-07-05 | 2016-07-09 |  |  | 20,000,000 | 20,000,000 | 20,000,000 | 0.08 | '95 تیر 19 | '95 تیر 15 | 0.07 |
| 19 | 1.6.5 | نصب شابلون صفحه ستون ها |  | 10d | 2016-07-05 A | 2016-07-14 A | 17 | 100% |  | 2016-07-05 | 2016-07-14 | 10d | 2016-07-05 | 2016-07-14 |  |  | 20,000,000 | 20,000,000 | 20,000,000 | 0.14 | '95 تیر 24 | '95 تیر 15 | 0.12 |
| 20 | 1.6.6 | بتن ریزی |  | 5d | 2016-07-15 A | 2016-07-19 | 19 | 20% | 4d | 2016-07-15 | 2016-07-19 | 5d | 2016-07-15 | 2016-07-19 | 604d |  | 1,040,355,000 | 1,040,355,000 | 208,071,000 | 1.49 | '95 تیر 29 | '95 تیر 25 | 1.53 |
| 21 | 1.7 | **اجرای اسکلت** |  | 156d | 2016-06-17 A | 2016-11-19 |  | 16% | 130.47d | 2016-06-17 | 2016-11-19 | 156d | 2016-06-17 | 2016-11-19 | 481d |  | 10,000,000,000 | 10,000,000,000 | 1,831,500,000 | 17.45 | '95 آبان 29 | '95 خرداد 28 | 14.26 |
| 22 | 1.7.1 | **ساخت اسکلت پارت اول** |  | 44d | 2016-06-17 A | 2016-07-30 |  | 61% | 17.05d | 2016-06-17 | 2016-07-30 | 44d | 2016-06-17 | 2016-07-30 | 593d |  | 3,150,000,000 | 3,150,000,000 | 1,644,000,000 | 5.23 | '95 مرداد 09 | '95 خرداد 28 | 5.44 |
| 23 | 1.7.1.1 | برشکاری |  | 20d | 2016-06-17 A | 2016-07-06 A | 16 | 100% |  | 2016-06-17 | 2016-07-06 | 20d | 2016-06-17 | 2016-07-06 |  |  | 600,000,000 | 600,000,000 | 600,000,000 | 1.05 | '95 تیر 16 | '95 خرداد 28 | 1.25 |
| 24 | 1.7.1.2 | مونتاژ |  | 20d | 2016-06-27 A | 2016-07-16 | 23FS-10d | 95% | 1d | 2016-06-27 | 2016-07-16 | 20d | 2016-06-27 | 2016-07-16 | 598d | 0d | 600,000,000 | 600,000,000 | 570,000,000 | 1.05 | '95 تیر 26 | '95 تیر 07 | 1.25 |
| 25 | 1.7.1.3 | جوشکاری |  | 20d | 2016-07-11 A | 2016-07-30 | 24FS-3% | 25% | 15d | 2016-07-11 | 2016-07-30 | 20d | 2016-07-11 | 2016-07-30 | 593d | 0d | 1,500,000,000 | 1,500,000,000 | 375,000,000 | 2.29 | '95 مرداد 09 | '95 تیر 21 | 1.68 |
| 26 | 1.7.1.4 | رنگ آمیزی |  | 15d | 2016-07-11 A | 2016-07-25 | 25SS | 33% | 10d | 2016-07-11 | 2016-07-25 | 15d | 2016-07-11 | 2016-07-25 | 528d | 0d | 300,000,000 | 300,000,000 | 99,000,000 | 0.58 | '95 مرداد 04 | '95 تیر 21 | 0.99 |
| 27 | 1.7.1.5 | حمل اسکات |  | 5d | 2016-07-21 | 2016-07-25 | 26FF |  |  | 2016-07-21 | 2016-07-25 | 5d | 2016-07-21 | 2016-07-25 | 528d | 0d | 150,000,000 | 150,000,000 |  | 0.26 | '95 مرداد 04 | '95 تیر 31 | 0.26 |

| ID | WBS | Task | Duration | Start | Finish | Predecessors | Complete | Remaining | Baseline start | Baseline finish | Baseline duration | Baseline 1 start | Baseline 1 finish | Total slack | Free slack | Cost | Baseline cost | Actual cost | وزن فعالیت | پايان | شروع | Text10 |
| --- | --- | --- | --- | --- | --- | --- | --- | --- | --- | --- | --- | --- | --- | --- | --- | --- | --- | --- | --- | --- | --- | --- |
| 28 | 1.7.2 | **ساخت اسکلت پارت دوم** | 62d | 2016-07-11 A | 2016-09-10 |  | 6% | 58.12d | 2016-07-11 | 2016-09-10 | 62d | 2016-07-11 | 2016-09-10 | 0d |  | 3,450,000,000 | 3,450,000,000 | 187,500,000 | 5.65 | '95 شهریور 20 | '95 تیر 21 | 5.44 |
| 29 | 1.7.2.1 | برشکاری | 20d | 2016-07-11 A | 2016-07-30 | 25SS | 25% | 15d | 2016-07-11 | 2016-07-30 | 20d | 2016-07-11 | 2016-07-30 | 0d |  | 750,000,000 | 750,000,000 | 187,500,000 | 1.26 | '95 مرداد 09 | '95 تیر 21 | 1.25 |
| 30 | 1.7.2.2 | مونتاژ | 20d | 2016-07-25 | 2016-08-13 | 29FS-3% |  |  | 2016-07-25 | 2016-08-13 | 20d | 2016-07-25 | 2016-08-13 | 0d |  | 750,000,000 | 750,000,000 |  | 1.26 | '95 مرداد 23 | '95 مرداد 04 | 1.25 |
| 31 | 1.7.2.3 | جوشکاری | 20d | 2016-08-08 | 2016-08-27 | 30FS-3% |  |  | 2016-08-08 | 2016-08-27 | 20d | 2016-08-08 | 2016-08-27 | 0d |  | 1,500,000,000 | 1,500,000,000 |  | 2.29 | '95 شهریور 06 | '95 مرداد 18 | 1.68 |
| 32 | 1.7.2.4 | رنگ آمیزی | 15d | 2016-08-22 | 2016-09-05 | 31FS-3% |  |  | 2016-08-22 | 2016-09-05 | 15d | 2016-08-22 | 2016-09-05 | 0d |  | 300,000,000 | 300,000,000 |  | 0.58 | '95 شهریور 15 | '95 شهریور 01 | 0.99 |
| 33 | 1.7.2.5 | حمل اسکات | 5d | 2016-09-06 | 2016-09-10 | 32FF+5d |  |  | 2016-09-06 | 2016-09-10 | 5d | 2016-09-06 | 2016-09-10 | 0d |  | 150,000,000 | 150,000,000 |  | 0.26 | '95 شهریور 20 | '95 شهریور 16 | 0.26 |
| 34 | 1.7.3 | **نصب اسکلت پارت اول** | 70d | 2016-07-26 | 2016-10-03 |  |  |  | 2016-07-26 | 2016-10-03 | 70d | 2016-07-26 | 2016-10-03 | 528d |  | 1,700,000,000 | 1,700,000,000 |  | 3.29 | '95 مهر 12 | '95 مرداد 05 | 1.69 |
| 35 | 1.7.3.1 | نصب صفحه ستون ها و ستون ها | 40d | 2016-07-26 | 2016-09-03 | 27 |  |  | 2016-07-26 | 2016-09-03 | 40d | 2016-07-26 | 2016-09-03 | 528d | 0d | 750,000,000 | 750,000,000 |  | 1.48 | '95 شهریور 13 | '95 مرداد 05 | 0.72 |
| 36 | 1.7.3.2 | نصب تیر ها و اتصالات مربوطه | 30d | 2016-08-20 | 2016-09-18 | 35FS-15d |  |  | 2016-08-20 | 2016-09-18 | 30d | 2016-08-20 | 2016-09-18 | 528d | 0d | 750,000,000 | 750,000,000 |  | 1.37 | '95 شهریور 28 | '95 مرداد 30 | 0.63 |
| 37 | 1.7.3.3 | شاغول کاری ستون ها و رگلاژ تیرها | 5d | 2016-09-19 | 2016-09-23 | 36 |  |  | 2016-09-19 | 2016-09-23 | 5d | 2016-09-19 | 2016-09-23 | 528d | 0d | 100,000,000 | 100,000,000 |  | 0.19 | '95 مهر 02 | '95 شهریور 29 | 0.12 |
| 38 | 1.7.3.4 | گروت ریزی | 5d | 2016-09-24 | 2016-09-28 | 37 |  |  | 2016-09-24 | 2016-09-28 | 5d | 2016-09-24 | 2016-09-28 | 528d | 0d | 50,000,000 | 50,000,000 |  | 0.12 | '95 مهر 07 | '95 مهر 03 | 0.12 |
| 39 | 1.7.3.5 | تکمیل اتصالات | 5d | 2016-09-29 | 2016-10-03 | 38 |  |  | 2016-09-29 | 2016-10-03 | 5d | 2016-09-29 | 2016-10-03 | 528d |  | 50,000,000 | 50,000,000 |  | 0.12 | '95 مهر 12 | '95 مهر 08 | 0.12 |
| 40 | 1.7.4 | **نصب اسکلت پارت دوم** | 70d | 2016-09-11 | 2016-11-19 |  |  |  | 2016-09-11 | 2016-11-19 | 70d | 2016-09-11 | 2016-11-19 | 0d |  | 1,700,000,000 | 1,700,000,000 |  | 3.29 | '95 آبان 29 | '95 شهریور 21 | 1.69 |
| 41 | 1.7.4.1 | نصب صفحه ستون ها و ستون ها | 40d | 2016-09-11 | 2016-10-20 | 33 |  |  | 2016-09-11 | 2016-10-20 | 40d | 2016-09-11 | 2016-10-20 | 0d |  | 750,000,000 | 750,000,000 |  | 1.48 | '95 مهر 29 | '95 شهریور 21 | 0.72 |
| 42 | 1.7.4.2 | نصب تیر ها و اتصالات مربوطه | 30d | 2016-10-06 | 2016-11-04 | 41FS-15d |  |  | 2016-10-06 | 2016-11-04 | 30d | 2016-10-06 | 2016-11-04 | 0d |  | 750,000,000 | 750,000,000 |  | 1.37 | '95 آبان 14 | '95 مهر 15 | 0.63 |
| 43 | 1.7.4.3 | شاغول کاری ستون ها و رگلاژ تیرها | 5d | 2016-11-05 | 2016-11-09 | 42 |  |  | 2016-11-05 | 2016-11-09 | 5d | 2016-11-05 | 2016-11-09 | 0d |  | 100,000,000 | 100,000,000 |  | 0.19 | '95 آبان 19 | '95 آبان 15 | 0.12 |
| 44 | 1.7.4.4 | گروت ریزی | 5d | 2016-11-10 | 2016-11-14 | 43 |  |  | 2016-11-10 | 2016-11-14 | 5d | 2016-11-10 | 2016-11-14 | 0d |  | 50,000,000 | 50,000,000 |  | 0.12 | '95 آبان 24 | '95 آبان 20 | 0.12 |
| 45 | 1.7.4.5 | تکمیل اتصالات | 5d | 2016-11-15 | 2016-11-19 | 44 |  |  | 2016-11-15 | 2016-11-19 | 5d | 2016-11-15 | 2016-11-19 | 0d |  | 50,000,000 | 50,000,000 |  | 0.12 | '95 آبان 29 | '95 آبان 25 | 0.12 |
| 46 | 1.8 | **اجرای سقف طبقات** | 72d | 2016-11-20 | 2017-01-30 |  |  |  | 2016-11-20 | 2017-01-30 | 72d | 2016-11-20 | 2017-01-30 | 0d |  | 1,395,000,000 | 1,395,000,000 |  | 2.72 | '95 بهمن 11 | '95 آبان 30 | 2.65 |
| 47 | 1.8.1 | حمل مصالح لازم برای قالب بندی سقف | 5d | 2016-11-20 | 2016-11-24 | 45 |  |  | 2016-11-20 | 2016-11-24 | 5d | 2016-11-20 | 2016-11-24 | 0d |  | 50,000,000 | 50,000,000 |  | 0.12 | '95 آذر 04 | '95 آبان 30 | 0.12 |
| 48 | 1.8.2 | اجرای سقف اول | 15d | 2016-11-25 | 2016-12-09 | 47 |  |  | 2016-11-25 | 2016-12-09 | 15d | 2016-11-25 | 2016-12-09 | 0d |  | 390,000,000 | 390,000,000 |  | 0.7 | '95 آذر 19 | '95 آذر 05 | 0.69 |
| 49 | 1.8.3 | اجرای بتن سقف اول | 5d | 2016-12-10 | 2016-12-14 | 48 |  |  | 2016-12-10 | 2016-12-14 | 5d | 2016-12-10 | 2016-12-14 | 0d |  | 170,000,000 | 170,000,000 |  | 0.29 | '95 آذر 24 | '95 آذر 20 | 0.29 |
| 50 | 1.8.4 | اجرای سقف دوم | 15d | 2016-12-15 | 2016-12-29 | 49 |  |  | 2016-12-15 | 2016-12-29 | 15d | 2016-12-15 | 2016-12-29 | 0d |  | 340,000,000 | 340,000,000 |  | 0.64 | '95 دی 09 | '95 آذر 25 | 0.62 |
| 51 | 1.8.5 | اجرای بتن سقف دوم | 5d | 2016-12-30 | 2017-01-03 | 50 |  |  | 2016-12-30 | 2017-01-03 | 5d | 2016-12-30 | 2017-01-03 | 0d |  | 150,000,000 | 150,000,000 |  | 0.26 | '95 دی 14 | '95 دی 10 | 0.26 |
| 52 | 1.8.6 | اجرای سقف سوم | 15d | 2017-01-04 | 2017-01-18 | 51 |  |  | 2017-01-04 | 2017-01-18 | 15d | 2017-01-04 | 2017-01-18 | 0d |  | 155,000,000 | 155,000,000 |  | 0.38 | '95 دی 29 | '95 دی 15 | 0.36 |
| 53 | 1.8.7 | اجرای بتن سقف سوم | 5d | 2017-01-19 | 2017-01-23 | 52 |  |  | 2017-01-19 | 2017-01-23 | 5d | 2017-01-19 | 2017-01-23 | 0d |  | 80,000,000 | 80,000,000 |  | 0.17 | '95 بهمن 04 | '95 دی 30 | 0.16 |
| 54 | 1.8.8 | اجرای سقف چهارم | 5d | 2017-01-24 | 2017-01-28 | 53 |  |  | 2017-01-24 | 2017-01-28 | 5d | 2017-01-24 | 2017-01-28 | 0d |  | 50,000,000 | 50,000,000 |  | 0.12 | '95 بهمن 09 | '95 بهمن 05 | 0.12 |
| 55 | 1.8.9 | اجرای بتن سقف چهارم | 2d | 2017-01-29 | 2017-01-30 | 54 |  |  | 2017-01-29 | 2017-01-30 | 2d | 2017-01-29 | 2017-01-30 | 0d |  | 10,000,000 | 10,000,000 |  | 0.04 | '95 بهمن 11 | '95 بهمن 10 | 0.03 |

| ID | WBS | Task | Duration | Start | Finish | Predecessors | Baseline start | Baseline finish | Baseline duration | Baseline 1 start | Baseline 1 finish | Total slack | Free slack | Cost | Baseline cost | وزن فعالیت | پايان | شروع | Text10 |
| --- | --- | --- | --- | --- | --- | --- | --- | --- | --- | --- | --- | --- | --- | --- | --- | --- | --- | --- | --- |
| 56 | 1.9 | **ضد حریق اسکلت** | 30d | 2017-01-31 | 2017-03-01 |  | 2017-01-31 | 2017-03-01 | 30d | 2017-01-31 | 2017-03-01 | 0d |  | 1,800,000,000 | 1,800,000,000 | 2.82 | '95 اسفند 11 | '95 بهمن 12 | 2.84 |
| 57 | 1.9.1 | اجرای ضد حریق بر روی اسکلت فلزی | 30d | 2017-01-31 | 2017-03-01 | 55 | 2017-01-31 | 2017-03-01 | 30d | 2017-01-31 | 2017-03-01 | 0d |  | 1,800,000,000 | 1,800,000,000 | 2.82 | '95 اسفند 11 | '95 بهمن 12 | 2.84 |
| 58 | 1.10 | **اجرای دیوارهای داخلی و خارجی و جایگذاری چهارچوب ها و فریم ها و اجرای وال پست ها** | 54.5d | 2017-03-02 | 2017-04-25 |  | 2017-03-02 | 2017-04-25 | 54.5d | 2017-03-02 | 2017-04-25 | 0d |  | 1,950,000,000 | 1,950,000,000 | 3.72 | '96 اردیبهشت 05 | '95 اسفند 12 | 3.63 |
| 59 | 1.10.1 | اجرای دیوارهای داخلی و خارجی و جایگذاری چهارچوب های همکف | 40d | 2017-03-02 | 2017-04-10 | 57 | 2017-03-02 | 2017-04-10 | 40d | 2017-03-02 | 2017-04-10 | 0d |  | 900,000,000 | 900,000,000 | 1.69 | '96 فروردین 21 | '95 اسفند 12 | 1.65 |
| 60 | 1.10.2 | اجرای دیوارهای داخلی و خارجی و جایگذاری چهارچوب های اول | 29d | 2017-03-22 | 2017-04-19 | 59FS-5% | 2017-03-22 | 2017-04-19 | 29d | 2017-03-22 | 2017-04-19 | 0d |  | 510,000,000 | 510,000,000 | 1.03 | '96 فروردین 30 | '96 فروردین 02 | 0.99 |
| 61 | 1.10.3 | اجرای دیوارهای داخلی و خارجی و جایگذاری چهارچوب های دوم | 20d | 2017-04-05 | 2017-04-25 | 60FS-5% | 2017-04-05 | 2017-04-25 | 20d | 2017-04-05 | 2017-04-25 | 44.5d | 0d | 490,000,000 | 490,000,000 | 0.9 | '96 اردیبهشت 05 | '96 فروردین 16 | 0.88 |
| 62 | 1.10.4 | اجرای دیوارهای داخلی و خارجی و جایگذاری چهارچوب های سوم | 4d | 2017-04-21 | 2017-04-25 | 61FF | 2017-04-21 | 2017-04-25 | 4d | 2017-04-21 | 2017-04-25 | 59.5d | 0d | 50,000,000 | 50,000,000 | 0.11 | '96 اردیبهشت 05 | '96 اردیبهشت 01 | 0.11 |
| 63 | 1.11 | **آهن کشی شاسی آسانسور** | 30d | 2017-04-25 | 2017-05-25 |  | 2017-04-25 | 2017-05-25 | 30d | 2017-04-25 | 2017-05-25 | 294.5d |  | 400,000,000 | 400,000,000 | 0.88 | '96 خرداد 04 | '96 اردیبهشت 05 | 0.85 |
| 64 | 1.11.1 | اجرای آهن کشی شاسی آسانسورها | 30d | 2017-04-25 | 2017-05-25 | 61 | 2017-04-25 | 2017-05-25 | 30d | 2017-04-25 | 2017-05-25 | 294.5d |  | 400,000,000 | 400,000,000 | 0.88 | '96 خرداد 04 | '96 اردیبهشت 05 | 0.85 |
| 65 | 1.12 | **اجرای گچ و خاک طبقات** | 49d | 2017-04-11 | 2017-05-29 |  | 2017-04-11 | 2017-05-29 | 49d | 2017-04-11 | 2017-05-29 | 50d |  | 361,200,000 | 361,200,000 | 1.77 | '96 خرداد 08 | '96 فروردین 22 | 1.57 |
| 66 | 1.12.1 | اجرای گچ وخاک دیوار های طبقه ی سوم | 5d | 2017-04-25 | 2017-04-30 | 62 | 2017-04-25 | 2017-04-30 | 5d | 2017-04-25 | 2017-04-30 | 59.5d | 0d | 20,000,000 | 20,000,000 | 0.08 | '96 اردیبهشت 10 | '96 اردیبهشت 05 | 0.07 |
| 67 | 1.12.2 | اجرای گچ وخاک دیوارهای طبقه ی دوم | 30d | 2017-04-25 | 2017-05-25 | 61 | 2017-04-25 | 2017-05-25 | 30d | 2017-04-25 | 2017-05-25 | 44.5d | 0d | 76,200,000 | 76,200,000 | 0.44 | '96 خرداد 04 | '96 اردیبهشت 05 | 0.39 |
| 68 | 1.12.3 | اجرای گچ وخاک دیوار های طبقه اول | 40d | 2017-04-20 | 2017-05-29 | 60 | 2017-04-20 | 2017-05-29 | 40d | 2017-04-20 | 2017-05-29 | 50d | 0d | 104,000,000 | 104,000,000 | 0.59 | '96 خرداد 08 | '96 فروردین 31 | 0.52 |
| 69 | 1.12.4 | اجرای گچ وخاک دیوارهای طبقه همکف | 40d | 2017-04-11 | 2017-05-20 | 59 | 2017-04-11 | 2017-05-20 | 40d | 2017-04-11 | 2017-05-20 | 59d | 0d | 161,000,000 | 161,000,000 | 0.67 | '96 اردیبهشت 30 | '96 فروردین 22 | 0.6 |
| 70 | 1.13 | **لوله کشی فاضلاب و آب باران** | 29.5d | 2017-04-11 | 2017-05-10 |  | 2017-04-11 | 2017-05-10 | 29.5d | 2017-04-11 | 2017-05-10 | 9d |  | 40,000,000 | 40,000,000 | 0.72 | '96 اردیبهشت 20 | '96 فروردین 22 | 0.61 |
| 71 | 1.13.1 | لوله کشی فاضلاب همکف | 20d | 2017-04-11 | 2017-04-30 | 59 | 2017-04-11 | 2017-04-30 | 20d | 2017-04-11 | 2017-04-30 | 184d | 0d | 10,000,000 | 10,000,000 | 0.24 | '96 اردیبهشت 10 | '96 فروردین 22 | 0.2 |
| 72 | 1.13.2 | لوله کشی فاضلاب طبقه اول | 15d | 2017-04-20 | 2017-05-04 | 60 | 2017-04-20 | 2017-05-04 | 15d | 2017-04-20 | 2017-05-04 | 0d |  | 10,000,000 | 10,000,000 | 0.18 | '96 اردیبهشت 14 | '96 فروردین 31 | 0.15 |
| 73 | 1.13.3 | لوله کشی فاضلاب طبقه دوم | 15d | 2017-04-25 | 2017-05-10 | 61 | 2017-04-25 | 2017-05-10 | 15d | 2017-04-25 | 2017-05-10 | 170.5d | 0d | 10,000,000 | 10,000,000 | 0.18 | '96 اردیبهشت 20 | '96 اردیبهشت 05 | 0.15 |
| 74 | 1.13.4 | لوله کشی فاضلاب طبقه سوم و آب باران | 10d | 2017-04-25 | 2017-05-05 | 62 | 2017-04-25 | 2017-05-05 | 10d | 2017-04-25 | 2017-05-05 | 292.5d | 0d | 10,000,000 | 10,000,000 | 0.12 | '96 اردیبهشت 15 | '96 اردیبهشت 05 | 0.11 |
| 75 | 1.14 | **کف سازی و شیب بندی** | 29.5d | 2017-05-01 | 2017-05-30 |  | 2017-05-01 | 2017-05-30 | 29.5d | 2017-05-01 | 2017-05-30 | 4d |  | 433,500,000 | 433,500,000 | 1.51 | '96 خرداد 09 | '96 اردیبهشت 11 | 1.37 |
| 76 | 1.14.1 | کف سازی و شیب بندی طبقه همکف | 20d | 2017-05-01 | 2017-05-20 | 71 | 2017-05-01 | 2017-05-20 | 20d | 2017-05-01 | 2017-05-20 | 184d | 0d | 147,000,000 | 147,000,000 | 0.42 | '96 اردیبهشت 30 | '96 اردیبهشت 11 | 0.39 |
| 77 | 1.14.2 | کف سازی و شیب بندی طبقه اول | 20d | 2017-05-05 | 2017-05-24 | 72 | 2017-05-05 | 2017-05-24 | 20d | 2017-05-05 | 2017-05-24 | 0d |  | 90,000,000 | 90,000,000 | 0.35 | '96 خرداد 03 | '96 اردیبهشت 15 | 0.31 |
| 78 | 1.14.3 | کف سازی و شیب بندی طبقه دوم و بالکن | 20d | 2017-05-10 | 2017-05-30 | 73 | 2017-05-10 | 2017-05-30 | 20d | 2017-05-10 | 2017-05-30 | 170.5d | 0d | 55,500,000 | 55,500,000 | 0.3 | '96 خرداد 09 | '96 اردیبهشت 20 | 0.26 |
| 79 | 1.14.4 | شیب بندی و کف سازی بام | 12d | 2017-05-05 | 2017-05-17 | 74 | 2017-05-05 | 2017-05-17 | 12d | 2017-05-05 | 2017-05-17 | 292.5d | 0d | 70,000,000 | 70,000,000 | 0.23 | '96 اردیبهشت 27 | '96 اردیبهشت 15 | 0.21 |
| 80 | 1.14.5 | اجرای عایق رطوبتی بام | 10d | 2017-05-17 | 2017-05-27 | 79 | 2017-05-17 | 2017-05-27 | 10d | 2017-05-17 | 2017-05-27 | 292.5d |  | 71,000,000 | 71,000,000 | 0.21 | '96 خرداد 06 | '96 اردیبهشت 27 | 0.19 |

| ID | WBS | Task | Duration | Start | Finish | Predecessors | Baseline start | Baseline finish | Baseline duration | Baseline 1 start | Baseline 1 finish | Total slack | Free slack | Cost | Baseline cost | وزن فعالیت | پايان | شروع | Text10 |
| --- | --- | --- | --- | --- | --- | --- | --- | --- | --- | --- | --- | --- | --- | --- | --- | --- | --- | --- | --- |
| 81 | 1.15 | **نماسازی** | 170d | 2017-05-30 | 2017-11-15 |  | 2017-05-30 | 2017-11-15 | 170d | 2017-05-30 | 2017-11-15 | 120d |  | 3,000,000,000 | 3,000,000,000 | 6.02 | '96 آبان 24 | '96 خرداد 09 | 6.9 |
| 82 | 1.15.1 | سنگ کاری و آجر کاری نما | 170d | 2017-05-30 | 2017-11-15 | 68 | 2017-05-30 | 2017-11-15 | 170d | 2017-05-30 | 2017-11-15 | 120d |  | 3,000,000,000 | 3,000,000,000 | 6.02 | '96 آبان 24 | '96 خرداد 09 | 6.9 |
| 83 | 1.16 | **کانال کشی تهویه مطبوع** | 43.5d | 2017-05-11 | 2017-06-23 |  | 2017-05-11 | 2017-06-23 | 43.5d | 2017-05-11 | 2017-06-23 | 4d |  | 530,000,000 | 530,000,000 | 1.61 | '96 تیر 02 | '96 اردیبهشت 21 | 1.48 |
| 84 | 1.16.1 | کانال کشی طبقه دوم | 24d | 2017-05-30 | 2017-06-23 | 78 | 2017-05-30 | 2017-06-23 | 24d | 2017-05-30 | 2017-06-23 | 170.5d | 0d | 106,000,000 | 106,000,000 | 0.41 | '96 تیر 02 | '96 خرداد 09 | 0.37 |
| 85 | 1.16.2 | کانال کشی طبقه اول | 25d | 2017-05-15 | 2017-06-08 | 77FS-10d | 2017-05-15 | 2017-06-08 | 25d | 2017-05-15 | 2017-06-08 | 0d |  | 159,000,000 | 159,000,000 | 0.5 | '96 خرداد 18 | '96 اردیبهشت 25 | 0.46 |
| 86 | 1.16.3 | کانال کشی طبقه همکف | 30d | 2017-05-11 | 2017-06-09 | 76FS-10d | 2017-05-11 | 2017-06-09 | 30d | 2017-05-11 | 2017-06-09 | 184d | 0d | 265,000,000 | 265,000,000 | 0.7 | '96 خرداد 19 | '96 اردیبهشت 21 | 0.65 |
| 87 | 1.17 | **لوله کشی آب بهداشتی و سرد و گرم** | 44.5d | 2017-06-09 | 2017-07-23 |  | 2017-06-09 | 2017-07-23 | 44.5d | 2017-06-09 | 2017-07-23 | 0d |  | 1,220,000,000 | 1,220,000,000 | 2.68 | '96 مرداد 01 | '96 خرداد 19 | 2.57 |
| 88 | 1.17.1 | اجرای لوله کشی آب سرد و گرم طبقه دوم | 30d | 2017-06-23 | 2017-07-23 | 84 | 2017-06-23 | 2017-07-23 | 30d | 2017-06-23 | 2017-07-23 | 170.5d | 0d | 445,000,000 | 445,000,000 | 0.95 | '96 مرداد 01 | '96 تیر 02 | 0.91 |
| 89 | 1.17.2 | اجرای لوله کشی آب سرد و گرم طبقه اول | 30d | 2017-06-09 | 2017-07-08 | 85 | 2017-06-09 | 2017-07-08 | 30d | 2017-06-09 | 2017-07-08 | 0d |  | 410,000,000 | 410,000,000 | 0.9 | '96 تیر 17 | '96 خرداد 19 | 0.86 |
| 90 | 1.17.3 | اجرای لوله کشی آب سرد و گرم طبقه همکف | 30d | 2017-06-10 | 2017-07-09 | 86 | 2017-06-10 | 2017-07-09 | 30d | 2017-06-10 | 2017-07-09 | 184d | 0d | 365,000,000 | 365,000,000 | 0.84 | '96 تیر 18 | '96 خرداد 20 | 0.8 |
| 91 | 1.18 | **لوله مسی** | 34.5d | 2017-07-09 | 2017-08-12 |  | 2017-07-09 | 2017-08-12 | 34.5d | 2017-07-09 | 2017-08-12 | 0d |  | 300,000,000 | 300,000,000 | 1.08 | '96 مرداد 21 | '96 تیر 18 | 0.98 |
| 92 | 1.18.1 | اجرای لوله کشی مسی طبقه دوم | 20d | 2017-07-23 | 2017-08-12 | 88 | 2017-07-23 | 2017-08-12 | 20d | 2017-07-23 | 2017-08-12 | 170.5d | 0d | 100,000,000 | 100,000,000 | 0.36 | '96 مرداد 21 | '96 مرداد 01 | 0.33 |
| 93 | 1.18.2 | اجرای لوله کشی مسی طبقه اول | 20d | 2017-07-09 | 2017-07-28 | 89 | 2017-07-09 | 2017-07-28 | 20d | 2017-07-09 | 2017-07-28 | 0d |  | 100,000,000 | 100,000,000 | 0.36 | '96 مرداد 06 | '96 تیر 18 | 0.33 |
| 94 | 1.18.3 | اجرای لوله کشی مسی طبقه همکف | 20d | 2017-07-10 | 2017-07-29 | 90 | 2017-07-10 | 2017-07-29 | 20d | 2017-07-10 | 2017-07-29 | 184d | 0d | 100,000,000 | 100,000,000 | 0.36 | '96 مرداد 07 | '96 تیر 19 | 0.33 |
| 95 | 1.19 | **اجرای لوله برق و سینی کابل** | 49.5d | 2017-04-30 | 2017-06-18 |  | 2017-04-30 | 2017-06-18 | 49.5d | 2017-04-30 | 2017-06-18 | 50d |  | 1,000,000,000 | 1,000,000,000 | 2.1 | '96 خرداد 28 | '96 اردیبهشت 10 | 2.02 |
| 96 | 1.19.1 | اجرای لوله برق و سینی کابل طبقه سوم | 5d | 2017-04-30 | 2017-05-05 | 66 | 2017-04-30 | 2017-05-05 | 5d | 2017-04-30 | 2017-05-05 | 59.5d | 0d | 50,000,000 | 50,000,000 | 0.12 | '96 اردیبهشت 15 | '96 اردیبهشت 10 | 0.12 |
| 97 | 1.19.2 | اجرای لوله برق و سینی کابل طبقه دوم | 20d | 2017-05-25 | 2017-06-14 | 67 | 2017-05-25 | 2017-06-14 | 20d | 2017-05-25 | 2017-06-14 | 44.5d | 0d | 250,000,000 | 250,000,000 | 0.57 | '96 خرداد 24 | '96 خرداد 04 | 0.54 |
| 98 | 1.19.3 | اجرای لوله برق و سینی کابل طبقه اول | 20d | 2017-05-30 | 2017-06-18 | 68 | 2017-05-30 | 2017-06-18 | 20d | 2017-05-30 | 2017-06-18 | 50d | 0d | 350,000,000 | 350,000,000 | 0.7 | '96 خرداد 28 | '96 خرداد 09 | 0.68 |
| 99 | 1.19.4 | اجرای لوله برق و سینی کابل طبقه همکف | 20d | 2017-05-21 | 2017-06-09 | 69 | 2017-05-21 | 2017-06-09 | 20d | 2017-05-21 | 2017-06-09 | 59d | 0d | 350,000,000 | 350,000,000 | 0.7 | '96 خرداد 19 | '96 اردیبهشت 31 | 0.68 |
| 100 | 1.20 | **اجرای زیر سازی سطوح کاذب** | 59.5d | 2017-07-29 | 2017-09-26 |  | 2017-07-29 | 2017-09-26 | 59.5d | 2017-07-29 | 2017-09-26 | 0d |  | 260,000,000 | 260,000,000 | 1.86 | '96 مهر 04 | '96 مرداد 07 | 1.61 |
| 101 | 1.20.1 | اجرای زیر سازی سطوح کاذب طبقه دوم | 45d | 2017-08-12 | 2017-09-26 | 92 | 2017-08-12 | 2017-09-26 | 45d | 2017-08-12 | 2017-09-26 | 170.5d |  | 60,000,000 | 60,000,000 | 0.58 | '96 مهر 04 | '96 مرداد 21 | 0.5 |
| 102 | 1.20.2 | اجرای زیر سازی سطوح کاذب طبقه اول | 45d | 2017-07-29 | 2017-09-11 | 93 | 2017-07-29 | 2017-09-11 | 45d | 2017-07-29 | 2017-09-11 | 0d |  | 80,000,000 | 80,000,000 | 0.61 | '96 شهریور 20 | '96 مرداد 07 | 0.53 |
| 103 | 1.20.3 | اجرای زیر سازی سطوح کاذب طبقه همکف | 45d | 2017-07-30 | 2017-09-12 | 94 | 2017-07-30 | 2017-09-12 | 45d | 2017-07-30 | 2017-09-12 | 184d |  | 120,000,000 | 120,000,000 | 0.66 | '96 شهریور 21 | '96 مرداد 08 | 0.59 |
| 104 | 1.21 | **فن کویل** | 50d | 2017-09-12 | 2017-10-31 |  | 2017-09-12 | 2017-10-31 | 50d | 2017-09-12 | 2017-10-31 | 0d |  | 1,577,240,450 | 1,577,240,450 | 2.73 | '96 آبان 09 | '96 شهریور 21 | 2.71 |
| 105 | 1.21.1 | سفارش،حمل،نصب فن کویل ها | 50d | 2017-09-12 | 2017-10-31 | 102 | 2017-09-12 | 2017-10-31 | 50d | 2017-09-12 | 2017-10-31 | 0d |  | 1,577,240,450 | 1,577,240,450 | 2.73 | '96 آبان 09 | '96 شهریور 21 | 2.71 |

| ID | WBS | Task | Duration | Start | Finish | Predecessors | Baseline start | Baseline finish | Baseline duration | Baseline 1 start | Baseline 1 finish | Total slack | Free slack | Constraint | Cost | Baseline cost | وزن فعالیت | پايان | شروع | Text10 |
| --- | --- | --- | --- | --- | --- | --- | --- | --- | --- | --- | --- | --- | --- | --- | --- | --- | --- | --- | --- | --- |
| 106 | 1.22 | **کابل و سیم کشی** | 79.5d | 2017-04-30 | 2017-07-18 |  | 2017-04-30 | 2017-07-18 | 79.5d | 2017-04-30 | 2017-07-18 | 59.5d |  |  | 1,067,250,700 | 1,067,250,700 | 2.86 | '96 تیر 27 | '96 اردیبهشت 10 | 2.67 |
| 107 | 1.22.1 | **کابل کشی و سیم کشی** | 79.5d | 2017-04-30 | 2017-07-18 |  | 2017-04-30 | 2017-07-18 | 79.5d | 2017-04-30 | 2017-07-18 | 59.5d |  |  | 1,067,250,700 | 1,067,250,700 | 2.86 | '96 تیر 27 | '96 اردیبهشت 10 | 2.67 |
| 108 | 1.22.1.1 | خرید کابلها و سر کابل های فشار متوسط تعهد کارفرما | 30d | 2017-04-30 | 2017-05-30 | 96SS | 2017-04-30 | 2017-05-30 | 30d | 2017-04-30 | 2017-05-30 | 59.5d | 0d |  |  |  | 0.33 | '96 خرداد 09 | '96 اردیبهشت 10 | 0.28 |
| 109 | 1.22.1.2 | کابل کشی و سیم کشی کامل طبقه ی سوم | 5d | 2017-05-30 | 2017-06-04 | 96, 108 | 2017-05-30 | 2017-06-04 | 5d | 2017-05-30 | 2017-06-04 | 284.5d |  |  | 50,000,000 | 50,000,000 | 0.12 | '96 خرداد 14 | '96 خرداد 09 | 0.12 |
| 110 | 1.22.1.3 | کابل کشی و سیم کشی کامل طبقه ی دوم | 30d | 2017-06-14 | 2017-07-14 | 97, 108 | 2017-06-14 | 2017-07-14 | 30d | 2017-06-14 | 2017-07-14 | 44.5d | 0d |  | 305,175,210 | 305,175,210 | 0.75 | '96 تیر 23 | '96 خرداد 24 | 0.71 |
| 111 | 1.22.1.4 | کابل کشی و سیم کشی کامل طبقه ی اول | 30d | 2017-06-19 | 2017-07-18 | 98, 108 | 2017-06-19 | 2017-07-18 | 30d | 2017-06-19 | 2017-07-18 | 50d | 0d |  | 508,625,350 | 508,625,350 | 1.03 | '96 تیر 27 | '96 خرداد 29 |  |
| 112 | 1.22.1.5 | کابل کشی و سیم کشی کامل طبقه ی همکف | 30d | 2017-06-10 | 2017-07-09 | 99, 108 | 2017-06-10 | 2017-07-09 | 30d | 2017-06-10 | 2017-07-09 | 59d | 0d |  | 203,450,140 | 203,450,140 | 0.61 | '96 تیر 18 | '96 خرداد 20 | 0.57 |
| 113 | 1.23 | **موتور خانه** | 190d | 2017-07-10 | 2018-01-15 |  | 2017-07-10 | 2018-01-15 | 190d | 2017-07-10 | 2018-01-15 | 59d |  |  | 981,647,000 | 981,647,000 | 5.79 | '96 دی 25 | '96 تیر 19 | 5.08 |
| 114 | 1.23.1 | تهیه و حمل دستگاه مبرد تعهد کارفرما | 90d | 2017-07-10 | 2017-10-07 | 112 | 2017-07-10 | 2017-10-07 | 90d | 2017-07-10 | 2017-10-07 | 159d | 0d |  |  |  |  | '96 مهر 15 | '96 تیر 19 | 0.83 |
| 115 | 1.23.2 | تهیه و حمل بوستر پمپ آبرسانی و آتشنشانی توسط کارفرما | 60d | 2017-07-10 | 2017-09-07 | 114SS | 2017-07-10 | 2017-09-07 | 60d | 2017-07-10 | 2017-09-07 | 189d |  |  |  |  | 0.67 | '96 شهریور 16 | '96 تیر 19 | 0.55 |
| 116 | 1.23.3 | نصب پمپها | 30d | 2017-07-10 | 2017-08-08 | 112 | 2017-07-10 | 2017-08-08 | 30d | 2017-07-10 | 2017-08-08 | 59d | 0d |  | 70,000,000 | 70,000,000 | 0.43 | '96 مرداد 17 | '96 تیر 19 | 0.38 |
| 117 | 1.23.4 | نصب بوستر پمپ آبرسانی و آتشنشانی تعهد کارفرما | 30d | 2017-08-09 | 2017-09-07 | 116 | 2017-08-09 | 2017-09-07 | 30d | 2017-08-09 | 2017-09-07 | 189d |  |  |  |  | 0.33 | '96 شهریور 16 | '96 مرداد 18 | 0.28 |
| 118 | 1.23.5 | سفارش و حمل و نصب سختی گیر ها | 30d | 2017-08-09 | 2017-09-07 | 116 | 2017-08-09 | 2017-09-07 | 30d | 2017-08-09 | 2017-09-07 | 59d | 0d |  | 35,000,000 | 35,000,000 | 0.38 | '96 شهریور 16 | '96 مرداد 18 | 0.33 |
| 119 | 1.23.6 | سفارش و حمل و نصب مخازن | 30d | 2017-09-08 | 2017-10-07 | 118 | 2017-09-08 | 2017-10-07 | 30d | 2017-09-08 | 2017-10-07 | 59d | 0d |  | 71,000,000 | 71,000,000 | 0.43 | '96 مهر 15 | '96 شهریور 17 | 0.38 |
| 120 | 1.23.7 | سفارش و حمل و نصب دیگ های چدنی و مشعل ها | 40d | 2017-10-08 | 2017-11-16 | 119 | 2017-10-08 | 2017-11-16 | 40d | 2017-10-08 | 2017-11-16 | 59d | 0d |  | 110,000,000 | 110,000,000 | 0.6 | '96 آبان 25 | '96 مهر 16 | 0.53 |
| 121 | 1.23.8 | نصب دستگاههای کنترل و اندازه گیری | 20d | 2017-11-17 | 2017-12-06 | 120, 111FF | 2017-11-17 | 2017-12-06 | 20d | 2017-11-17 | 2017-12-06 | 59d | 0d |  | 352,000,000 | 352,000,000 | 0.71 | '96 آذر 15 | '96 آبان 26 | 0.69 |
| 122 | 1.23.9 | نصب شیر ها و صافی ها و لوله کشی داخل موتورخانه | 40d | 2017-12-07 | 2018-01-15 | 121 | 2017-12-07 | 2018-01-15 | 40d | 2017-12-07 | 2018-01-15 | 59d |  | start no earlier than 2016-05-25 | 343,647,000 | 343,647,000 | 0.92 | '96 دی 25 | '96 آذر 16 | 0.86 |
| 123 | 1.23.10 | نصب دستگاه مبرد تعهد کارفرما | 30d | 2017-12-07 | 2018-01-05 | 121 | 2017-12-07 | 2018-01-05 | 30d | 2017-12-07 | 2018-01-05 | 69d |  |  |  |  | 0.33 | '96 دی 15 | '96 آذر 16 | 0.28 |
| 124 | 1.24 | **تابلو و مولد برق و آسانسور** | 115d | 2017-09-08 | 2017-12-31 |  | 2017-09-08 | 2017-12-31 | 115d | 2017-09-08 | 2017-12-31 | 74d |  |  | 254,611,000 | 254,611,000 | 2.79 | '96 دی 10 | '96 شهریور 17 | 2.39 |
| 125 | 1.24.1 | ساخت و نصب تابلو برق | 90d | 2017-10-03 | 2017-12-31 | 138, 121FF | 2017-10-03 | 2017-12-31 | 90d | 2017-10-03 | 2017-12-31 | 74d |  |  | 254,611,000 | 254,611,000 | 1.35 | '96 دی 10 | '96 مهر 11 | 1.19 |
| 126 | 1.24.2 | تهیه و حمل مولد 250 و ترانسفورماتور فشار متوسط توسط کارفرما | 45d | 2017-09-08 | 2017-10-22 | 119SS | 2017-09-08 | 2017-10-22 | 45d | 2017-09-08 | 2017-10-22 | 109d | 0d |  |  |  | 0.5 | '96 مهر 30 | '96 شهریور 17 | 0.41 |
| 127 | 1.24.3 | نصب مولد برق و ترانسفورماتور ها تعهد کارفرما | 20d | 2017-11-07 | 2017-11-26 | 126SS+60d | 2017-11-07 | 2017-11-26 | 20d | 2017-11-07 | 2017-11-26 | 109d |  |  |  |  | 0.22 | '96 آذر 05 | '96 آبان 16 | 0.18 |
| 128 | 1.24.4 | تهیه و حمل آسانسورها توسط کارفرما | 45d | 2017-09-08 | 2017-10-22 | 126SS | 2017-09-08 | 2017-10-22 | 45d | 2017-09-08 | 2017-10-22 | 109d | 0d |  |  |  | 0.5 | '96 مهر 30 | '96 شهریور 17 | 0.41 |
| 129 | 1.24.5 | نصب آسانسورها تعهد کارفرما | 20d | 2017-11-07 | 2017-11-26 | 128SS+60d | 2017-11-07 | 2017-11-26 | 20d | 2017-11-07 | 2017-11-26 | 109d |  |  |  |  | 0.22 | '96 آذر 05 | '96 آبان 16 | 0.18 |

| ID | WBS | Task | Duration | Start | Finish | Predecessors | Baseline start | Baseline finish | Baseline duration | Baseline 1 start | Baseline 1 finish | Total slack | Free slack | Constraint | Cost | Baseline cost | وزن فعالیت | پايان | شروع | Text10 |
| --- | --- | --- | --- | --- | --- | --- | --- | --- | --- | --- | --- | --- | --- | --- | --- | --- | --- | --- | --- | --- |
| 130 | 1.25 | **کاشی وسرامیک دیوارها** | 84d | 2017-07-10 | 2017-10-01 |  | 2017-07-10 | 2017-10-01 | 84d | 2017-07-10 | 2017-10-01 | 49d |  |  | 600,000,000 | 600,000,000 | 3.32 | '96 مهر 09 | '96 تیر 19 | 2.93 |
| 131 | 1.25.1 | کاشیکاری و سرامیک کاری دیوار های طبقه ی دوم | 75d | 2017-07-14 | 2017-09-27 | 110 | 2017-07-14 | 2017-09-27 | 75d | 2017-07-14 | 2017-09-27 | 44.5d | 0d |  | 200,000,000 | 200,000,000 | 1.11 | '96 مهر 05 | '96 تیر 23 | 0.98 |
| 132 | 1.25.2 | کاشیکاری و سرامیک کاری دیوارهای طبقه اول | 75d | 2017-07-19 | 2017-10-01 | 111 | 2017-07-19 | 2017-10-01 | 75d | 2017-07-19 | 2017-10-01 | 50d | 0d |  | 200,000,000 | 200,000,000 | 1.11 | '96 مهر 09 | '96 تیر 28 | 0.98 |
| 133 | 1.25.3 | کاشیکاری و سرامیک کاری دیوارهای طبقه ی همکف | 75d | 2017-07-10 | 2017-09-22 | 112 | 2017-07-10 | 2017-09-22 | 75d | 2017-07-10 | 2017-09-22 | 74d | 0d |  | 200,000,000 | 200,000,000 | 1.11 | '96 شهریور 31 | '96 تیر 19 | 0.98 |
| 134 | 1.26 | **سفید کاری دیوارها** | 19d | 2017-09-23 | 2017-10-11 |  | 2017-09-23 | 2017-10-11 | 19d | 2017-09-23 | 2017-10-11 | 49d |  |  | 1,000,000,000 | 1,000,000,000 | 1.82 | '96 مهر 19 | '96 مهر 01 | 1.79 |
| 135 | 1.26.1 | اجرای سفیدکاری دیوارهای طبقه ی دوم | 10d | 2017-09-27 | 2017-10-07 | 131 | 2017-09-27 | 2017-10-07 | 10d | 2017-09-27 | 2017-10-07 | 44.5d | 0d |  | 200,000,000 | 200,000,000 | 0.39 | '96 مهر 15 | '96 مهر 05 | 0.38 |
| 136 | 1.26.2 | اجرای گچ دیوار های راه پله | 10d | 2017-09-27 | 2017-10-07 | 131 | 2017-09-27 | 2017-10-07 | 10d | 2017-09-27 | 2017-10-07 | 159.5d |  |  | 200,000,000 | 200,000,000 | 0.39 | '96 مهر 15 | '96 مهر 05 | 0.38 |
| 137 | 1.26.3 | اجرای گچ دیوارهای طبقه اول | 10d | 2017-10-02 | 2017-10-11 | 132 | 2017-10-02 | 2017-10-11 | 10d | 2017-10-02 | 2017-10-11 | 50d | 0d |  | 300,000,000 | 300,000,000 | 0.52 | '96 مهر 19 | '96 مهر 10 | 0.52 |
| 138 | 1.26.4 | اجرای گچ دیوارهای طبقه ی همکف | 10d | 2017-09-23 | 2017-10-02 | 133 | 2017-09-23 | 2017-10-02 | 10d | 2017-09-23 | 2017-10-02 | 74d | 0d |  | 300,000,000 | 300,000,000 | 0.52 | '96 مهر 10 | '96 مهر 01 | 0.52 |
| 139 | 1.27 | **نصب سطوح کاذب(تایل)** | 15d | 2017-11-01 | 2017-11-15 |  | 2017-11-01 | 2017-11-15 | 15d | 2017-11-01 | 2017-11-15 | 0d |  |  | 1,200,000,000 | 1,200,000,000 | 2.04 | '96 آبان 24 | '96 آبان 10 | 2.03 |
| 140 | 1.27.1 | نصب سطوح کاذب طبقه دوم | 10d | 2017-11-01 | 2017-11-10 | 105 | 2017-11-01 | 2017-11-10 | 10d | 2017-11-01 | 2017-11-10 | 65d | 0d |  | 400,000,000 | 400,000,000 | 0.66 | '96 آبان 19 | '96 آبان 10 | 0.66 |
| 141 | 1.27.2 | نصب سطوح کاذب طبقه اول | 10d | 2017-11-01 | 2017-11-10 | 105 | 2017-11-01 | 2017-11-10 | 10d | 2017-11-01 | 2017-11-10 | 65d | 0d |  | 400,000,000 | 400,000,000 | 0.66 | '96 آبان 19 | '96 آبان 10 | 0.66 |
| 142 | 1.27.3 | نصب سطوح کاذب طبقه همکف | 15d | 2017-11-01 | 2017-11-15 | 105 | 2017-11-01 | 2017-11-15 | 15d | 2017-11-01 | 2017-11-15 | 0d |  |  | 400,000,000 | 400,000,000 | 0.72 | '96 آبان 24 | '96 آبان 10 | 0.71 |
| 143 | 1.28 | **موزاییک و سرامیک کف** | 65d | 2017-11-11 | 2018-01-14 |  | 2017-11-11 | 2018-01-14 | 65d | 2017-11-11 | 2018-01-14 | 60d |  |  | 1,765,000,000 | 1,765,000,000 | 4.43 | '96 دی 24 | '96 آبان 20 | 4.17 |
| 144 | 1.28.1 | اجرای سرامیک و موزاییک کف طبقه دوم | 60d | 2017-11-11 | 2018-01-09 | 140 | 2017-11-11 | 2018-01-09 | 60d | 2017-11-11 | 2018-01-09 | 65d |  |  | 400,000,000 | 400,000,000 | 1.22 | '96 دی 19 | '96 آبان 20 | 1.12 |
| 145 | 1.28.2 | اجرای سرامیک و موزاییک کف طبقه اول | 60d | 2017-11-11 | 2018-01-09 | 141 | 2017-11-11 | 2018-01-09 | 60d | 2017-11-11 | 2018-01-09 | 65d |  |  | 600,000,000 | 600,000,000 | 1.49 | '96 دی 19 | '96 آبان 20 | 1.41 |
| 146 | 1.28.3 | اجرای سرامیک و موزاییک کف طبقه همکف | 60d | 2017-11-16 | 2018-01-14 | 142 | 2017-11-16 | 2018-01-14 | 60d | 2017-11-16 | 2018-01-14 | 60d |  |  | 765,000,000 | 765,000,000 | 1.72 | '96 دی 24 | '96 آبان 25 | 1.64 |
| 147 | 1.29 | **نصب درب و پنجره** | 105d | 2017-10-12 | 2018-01-24 |  | 2017-10-12 | 2018-01-24 | 105d | 2017-10-12 | 2018-01-24 | 50d |  |  | 1,820,000,000 | 1,820,000,000 | 4.06 | '96 بهمن 04 | '96 مهر 20 | 3.88 |
| 148 | 1.29.1 | ساخت درب های چوبی و پنجره upvc | 90d | 2017-10-12 | 2018-01-09 | 137 | 2017-10-12 | 2018-01-09 | 90d | 2017-10-12 | 2018-01-09 | 50d | 0d |  | 1,200,000,000 | 1,200,000,000 | 2.65 | '96 دی 19 | '96 مهر 20 | 2.54 |
| 149 | 1.29.2 | نصب درب و پنجره طبقه سوم | 5d | 2018-01-10 | 2018-01-14 | 148 | 2018-01-10 | 2018-01-14 | 5d | 2018-01-10 | 2018-01-14 | 60d |  |  | 20,000,000 | 20,000,000 | 0.08 | '96 دی 24 | '96 دی 20 | 0.07 |
| 150 | 1.29.3 | نصب درب و پنجره طبقه دوم | 15d | 2018-01-10 | 2018-01-24 | 148 | 2018-01-10 | 2018-01-24 | 15d | 2018-01-10 | 2018-01-24 | 50d |  | start no earlier than 2017-09-29 | 200,000,000 | 200,000,000 | 0.44 | '96 بهمن 04 | '96 دی 20 | 0.42 |
| 151 | 1.29.4 | نصب درب و پنجره طبقه اول | 15d | 2018-01-10 | 2018-01-24 | 148 | 2018-01-10 | 2018-01-24 | 15d | 2018-01-10 | 2018-01-24 | 50d |  |  | 200,000,000 | 200,000,000 | 0.44 | '96 بهمن 04 | '96 دی 20 | 0.42 |
| 152 | 1.29.5 | نصب درب و پنجره طبقه همکف | 15d | 2018-01-10 | 2018-01-24 | 148 | 2018-01-10 | 2018-01-24 | 15d | 2018-01-10 | 2018-01-24 | 50d |  |  | 200,000,000 | 200,000,000 | 0.44 | '96 بهمن 04 | '96 دی 20 | 0.42 |
| 153 | 1.30 | **اجرای نرده و حفاظ نرده** | 50d | 2017-10-03 | 2017-11-21 |  | 2017-10-03 | 2017-11-21 | 50d | 2017-10-03 | 2017-11-21 | 114d |  |  | 338,606,577 | 338,606,577 | 1.02 | '96 آبان 30 | '96 مهر 11 | 0.94 |
| 154 | 1.30.1 | اجرای نرده و حفاظ نرده | 50d | 2017-10-03 | 2017-11-21 | 138 | 2017-10-03 | 2017-11-21 | 50d | 2017-10-03 | 2017-11-21 | 114d |  |  | 338,606,577 | 338,606,577 | 1.02 | '96 آبان 30 | '96 مهر 11 | 0.94 |

| ID | WBS | Task | Type | Duration | Start | Finish | Predecessors | Baseline start | Baseline finish | Baseline duration | Baseline 1 start | Baseline 1 finish | Total slack | Free slack | Cost | Baseline cost | وزن فعالیت | پايان | شروع | Text10 |
| --- | --- | --- | --- | --- | --- | --- | --- | --- | --- | --- | --- | --- | --- | --- | --- | --- | --- | --- | --- | --- |
| 155 | 1.31 | **نصب دریچه هاو هواکش ها** |  | 30d | 2017-10-12 | 2017-11-10 |  | 2017-10-12 | 2017-11-10 | 30d | 2017-10-12 | 2017-11-10 | 125d |  | 185,525,000 | 185,525,000 | 0.59 | '96 آبان 19 | '96 مهر 20 | 0.54 |
| 156 | 1.31.1 | نصب دریچه ها و هواکشها |  | 30d | 2017-10-12 | 2017-11-10 | 148SS | 2017-10-12 | 2017-11-10 | 30d | 2017-10-12 | 2017-11-10 | 125d |  | 185,525,000 | 185,525,000 | 0.59 | '96 آبان 19 | '96 مهر 20 | 0.54 |
| 157 | 1.32 | **اجرای رنگ آمیزی** |  | 54.5d | 2017-10-07 | 2017-11-30 |  | 2017-10-07 | 2017-11-30 | 54.5d | 2017-10-07 | 2017-11-30 | 39.5d |  | 1,214,921,300 | 1,214,921,300 | 2.29 | '96 آذر 09 | '96 مهر 15 | 2.24 |
| 158 | 1.32.1 | اجرای رنگ آمیزی طبقه ی سوم |  | 5d | 2017-10-07 | 2017-10-12 | 135 | 2017-10-07 | 2017-10-12 | 5d | 2017-10-07 | 2017-10-12 | 154.5d |  | 50,000,000 | 50,000,000 | 0.12 | '96 مهر 20 | '96 مهر 15 | 0.12 |
| 159 | 1.32.2 | اجرای رنگ آمیزی طبقه دوم |  | 20d | 2017-10-07 | 2017-10-27 | 135 | 2017-10-07 | 2017-10-27 | 20d | 2017-10-07 | 2017-10-27 | 44.5d | 0d | 232,982,460 | 232,982,460 | 0.54 | '96 آبان 05 | '96 مهر 15 | 0.52 |
| 160 | 1.32.3 | اجرای رنگ آمیزی طبقه اول |  | 20d | 2017-11-11 | 2017-11-30 | 141, 159 | 2017-11-11 | 2017-11-30 | 20d | 2017-11-11 | 2017-11-30 | 105d |  | 349,473,690 | 349,473,690 | 0.7 | '96 آذر 09 | '96 آبان 20 | 0.68 |
| 161 | 1.32.4 | اجرای رنگ آمیزی طبقه ی همکف |  | 10d | 2017-11-16 | 2017-11-25 | 142 | 2017-11-16 | 2017-11-25 | 10d | 2017-11-16 | 2017-11-25 | 0d |  | 582,465,150 | 582,465,150 | 0.91 | '96 آذر 04 | '96 آبان 25 | 0.92 |
| 162 | 1.33 | **نصب وسائل داخلی طبقات شامل درب ها،وسائل بهداشتی وغیره…** |  | 94.5d | 2017-10-27 | 2018-01-29 |  | 2017-10-27 | 2018-01-29 | 94.5d | 2017-10-27 | 2018-01-29 | 29.5d |  | 2,652,092,000 | 2,652,092,000 | 7.03 | '96 بهمن 09 | '96 آبان 05 | 6.58 |
| 163 | 1.33.1 | تهیه و حمل آنتن گیرنده تلویزیون،پایه مخصوص نصب آنتن،تقویت کننده،رک،پریز شبکه،ups , چراغ نگاتسکوپ و آبسرد کنها تعهد کارفرما |  | 30d | 2017-10-27 | 2017-11-26 | 159 | 2017-10-27 | 2017-11-26 | 30d | 2017-10-27 | 2017-11-26 | 44.5d |  |  |  | 0.33 | '96 آذر 05 | '96 آبان 05 | 0.28 |
| 164 | 1.33.2 | حمل و نصب درب های چوبی و مقاوم در برابر آتش |  | 20d | 2017-11-26 | 2017-12-15 | 161 | 2017-11-26 | 2017-12-15 | 20d | 2017-11-26 | 2017-12-15 | 9d | 0d | 700,000,000 | 700,000,000 | 1.19 | '96 آذر 24 | '96 آذر 05 | 1.18 |
| 165 | 1.33.3 | تهیه و حمل و نصب درب سربی |  | 20d | 2017-11-26 | 2017-12-15 | 161, 164FF | 2017-11-26 | 2017-12-15 | 20d | 2017-11-26 | 2017-12-15 | 9d |  | 24,500,000 | 24,500,000 | 0.26 | '96 آذر 24 | '96 آذر 05 | 0.22 |
| 166 | 1.33.4 | تهیه و نصب درهای اتوماتیک |  | 29d | 2017-11-26 | 2017-12-24 | 161, 165FF | 2017-11-26 | 2017-12-24 | 29d | 2017-11-26 | 2017-12-24 | 0d |  | 110,000,000 | 110,000,000 | 0.47 | '96 دی 03 | '96 آذر 05 | 0.42 |
| 167 | 1.33.5 | نصب وسائل بهداشتی طبقات |  | 50d | 2017-11-26 | 2018-01-14 | 161, 166FF | 2017-11-26 | 2018-01-14 | 50d | 2017-11-26 | 2018-01-14 | 60d |  | 128,000,000 | 128,000,000 | 0.73 | '96 دی 24 | '96 آذر 05 | 0.64 |
| 168 | 1.33.6 | نصب آنتن گیرنده تلویزیون،پایه مخصوص نصب آنتن،تقویت کننده،رک،پریز شبکه،ups , چراغ نگاتسکوپ و آبسرد کنها تعهد کارفرما |  | 45d | 2017-11-26 | 2018-01-09 | 166SS | 2017-11-26 | 2018-01-09 | 45d | 2017-11-26 | 2018-01-09 | 0d |  |  |  | 0.5 | '96 دی 19 | '96 آذر 05 | 0.41 |
| 169 | 1.33.7 | نصب ادوات برقی طبقات |  | 20d | 2018-01-10 | 2018-01-29 | 161, 168, 163 | 2018-01-10 | 2018-01-29 | 20d | 2018-01-10 | 2018-01-29 | 0d |  | 852,942,000 | 852,942,000 | 1.4 | '96 بهمن 09 | '96 دی 20 | 1.4 |
| 170 | 1.33.8 | نصب تجهیزات گاز طبی |  | 60d | 2017-12-01 | 2018-01-29 | 161, 169FF | 2017-12-01 | 2018-01-29 | 60d | 2017-12-01 | 2018-01-29 | 45d | 0d | 496,650,000 | 496,650,000 | 1.35 | '96 بهمن 09 | '96 آذر 10 | 1.26 |
| 171 | 1.33.9 | نصب لوازم آتشنشانی و اعلام حریق |  | 30d | 2017-12-31 | 2018-01-29 | 161, 170FF | 2017-12-31 | 2018-01-29 | 30d | 2017-12-31 | 2018-01-29 | 45d |  | 340,000,000 | 340,000,000 | 0.8 | '96 بهمن 09 | '96 دی 10 | 0.76 |
| 172 | 1.34 | **تست،راه اندازی و تحویل موقت** |  | 45d | 2018-01-30 | 2018-03-15 |  | 2018-01-30 | 2018-03-15 | 45d | 2018-01-30 | 2018-03-15 | 0d |  | 500,000,000 | 500,000,000 | 1.19 | '96 اسفند 24 | '96 بهمن 10 | 1.13 |
| 173 | 1.34.1 | تست و راه اندازی |  | 20d | 2018-01-30 | 2018-02-18 | 169 | 2018-01-30 | 2018-02-18 | 20d | 2018-01-30 | 2018-02-18 | 0d |  | 200,000,000 | 200,000,000 | 0.5 | '96 بهمن 29 | '96 بهمن 10 | 0.47 |
| 174 | 1.34.2 | عملیات مربوط به تحویل موقت |  | 15d | 2018-02-19 | 2018-03-05 | 173 | 2018-02-19 | 2018-03-05 | 15d | 2018-02-19 | 2018-03-05 | 0d |  | 100,000,000 | 100,000,000 | 0.3 | '96 اسفند 14 | '96 بهمن 30 | 0.28 |
| 175 | 1.34.3 | برچیدن کارگاه |  | 10d | 2018-03-06 | 2018-03-15 | 174 | 2018-03-06 | 2018-03-15 | 10d | 2018-03-06 | 2018-03-15 | 0d |  | 200,000,000 | 200,000,000 | 0.39 | '96 اسفند 24 | '96 اسفند 15 | 0.38 |
| 176 | 1.34.4 | پایان | milestone | 0d | 2018-03-15 | 2018-03-15 | 175FF | 2018-03-15 | 2018-03-15 | 0d | 2018-03-15 | 2018-03-15 | 0d |  |  |  |  | '96 اسفند 24 | '96 اسفند 24 |  |
