# ایستگاه S03

Schedule from MS Project, 2017-06-10 to 2017-12-08, status date 2017-05-29.

## Calendars

- Standard: Mon-Sun 08:00-12:00, 13:00-17:00.

## Schedule

| ID | WBS | Task | Type | Duration | Start | Finish | Predecessors | Total slack | Constraint | Text1 | Text2 | start. | finish. |
| --- | --- | --- | --- | --- | --- | --- | --- | --- | --- | --- | --- | --- | --- |
| 1 | 1 | **فرآیندهای مدیریت پروژه** |  | 162d | 2017-06-11 | 2017-11-19 |  | 0d |  | 96/3/20 | 97/7/4 | 96/3/21 | 96/8/28 |
| 2 | 1.1 | **فرآیندهای فنی و مهندسی** |  | 113d | 2017-07-30 | 2017-11-19 |  | 0d |  | 96/7/27 | 97/7/4 | 96/5/8 | 96/8/28 |
| 3 | 1.1.1 | نقشه فونداسیون |  | 35d | 2017-09-11 | 2017-10-15 |  | 0d | as late as possible | 97/4/28 | 97/6/1 | 96/6/20 | 96/7/23 |
| 4 | 1.1.2 | نقشه شاپ دراوینگ |  | 35d | 2017-10-16 | 2017-11-19 | 3 | 19d | start no earlier than 2017-05-29 | 97/6/1 | 97/7/4 | 96/7/24 | 96/8/28 |
| 5 | 1.1.3 | طرح اختلاط بتن |  | 40d | 2017-09-11 | 2017-10-20 |  | 0d | as late as possible | 97/5/7 | 97/6/16 | 96/6/20 | 96/7/28 |
| 6 | 1.1.4 | نقشه های زهکشی و ارتینگ |  | 35d | 2017-09-05 | 2017-10-09 |  | 0d | as late as possible | 97/5/3 | 97/6/7 | 96/6/14 | 96/7/17 |
| 7 | 1.1.5 | ارسال مشخصات زهکش جهت خرید |  | 35d | 2017-10-10 | 2017-11-13 | 6 | 25d | start no earlier than 2017-05-29 | 97/3/30 | 97/5/3 | 96/7/18 | 96/8/22 |
| 8 | 1.1.6 | ارسال مشخصات ارتینگ جهت خرید |  | 35d | 2017-10-10 | 2017-11-13 | 6 | 25d | start no earlier than 2017-05-29 | 97/3/30 | 97/5/3 | 96/7/18 | 96/8/22 |
| 9 | 1.1.7 | ارسال مشخصات عایق جهت خرید |  | 35d | 2017-07-30 | 2017-09-02 |  | 0d | as late as possible | 97/4/2 | 97/5/6 | 96/5/8 | 96/6/11 |
| 10 | 1.2 | **فرآیندهای قراردادی** |  | 131d | 2017-06-11 | 2017-10-19 |  | 0d |  | 96/3/20 | 97/6/7 | 96/3/21 | 96/7/27 |
| 11 | 1.2.1 | انعقاد قرارداد استرات |  | 7d | 2017-06-11 | 2017-06-17 |  | 0d | start no earlier than 2017-06-10 | 96/8/15 | 96/9/30 | 96/3/21 | 96/3/27 |
| 12 | 1.2.2 | انعقاد قرار داد زهکش و ارت |  | 45d | 2017-09-05 | 2017-10-19 |  | 0d | as late as possible | 97/4/24 | 97/6/7 | 96/6/14 | 96/7/27 |
| 13 | 1.2.3 | انعقاد قرار داد فونداسیون |  | 45d | 2017-08-27 | 2017-10-10 |  | 0d | as late as possible | 97/4/23 | 97/6/6 | 96/6/5 | 96/7/18 |
| 14 | 1.3 | **فرآیندهای پشتیبانی** |  | 54d | 2017-08-30 | 2017-10-22 |  | 0d |  | 96/3/23 | 97/6/15 | 96/6/8 | 96/7/30 |
| 15 | 1.3.1 | خرید ارت |  | 40d | 2017-09-10 | 2017-10-19 |  | 0d | as late as possible | 97/5/3 | 97/6/12 | 96/6/19 | 96/7/27 |
| 16 | 1.3.2 | خرید زهکش |  | 40d | 2017-09-10 | 2017-10-19 |  | 0d | as late as possible | 97/5/3 | 97/6/12 | 96/6/19 | 96/7/27 |
| 17 | 1.3.3 | خرید میلگرد برای فونداسیون |  | 40d | 2017-09-01 | 2017-10-10 |  | 0d | as late as possible | 97/4/25 | 97/6/3 | 96/6/10 | 96/7/18 |
| 18 | 1.3.4 | خریداری ژئوتکستایل |  | 40d | 2017-09-13 | 2017-10-22 |  | 0d | as late as possible | 97/4/25 | 97/6/2 | 96/6/22 | 96/7/30 |
| 19 | 1.3.5 | خرید عایق |  | 40d | 2017-09-03 | 2017-10-12 | 9 | 0d | as late as possible | 97/5/6 | 97/6/15 | 96/6/12 | 96/7/20 |
| 20 | 1.3.6 | خرید پله فلزی |  | 40d | 2017-08-30 | 2017-10-08 |  | 0d | as late as possible |  |  | 96/6/8 | 96/7/16 |
| 21 | 2 | **فرآیندهای محصول گرا** |  | 135d | 2017-06-10 | 2017-10-23 |  | 0d |  | 96/2/16 | 97/9/12 | 96/3/20 | 96/8/1 |
| 22 | 2.1 | **سازه نگهبان** |  | 135d | 2017-06-10 | 2017-10-23 |  | 0d |  |  |  | 96/3/20 | 96/8/1 |
| 23 | 2.1.1 | **خاکبرداری** |  | 132d | 2017-06-10 | 2017-10-20 |  | 0d |  |  |  | 96/3/20 | 96/7/28 |
| 24 | 2.1.1.1 | **خاکبرداری تا ترازفونداسیون** |  | 132d | 2017-06-10 | 2017-10-20 |  | 0d |  |  |  | 96/3/20 | 96/7/28 |
| 25 | 2.1.1.1.1 | **خاکبرداری تا ترازفونداسیون تا 6 متر** |  | 80d | 2017-06-10 | 2017-08-29 |  | 0d |  |  |  | 96/3/20 | 96/6/7 |
| 26 | 2.1.1.1.1.1 | شروع عملیات | milestone | 0d | 2017-06-10 | 2017-06-10 |  | 7d | start no earlier than 2017-06-10 |  |  | 96/3/20 | 96/3/20 |

| ID | WBS | Task | Duration | Start | Finish | Predecessors | Total slack | Free slack | Constraint | start. | finish. |
| --- | --- | --- | --- | --- | --- | --- | --- | --- | --- | --- | --- |
| 27 | 2.1.1.1.1.2 | **خاکبرداری تا ترازفونداسیون 2 متر** | 21d | 2017-07-28 | 2017-08-17 |  | 0d |  |  | 96/5/6 | 96/5/26 |
| 28 | 2.1.1.1.1.2.1 | خاکبرداری تا ترازفونداسیون پارت دوم 2متر | 3d | 2017-07-28 | 2017-07-30 | 60, 61 | 0d |  |  | 96/5/6 | 96/5/8 |
| 29 | 2.1.1.1.1.2.2 | خاکبرداری تا ترازفونداسیون پارت سوم 2متر | 3d | 2017-07-31 | 2017-08-02 | 61, 28 | 0d |  |  | 96/5/9 | 96/5/11 |
| 30 | 2.1.1.1.1.2.3 | خاکبرداری تا ترازفونداسیون پارت چهارم( یو شکل غربی)2متر | 3d | 2017-08-15 | 2017-08-17 | 62, 37 | 0d |  |  | 96/5/24 | 96/5/26 |
| 31 | 2.1.1.1.1.3 | **خاکبرداری تا تراز فونداسیون 2تا4 متر** | 21d | 2017-08-03 | 2017-08-23 |  | 0d |  |  | 96/5/12 | 96/6/1 |
| 32 | 2.1.1.1.1.3.1 | خاکبرداری تا ترازفونداسیون پارت دوم 2تا 4 متر | 3d | 2017-08-03 | 2017-08-05 | 65, 29 | 15d | 0d |  | 96/5/12 | 96/5/14 |
| 33 | 2.1.1.1.1.3.2 | خاکبرداری تا ترازفونداسیون پارت سوم2تا 4 متر | 3d | 2017-08-06 | 2017-08-08 | 29, 66 | 0d |  |  | 96/5/15 | 96/5/17 |
| 34 | 2.1.1.1.1.3.3 | خاکبرداری تا ترازفونداسیون پارت چهارم( یو شکل غربی)2تا 4 متر | 3d | 2017-08-21 | 2017-08-23 | 30, 67 | 0d |  |  | 96/5/30 | 96/6/1 |
| 35 | 2.1.1.1.1.4 | **خاکبرداری تا تراز فونداسیون 4 تا6متر** | 21d | 2017-08-09 | 2017-08-29 |  | 0d |  |  | 96/5/18 | 96/6/7 |
| 36 | 2.1.1.1.1.4.1 | خاکبرداری تا ترازفونداسیون پارت دوم4 تا6متر | 3d | 2017-08-09 | 2017-08-11 | 69 | 15d | 0d |  | 96/5/18 | 96/5/20 |
| 37 | 2.1.1.1.1.4.2 | خاکبرداری تا ترازفونداسیون پارت سوم 4 تا6متر | 3d | 2017-08-12 | 2017-08-14 | 33, 70 | 0d |  |  | 96/5/21 | 96/5/23 |
| 38 | 2.1.1.1.1.4.3 | خاکبرداری تا ترازفونداسیون پارت چهارم( یو شکل غربی) 4 تا6متر | 3d | 2017-08-27 | 2017-08-29 | 34, 71 | 0d |  |  | 96/6/5 | 96/6/7 |
| 39 | 2.1.1.1.2 | **خاکبرداری تا تراز فونداسیون 6مترتا12 متر** | 52d | 2017-08-30 | 2017-10-20 |  | 0d |  |  | 96/6/8 | 96/7/28 |
| 40 | 2.1.1.1.2.1 | **خاکبرداری تا تراز فونداسیون 6 تا8متر** | 10d | 2017-08-30 | 2017-09-08 |  | 0d |  |  | 96/6/8 | 96/6/17 |
| 41 | 2.1.1.1.2.1.1 | خاکبرداری تا ترازفونداسیون پارت دوم 6 تا8متر | 3d | 2017-08-30 | 2017-09-01 | 73, 38 | 0d |  |  | 96/6/8 | 96/6/10 |
| 42 | 2.1.1.1.2.1.2 | خاکبرداری تا ترازفونداسیون پارت سوم 6 تا8متر | 3d | 2017-09-02 | 2017-09-04 | 74, 41 | 0d |  |  | 96/6/11 | 96/6/13 |
| 43 | 2.1.1.1.2.1.3 | خاکبرداری تا ترازفونداسیون پارت چهارم( یو شکل غربی) 6 تا8متر | 4d | 2017-09-05 | 2017-09-08 | 75, 42 | 0d |  |  | 96/6/14 | 96/6/17 |
| 44 | 2.1.1.1.2.2 | **خاکبرداری تا تراز فونداسیون 8تا10متر** | 13d | 2017-09-09 | 2017-09-21 |  | 0d |  |  | 96/6/18 | 96/6/30 |
| 45 | 2.1.1.1.2.2.1 | خاکبرداری تا ترازفونداسیون پارت اول( یو شکل شرقی)8 تا 10 متر | 3d | 2017-09-09 | 2017-09-11 | 43 | 0d |  |  | 96/6/18 | 96/6/20 |
| 46 | 2.1.1.1.2.2.2 | خاکبرداری تا ترازفونداسیون پارت دوم 8 تا 10 متر | 3d | 2017-09-12 | 2017-09-14 | 77, 45 | 0d |  |  | 96/6/21 | 96/6/23 |
| 47 | 2.1.1.1.2.2.3 | خاکبرداری تا ترازفونداسیون پارت سوم 8 تا 10 متر | 3d | 2017-09-15 | 2017-09-17 | 78, 46 | 0d |  |  | 96/6/24 | 96/6/26 |
| 48 | 2.1.1.1.2.2.4 | خاکبرداری تا ترازفونداسیون پارت چهارم( یو شکل غربی) 8 تا 10 متر | 4d | 2017-09-18 | 2017-09-21 | 79, 47 | 0d |  |  | 96/6/27 | 96/6/30 |
| 49 | 2.1.1.1.2.3 | **خاکبرداری تا تراز فونداسیون 10تا 12/5 متر** | 29d | 2017-09-22 | 2017-10-20 |  | 0d |  |  | 96/6/31 | 96/7/28 |
| 50 | 2.1.1.1.2.3.1 | خاکبرداری تا ترازفونداسیون پارت اول( یو شکل شرقی)10تا 12/5 متر | 3d | 2017-09-22 | 2017-09-24 | 81, 48 | 0d |  |  | 96/6/31 | 96/7/2 |
| 51 | 2.1.1.1.2.3.2 | خاکبرداری تا ترازفونداسیون پارت دوم 10تا 12/5 متر | 3d | 2017-09-25 | 2017-09-27 | 82, 50 | 0d |  |  | 96/7/3 | 96/7/5 |
| 52 | 2.1.1.1.2.3.3 | خاکبرداری تا ترازفونداسیون پارت سوم 10تا 12/5 متر | 3d | 2017-09-28 | 2017-09-30 | 83, 51 | 0d |  |  | 96/7/6 | 96/7/8 |
| 53 | 2.1.1.1.2.3.4 | خاکبرداری تا ترازفونداسیون پارت چهارم( یو شکل غربی)10تا 12/5 متر | 20d | 2017-10-01 | 2017-10-20 | 84, 52 | 0d |  | start no earlier than 2017-05-29 | 96/7/9 | 96/7/28 |

| ID | WBS | Task | Duration | Start | Finish | Predecessors | Total slack | Free slack | Constraint | start. | finish. |
| --- | --- | --- | --- | --- | --- | --- | --- | --- | --- | --- | --- |
| 54 | 2.1.2 | **استرات** | 55d | 2017-06-18 | 2017-08-11 |  | 0d |  |  | 96/3/28 | 96/5/20 |
| 55 | 2.1.2.1 | **ساخت استرات** | 45d | 2017-06-18 | 2017-08-01 | 26 | 0d |  |  | 96/3/28 | 96/5/10 |
| 56 | 2.1.2.1.1 | ساخت استرات پارت2 | 15d | 2017-06-18 | 2017-07-02 | 11 | 0d |  | start no earlier than 2017-06-10 | 96/3/28 | 96/4/11 |
| 57 | 2.1.2.1.2 | ساخت استرات پارت3 | 15d | 2017-07-03 | 2017-07-17 | 26, 56 | 0d |  | start no earlier than 2017-05-29 | 96/4/12 | 96/4/26 |
| 58 | 2.1.2.1.3 | ساخت استرات پارت4 | 15d | 2017-07-18 | 2017-08-01 | 57 | 3d | 0d | start no earlier than 2017-05-29 | 96/4/27 | 96/5/10 |
| 59 | 2.1.2.2 | **نصب استرات** | 40d | 2017-07-03 | 2017-08-11 |  | 3d |  |  | 96/4/12 | 96/5/20 |
| 60 | 2.1.2.2.1 | نصب استرات پارت2 | 10d | 2017-07-03 | 2017-07-12 | 26, 56 | 15d |  | start no earlier than 2017-05-29 | 96/4/12 | 96/4/21 |
| 61 | 2.1.2.2.2 | نصب استرات پارت3 | 10d | 2017-07-18 | 2017-07-27 | 57 | 0d |  | start no earlier than 2017-05-29 | 96/4/27 | 96/5/5 |
| 62 | 2.1.2.2.3 | نصب استرات پارت4 | 10d | 2017-08-02 | 2017-08-11 | 61, 58 | 3d |  | start no earlier than 2017-05-29 | 96/5/11 | 96/5/20 |
| 63 | 2.1.3 | **مش بندی و شاتکریت تا تراز فونداسیون** | 85d | 2017-07-31 | 2017-10-23 |  | 0d |  |  | 96/5/9 | 96/8/1 |
| 64 | 2.1.3.1 | **مش بندی و شاتکریت تا تراز فونداسیون2 متر** | 21d | 2017-07-31 | 2017-08-20 |  | 0d |  |  | 96/5/9 | 96/5/29 |
| 65 | 2.1.3.1.1 | مش بندی و شاتکریت تا تراز فونداسیون، پارت دوم، 2متر | 3d | 2017-07-31 | 2017-08-02 | 28 | 0d |  | start no earlier than 2017-05-29 | 96/5/9 | 96/5/11 |
| 66 | 2.1.3.1.2 | مش بندی و شاتکریت تا تراز فونداسیون، پارت سوم، 2متر | 3d | 2017-08-03 | 2017-08-05 | 29, 65 | 0d |  | start no earlier than 2017-05-29 | 96/5/12 | 96/5/14 |
| 67 | 2.1.3.1.3 | مش بندی و شاتکریت تا تراز فونداسیون، پارت چهارم (یو شکل غربی)،2متر | 3d | 2017-08-18 | 2017-08-20 | 30, 66 | 0d |  | start no earlier than 2017-05-29 | 96/5/27 | 96/5/29 |
| 68 | 2.1.3.2 | **مش بندی و شاتکریت تا تراز فونداسیون2تا 4متر** | 21d | 2017-08-06 | 2017-08-26 |  | 0d |  |  | 96/5/15 | 96/6/4 |
| 69 | 2.1.3.2.1 | مش بندی و شاتکریت تا تراز فونداسیون، پارت دوم، 2تا 4متر | 3d | 2017-08-06 | 2017-08-08 | 32, 65 | 15d | 0d | start no earlier than 2017-05-29 | 96/5/15 | 96/5/17 |
| 70 | 2.1.3.2.2 | مش بندی و شاتکریت تا تراز فونداسیون، پارت سوم، 2تا 4متر | 3d | 2017-08-09 | 2017-08-11 | 33, 66 | 0d |  | start no earlier than 2017-05-29 | 96/5/18 | 96/5/20 |
| 71 | 2.1.3.2.3 | مش بندی و شاتکریت تا تراز فونداسیون، پارت چهارم (یو شکل غربی)،2تا 4متر | 3d | 2017-08-24 | 2017-08-26 | 34, 67 | 0d |  | start no earlier than 2017-05-29 | 96/6/2 | 96/6/4 |
| 72 | 2.1.3.3 | **مش بندی و شاتکریت تا تراز فونداسیون4تا 6متر** | 21d | 2017-08-12 | 2017-09-01 |  | 3d |  |  | 96/5/21 | 96/6/10 |
| 73 | 2.1.3.3.1 | مش بندی و شاتکریت تا تراز فونداسیون، پارت دوم، 4تا 6متر | 3d | 2017-08-12 | 2017-08-14 | 36, 69 | 15d |  | start no earlier than 2017-05-29 | 96/5/21 | 96/5/23 |
| 74 | 2.1.3.3.2 | مش بندی و شاتکریت تا تراز فونداسیون، پارت سوم، 4تا 6متر | 3d | 2017-08-15 | 2017-08-17 | 37, 70 | 15d |  | start no earlier than 2017-05-29 | 96/5/24 | 96/5/26 |
| 75 | 2.1.3.3.3 | مش بندی و شاتکریت تراز فونداسیون، پارت چهارم (یو شکل غربی)،4تا 6متر | 3d | 2017-08-30 | 2017-09-01 | 38, 71 | 3d |  | start no earlier than 2017-05-29 | 96/6/8 | 96/6/10 |
| 76 | 2.1.3.4 | **مش بندی و شاتکریت تا تراز فونداسیون6تا 8متر** | 9d | 2017-09-02 | 2017-09-10 |  | 7d |  |  | 96/6/11 | 96/6/19 |
| 77 | 2.1.3.4.1 | مش بندی و شاتکریت تا تراز فونداسیون، پارت دوم، 6تا 8متر | 3d | 2017-09-02 | 2017-09-04 | 41 | 7d | 0d | start no earlier than 2017-05-29 | 96/6/11 | 96/6/13 |
| 78 | 2.1.3.4.2 | مش بندی و شاتکریت تا تراز فونداسیون، پارت سوم،6تا 8متر | 3d | 2017-09-05 | 2017-09-07 | 41, 77 | 7d | 0d | start no earlier than 2017-05-29 | 96/6/14 | 96/6/16 |
| 79 | 2.1.3.4.3 | مش بندی و شاتکریت تراز فونداسیون، پارت چهارم (یو شکل غربی)،6تا 8متر | 3d | 2017-09-08 | 2017-09-10 | 42, 78 | 7d | 1d | start no earlier than 2017-05-29 | 96/6/17 | 96/6/19 |

| ID | WBS | Task | Duration | Start | Finish | Predecessors | Total slack | Free slack | Constraint | start. | finish. |
| --- | --- | --- | --- | --- | --- | --- | --- | --- | --- | --- | --- |
| 80 | 2.1.3.5 | **مش بندی و شاتکریت تا تراز فونداسیون8تا 10متر** | 12d | 2017-09-12 | 2017-09-23 |  | 7d |  |  | 96/6/21 | 96/7/1 |
| 81 | 2.1.3.5.1 | مش بندی و شاتکریت تا تراز فونداسیون، پارت اول (یو شکل شرقی)،8تا 10متر | 3d | 2017-09-12 | 2017-09-14 | 45, 79 | 7d | 0d | start no earlier than 2017-05-29 | 96/6/21 | 96/6/23 |
| 82 | 2.1.3.5.2 | مش بندی و شاتکریت تا تراز فونداسیون، پارت دوم، 8تا 10متر | 3d | 2017-09-15 | 2017-09-17 | 45, 81 | 7d | 0d | start no earlier than 2017-05-29 | 96/6/24 | 96/6/26 |
| 83 | 2.1.3.5.3 | مش بندی و شاتکریت تا تراز فونداسیون، پارت سوم،8تا 10متر | 3d | 2017-09-18 | 2017-09-20 | 46, 82 | 7d | 0d | start no earlier than 2017-05-29 | 96/6/27 | 96/6/29 |
| 84 | 2.1.3.5.4 | مش بندی و شاتکریت تراز فونداسیون، پارت چهارم (یو شکل غربی)،8تا 10متر | 3d | 2017-09-21 | 2017-09-23 | 47, 83 | 7d | 1d | start no earlier than 2017-05-29 | 96/6/30 | 96/7/1 |
| 85 | 2.1.3.6 | **مش بندی و شاتکریت تا تراز فونداسیون10تا 12/5متر** | 29d | 2017-09-25 | 2017-10-23 |  | 0d |  |  | 96/7/3 | 96/8/1 |
| 86 | 2.1.3.6.1 | مش بندی و شاتکریت تا تراز فونداسیون، پارت اول (یو شکل شرقی)،10تا 12/5متر | 3d | 2017-09-25 | 2017-09-27 | 50, 84 | 17d | 0d | start no earlier than 2017-05-29 | 96/7/3 | 96/7/5 |
| 87 | 2.1.3.6.2 | مش بندی و شاتکریت تا تراز فونداسیون، پارت دوم، 10تا 12/5متر | 3d | 2017-09-28 | 2017-09-30 | 86, 51 | 17d | 0d | start no earlier than 2017-05-29 | 96/7/6 | 96/7/8 |
| 88 | 2.1.3.6.3 | مش بندی و شاتکریت تا تراز فونداسیون، پارت سوم،10تا 12/5متر | 3d | 2017-10-01 | 2017-10-03 | 87, 52 | 17d |  | start no earlier than 2017-05-29 | 96/7/9 | 96/7/11 |
| 89 | 2.1.3.6.4 | مش بندی و شاتکریت تا تراز فونداسیون، پارت چهارم (یو شکل غربی)،10تا 12/5متر | 3d | 2017-10-21 | 2017-10-23 | 88, 53 | 0d |  | start no earlier than 2017-05-29 | 96/7/29 | 96/8/1 |
| 90 | 3 | **اجراي فونداسيون** | 51d | 2017-10-19 | 2017-12-08 |  | 0d |  |  | 96/7/27 | 96/9/17 |
| 91 | 3.1 | **پارت اول** | 16d | 2017-10-19 | 2017-11-03 |  | 0d |  |  | 96/7/27 | 96/8/12 |
| 92 | 3.1.1 | رگلاژ كف پارت اول یو شکل شرقی | 1d | 2017-10-19 | 2017-10-19 | 50, 86, 20FS+10d | 0d |  | start no earlier than 2017-05-29 | 96/7/27 | 96/7/27 |
| 93 | 3.1.2 | اجراي سيستم زهكشي پارت اول یو شکل شرقی | 2d | 2017-10-20 | 2017-10-21 | 92, 6FS+10d, 12, 16 | 0d |  | start no earlier than 2017-05-29 | 96/7/28 | 96/7/29 |
| 94 | 3.1.3 | اجراي ارتينگ پارت اول یو شکل شرقی | 2d | 2017-10-20 | 2017-10-21 | 93SS, 15 | 0d |  | start no earlier than 2017-05-29 | 96/7/28 | 96/7/29 |
| 95 | 3.1.4 | اجراي بتن مگر پارت اول یو شکل شرقی | 1d | 2017-10-22 | 2017-10-22 | 94 | 0d |  | start no earlier than 2017-05-29 | 96/7/30 | 96/7/30 |
| 96 | 3.1.5 | اجراي عايقكاري پارت اول یو شکل شرقی | 2d | 2017-10-23 | 2017-10-24 | 95, 86, 19FS+10d, 18 | 0d |  | start no earlier than 2017-05-29 | 96/8/1 | 96/8/2 |
| 97 | 3.1.6 | اجراي ملات پارت اول یو شکل شرقی | 1d | 2017-10-25 | 2017-10-25 | 96 | 0d |  | start no earlier than 2017-05-29 | 96/8/3 | 96/8/3 |
| 98 | 3.1.7 | آرماتور بندي فونداسيون پارت اول یو شکل شرقی | 8d | 2017-10-26 | 2017-11-02 | 95, 97, 3FS+10d, 5FS+5d, 13FS+15d, 17FS+15d | 0d |  | start no earlier than 2017-05-29 | 96/8/4 | 96/8/11 |
| 99 | 3.1.8 | قالب بندي فونداسيون پارت اول یو شکل شرقی | 3d | 2017-10-31 | 2017-11-02 | 98FF | 23d | 0d | start no earlier than 2017-05-29 | 96/8/9 | 96/8/11 |
| 100 | 3.1.9 | بتن ريزي فونداسيون پارت اول یو شکل شرقی | 1d | 2017-11-03 | 2017-11-03 | 99 | 31d | 10d | start no earlier than 2017-05-29 | 96/8/12 | 96/8/12 |
| 101 | 3.2 | **پارت دوم** | 26d | 2017-10-20 | 2017-11-14 |  | 7d |  |  | 96/7/28 | 96/8/23 |
| 102 | 3.2.1 | رگلاژ كف پارت دوم | 1d | 2017-10-20 | 2017-10-20 | 92, 50, 86 | 7d | 0d | start no earlier than 2017-05-29 | 96/7/28 | 96/7/28 |
| 103 | 3.2.2 | اجراي سيستم زهكشي پارت دوم | 2d | 2017-10-22 | 2017-10-23 | 93, 102 | 6d | 0d | start no earlier than 2017-05-29 | 96/7/30 | 96/8/1 |
| 104 | 3.2.3 | اجراي ارتينگ پارت دوم | 2d | 2017-10-22 | 2017-10-23 | 94, 103SS | 6d | 0d | start no earlier than 2017-05-29 | 96/7/30 | 96/8/1 |
| 105 | 3.2.4 | اجراي بتن مگرپارت دوم | 1d | 2017-10-24 | 2017-10-24 | 95, 104 | 6d | 0d | start no earlier than 2017-05-29 | 96/8/2 | 96/8/2 |
| 106 | 3.2.5 | اجراي عايقكاري پارت دوم | 2d | 2017-10-25 | 2017-10-26 | 96, 105, 86 | 6d | 0d | start no earlier than 2017-05-29 | 96/8/3 | 96/8/4 |
| 107 | 3.2.6 | اجراي ملات پارت دوم | 1d | 2017-10-27 | 2017-10-27 | 106 | 6d | 1d | start no earlier than 2017-05-29 | 96/8/5 | 96/8/5 |
| 108 | 3.2.7 | آرماتور بندي فونداسيون پارت دوم | 8d | 2017-11-03 | 2017-11-10 | 98, 105, 107 | 0d |  | start no earlier than 2017-05-29 | 96/8/12 | 96/8/19 |
| 109 | 3.2.8 | قالب بندي فونداسيون پارت دوم | 3d | 2017-11-11 | 2017-11-13 | 99, 108 | 15d | 0d | start no earlier than 2017-05-29 | 96/8/20 | 96/8/22 |
| 110 | 3.2.9 | بتن ريزي فونداسيون پارت دوم | 1d | 2017-11-14 | 2017-11-14 | 100, 109 | 21d | 7d | start no earlier than 2017-05-29 | 96/8/23 | 96/8/23 |

| ID | WBS | Task | Duration | Start | Finish | Predecessors | Total slack | Free slack | Constraint | start. | finish. |
| --- | --- | --- | --- | --- | --- | --- | --- | --- | --- | --- | --- |
| 111 | 3.3 | **پارت سوم** | 33d | 2017-10-21 | 2017-11-22 |  | 14d |  |  | 96/7/29 | 96/9/1 |
| 112 | 3.3.1 | رگلاژ كف پارت سوم | 1d | 2017-10-21 | 2017-10-21 | 102, 51, 87 | 14d | 0d | start no earlier than 2017-05-29 | 96/7/29 | 96/7/29 |
| 113 | 3.3.2 | اجراي سيستم زهكشي پارت سوم | 2d | 2017-10-24 | 2017-10-25 | 103, 112 | 12d | 0d | start no earlier than 2017-05-29 | 96/8/2 | 96/8/3 |
| 114 | 3.3.3 | اجراي ارتينگ پارت سوم | 2d | 2017-10-24 | 2017-10-25 | 104, 113SS | 12d | 0d | start no earlier than 2017-05-29 | 96/8/2 | 96/8/3 |
| 115 | 3.3.4 | اجراي بتن مگر پارت سوم | 1d | 2017-10-26 | 2017-10-26 | 105, 114 | 12d | 0d | start no earlier than 2017-05-29 | 96/8/4 | 96/8/4 |
| 116 | 3.3.5 | اجراي عايقكاري پارت سوم | 2d | 2017-10-27 | 2017-10-28 | 106, 115, 87 | 12d | 0d | start no earlier than 2017-05-29 | 96/8/5 | 96/8/6 |
| 117 | 3.3.6 | اجراي ملات پارت سوم | 1d | 2017-10-29 | 2017-10-29 | 107, 116 | 12d |  | start no earlier than 2017-05-29 | 96/8/7 | 96/8/7 |
| 118 | 3.3.7 | آرماتور بندي فونداسيون پارت سوم | 8d | 2017-11-11 | 2017-11-18 | 108, 115, 117 | 0d |  | start no earlier than 2017-05-29 | 96/8/20 | 96/8/27 |
| 119 | 3.3.8 | قالب بندي فونداسيون پارت سوم | 3d | 2017-11-19 | 2017-11-21 | 109, 118 | 10d | 0d | start no earlier than 2017-05-29 | 96/8/28 | 96/8/30 |
| 120 | 3.3.9 | بتن ريزي فونداسيون پارت سوم | 1d | 2017-11-22 | 2017-11-22 | 110, 119 | 14d | 7d | start no earlier than 2017-05-29 | 96/9/1 | 96/9/1 |
| 121 | 3.4 | **پارت چهارم** | 40d | 2017-10-22 | 2017-11-30 |  | 7d |  |  | 96/7/30 | 96/9/9 |
| 122 | 3.4.1 | رگلاژ كف پارت چهارم | 1d | 2017-10-22 | 2017-10-22 | 112, 51, 87 | 21d | 0d | start no earlier than 2017-05-29 | 96/7/30 | 96/7/30 |
| 123 | 3.4.2 | اجراي سيستم زهكشي پارت چهارم | 2d | 2017-10-26 | 2017-10-27 | 113, 122 | 18d | 0d | start no earlier than 2017-05-29 | 96/8/4 | 96/8/5 |
| 124 | 3.4.3 | اجراي ارتينگ پارت چهارم | 2d | 2017-10-26 | 2017-10-27 | 123SS | 18d | 0d | start no earlier than 2017-05-29 | 96/8/4 | 96/8/5 |
| 125 | 3.4.4 | اجراي بتن مگر پارت چهارم | 1d | 2017-10-28 | 2017-10-28 | 115, 123, 124 | 18d | 0d | start no earlier than 2017-05-29 | 96/8/6 | 96/8/6 |
| 126 | 3.4.5 | اجراي عايقكاري پارت چهارم | 2d | 2017-10-29 | 2017-10-30 | 125, 87 | 18d | 0d | start no earlier than 2017-05-29 | 96/8/7 | 96/8/8 |
| 127 | 3.4.6 | اجراي ملات پارت چهارم | 1d | 2017-10-31 | 2017-10-31 | 126 | 18d |  | start no earlier than 2017-05-29 | 96/8/9 | 96/8/9 |
| 128 | 3.4.7 | آرماتور بندي فونداسيون پارت چهارم | 8d | 2017-11-19 | 2017-11-26 | 118, 125, 127 | 0d |  | start no earlier than 2017-05-29 | 96/8/28 | 96/9/5 |
| 129 | 3.4.8 | قالب بندي فونداسيون پارت چهارم | 3d | 2017-11-27 | 2017-11-29 | 119, 128 | 5d | 0d | start no earlier than 2017-05-29 | 96/9/6 | 96/9/8 |
| 130 | 3.4.9 | بتن ريزي پارت چهارم | 1d | 2017-11-30 | 2017-11-30 | 120, 129 | 7d |  | start no earlier than 2017-05-29 | 96/9/9 | 96/9/9 |
| 131 | 3.5 | **پارت پنجم** | 47d | 2017-10-23 | 2017-12-08 |  | 0d |  |  | 96/8/1 | 96/9/17 |
| 132 | 3.5.1 | رگلاژ كف پارت پنجم | 1d | 2017-10-23 | 2017-10-23 | 122, 52, 88 | 26d | 4d | start no earlier than 2017-05-29 | 96/8/1 | 96/8/1 |
| 133 | 3.5.2 | اجراي سيستم زهكشي پارت پنجم | 2d | 2017-10-28 | 2017-10-29 | 123, 132 | 22d | 0d | start no earlier than 2017-05-29 | 96/8/6 | 96/8/7 |
| 134 | 3.5.3 | اجراي ارتينگ پارت پنجم | 2d | 2017-10-28 | 2017-10-29 | 133SS | 24d | 0d | start no earlier than 2017-05-29 | 96/8/6 | 96/8/7 |
| 135 | 3.5.4 | اجراي بتن مگر پارت پنجم | 1d | 2017-10-30 | 2017-10-30 | 133, 134 | 24d | 0d | start no earlier than 2017-05-29 | 96/8/8 | 96/8/8 |
| 136 | 3.5.5 | اجراي عايقكاري پارت پنجم | 2d | 2017-10-31 | 2017-11-01 | 135, 88 | 24d | 0d | start no earlier than 2017-05-29 | 96/8/9 | 96/8/10 |
| 137 | 3.5.6 | اجراي ملات پارت پنجم | 1d | 2017-11-02 | 2017-11-02 | 136 | 24d |  | start no earlier than 2017-05-29 | 96/8/11 | 96/8/11 |
| 138 | 3.5.7 | آرماتور بندي فونداسيون پارت پنجم | 8d | 2017-11-27 | 2017-12-04 | 128, 135, 137 | 0d |  | start no earlier than 2017-05-29 | 96/9/6 | 96/9/13 |
| 139 | 3.5.8 | قالب بندي فونداسيون پارت پنجم | 3d | 2017-12-05 | 2017-12-07 | 129, 138 | 0d |  | start no earlier than 2017-05-29 | 96/9/14 | 96/9/16 |
| 140 | 3.5.9 | بتن ريزي پارت پنجم | 1d | 2017-12-08 | 2017-12-08 | 130, 139 | 0d |  | start no earlier than 2017-05-29 | 96/9/17 | 96/9/17 |

| ID | WBS | Task | Type | Duration | Start | Finish | Predecessors | Total slack | Free slack | Constraint | start. | finish. |
| --- | --- | --- | --- | --- | --- | --- | --- | --- | --- | --- | --- | --- |
| 141 | 3.6 | **پارت ششم** |  | 43d | 2017-10-27 | 2017-12-08 |  | 0d |  |  | 96/8/5 | 96/9/17 |
| 142 | 3.6.1 | رگلاژ كف پارت ششم |  | 1d | 2017-10-27 | 2017-10-27 | 52, 152, 88 | 24d | 2d | start no earlier than 2017-05-29 | 96/8/5 | 96/8/5 |
| 143 | 3.6.2 | اجراي سيستم زهكشي پارت ششم |  | 2d | 2017-10-30 | 2017-10-31 | 142, 133 | 22d | 0d | start no earlier than 2017-05-29 | 96/8/8 | 96/8/9 |
| 144 | 3.6.3 | اجراي ارتينگ پارت ششم |  | 2d | 2017-10-30 | 2017-10-31 | 143SS | 22d | 0d | start no earlier than 2017-05-29 | 96/8/8 | 96/8/9 |
| 145 | 3.6.4 | اجراي بتن مگر پارت ششم |  | 1d | 2017-11-01 | 2017-11-01 | 143, 144, 155 | 22d | 1d | start no earlier than 2017-05-29 | 96/8/10 | 96/8/10 |
| 146 | 3.6.5 | اجراي عايقكاري پارت ششم |  | 2d | 2017-11-03 | 2017-11-04 | 145, 156, 88 | 21d | 0d | start no earlier than 2017-05-29 | 96/8/12 | 96/8/13 |
| 147 | 3.6.6 | اجراي ملات پارت ششم |  | 1d | 2017-11-05 | 2017-11-05 | 146, 157 | 21d |  | start no earlier than 2017-05-29 | 96/8/14 | 96/8/14 |
| 148 | 3.6.7 | آرماتور بندي فونداسيون پارت ششم |  | 8d | 2017-11-27 | 2017-12-04 | 145, 147, 158 | 0d |  | start no earlier than 2017-05-29 | 96/9/6 | 96/9/13 |
| 149 | 3.6.8 | قالب بندي فونداسيون پارت ششم |  | 3d | 2017-12-05 | 2017-12-07 | 148, 159 | 0d |  |  | 96/9/14 | 96/9/16 |
| 150 | 3.6.9 | بتن ريزي پارت ششم |  | 1d | 2017-12-08 | 2017-12-08 | 149, 160 | 0d |  |  | 96/9/17 | 96/9/17 |
| 151 | 3.7 | **پارت هفتم** |  | 36d | 2017-10-26 | 2017-11-30 |  | 7d |  |  | 96/8/4 | 96/9/9 |
| 152 | 3.7.1 | رگلاژ كف پارت هفتم |  | 1d | 2017-10-26 | 2017-10-26 | 53, 162, 89 | 17d | 0d | start no earlier than 2017-05-29 | 96/8/4 | 96/8/4 |
| 153 | 3.7.2 | اجراي سيستم زهكشي پارت هفتم |  | 2d | 2017-10-29 | 2017-10-30 | 152, 163 | 15d | 0d | start no earlier than 2017-05-29 | 96/8/7 | 96/8/8 |
| 154 | 3.7.3 | اجراي ارتينگ پارت هفتم |  | 2d | 2017-10-29 | 2017-10-30 | 153SS | 15d | 0d | start no earlier than 2017-05-29 | 96/8/7 | 96/8/8 |
| 155 | 3.7.4 | اجراي بتن مگر پارت هفتم |  | 1d | 2017-10-31 | 2017-10-31 | 153, 154, 165 | 15d | 0d | start no earlier than 2017-05-29 | 96/8/9 | 96/8/9 |
| 156 | 3.7.5 | اجراي عايقكاري پارت هفتم |  | 2d | 2017-11-01 | 2017-11-02 | 155, 166, 89 | 15d | 0d | start no earlier than 2017-05-29 | 96/8/10 | 96/8/11 |
| 157 | 3.7.6 | اجراي ملات پارت هفتم |  | 1d | 2017-11-03 | 2017-11-03 | 156, 167 | 15d | 1d | start no earlier than 2017-05-29 | 96/8/12 | 96/8/12 |
| 158 | 3.7.7 | آرماتور بندي فونداسيون پارت هفتم |  | 8d | 2017-11-19 | 2017-11-26 | 155, 157, 170 | 0d |  | start no earlier than 2017-05-29 | 96/8/28 | 96/9/5 |
| 159 | 3.7.8 | قالب بندي فونداسيون پارت هفتم |  | 3d | 2017-11-27 | 2017-11-29 | 158, 169 | 5d | 0d | start no earlier than 2017-05-29 | 96/9/6 | 96/9/8 |
| 160 | 3.7.9 | بتن ريزي پارت هفتم |  | 1d | 2017-11-30 | 2017-11-30 | 159, 170 | 7d |  | start no earlier than 2017-05-29 | 96/9/9 | 96/9/9 |
| 161 | 3.8 | **پارت هشتم** |  | 26d | 2017-10-24 | 2017-11-18 |  | 0d |  |  | 96/8/2 | 96/8/27 |
| 162 | 3.8.1 | رگلاژ كف پارت هشتم یو شکل غربی |  | 2d | 2017-10-24 | 2017-10-25 | 53, 89 | 0d |  | start no earlier than 2017-05-29 | 96/8/2 | 96/8/3 |
| 163 | 3.8.2 | اجراي سيستم زهكشي پارت هشتم یو شکل غربی |  | 3d | 2017-10-26 | 2017-10-28 | 162 | 0d |  | start no earlier than 2017-05-29 | 96/8/4 | 96/8/6 |
| 164 | 3.8.3 | اجراي ارتينگ پارت هشتم یو شکل غربی |  | 3d | 2017-10-26 | 2017-10-28 | 163SS | 0d |  | start no earlier than 2017-05-29 | 96/8/4 | 96/8/6 |
| 165 | 3.8.4 | اجراي بتن مگر پارت هشتم یو شکل غربی |  | 1d | 2017-10-29 | 2017-10-29 | 163, 164 | 0d |  | start no earlier than 2017-05-29 | 96/8/7 | 96/8/7 |
| 166 | 3.8.5 | اجراي عايقكاري پارت هشتم یو شکل غربی |  | 2d | 2017-10-30 | 2017-10-31 | 165, 89 | 0d |  | start no earlier than 2017-05-29 | 96/8/8 | 96/8/9 |
| 167 | 3.8.6 | اجراي ملات پارت هشتم یو شکل غربی |  | 2d | 2017-11-01 | 2017-11-02 | 166 | 0d |  | start no earlier than 2017-05-29 | 96/8/10 | 96/8/11 |
| 168 | 3.8.7 | آرماتور بندي فونداسيون پارت هشتم یو شکل غربی |  | 8d | 2017-11-03 | 2017-11-10 | 165, 167 | 0d |  | start no earlier than 2017-05-29 | 96/8/12 | 96/8/19 |
| 169 | 3.8.8 | قالب بندي فونداسيون پارت هشتم یو شکل غربی |  | 6d | 2017-11-11 | 2017-11-16 | 168 | 0d |  | start no earlier than 2017-05-29 | 96/8/20 | 96/8/25 |
| 170 | 3.8.9 | بتن ريزي پارت هشتم یو شکل غربی |  | 2d | 2017-11-17 | 2017-11-18 | 169 | 0d |  | start no earlier than 2017-05-29 | 96/8/26 | 96/8/27 |
| 171 | 3.9 | پایان فعالیت | milestone | 0d | 2017-12-08 | 2017-12-08 | 140, 150 | 0d |  |  | 96/9/17 | 96/9/17 |
